# Muon Accelerator Program

Schedule from MS Project, 2011-10-01 to 2018-11-16, status date 2013-03-31, costs in $, A marks actual dates.
FNAL

## Calendars

- Standard: Mon-Fri 08:00-12:00, 13:00-17:00; Sat-Sun off. Exceptions (off unless hours are given): 2011-11-24 (Thanksgiving Day), 2011-11-25 (Day After Thanksgiving), 2011-12-23 (Christmas Eve), 2011-12-26 (Christmas Day), 2011-12-30 (New Years Eve), 2012-01-02 (New Years Day), 2012-01-16 (Martin Luther King Day), 2012-05-28 (Memorial Day), 2012-07-04 (Independence Day), 2012-09-03 (Labor Day), 2012-11-22 (Thanksgiving Day), 2012-11-23 (Day After Thanksgiving), 2012-12-24 (Christmas Eve), 2012-12-25 (Christmas Day), 2012-12-31 (New Years Eve), 2013-01-01 (New Years Day), 2013-01-21 (Martin Luther King Day), 2013-05-27 (Memorial Day, recurring), 2013-07-04, 2013-09-02 (Labor Day), 2013-11-28 (Thanksgiving Day), 2013-11-29 (Day After Thanksgiving), 2013-12-24 (Christmas Eve), 2013-12-25 (Christmas Day), 2013-12-31 (New Years Eve), 2014-01-01 (New Years Day), 2014-01-20 (Martin Luther King Day), 2014-05-26 (Memorial Day, recurring), 2014-07-04 (Independence Day), 2014-09-01 (Labor Day), 2014-11-27 (Thanksgiving Day), 2014-11-28 (Day After Thanksgiving), 2014-12-24 (Christmas Eve), 2014-12-25 (Christmas Day), 2014-12-31 (New Years Eve), 2015-01-01 (New Years Day), 2015-01-19 (Martin Luther King Day), 2015-05-25 (Memorial Day), 2015-07-03 (Independence Day), 2015-09-07 (Labor Day), 2015-11-26 (Thanksgiving), 2015-11-27 (Day After Thanksgiving), 2015-12-24 (Christmas Eve), 2015-12-25 (Christmas Day), 2015-12-31 (New Years Eve), 2016-01-01 (New Years Day, recurring), 2016-01-18 (Martin Luther King Day), 2016-05-30 (Memorial Day, recurring), 2016-07-04 (Independence Day), 2016-09-05 (Labor Day), 2016-11-24 (Thanksgiving Day), 2016-11-25 (Day After Thanksgiving), 2016-12-23 (Christmas Eve), 2016-12-26 (Christmas Day), 2016-12-30 (New Years Eve), 2017-01-02 (New Years Day), 2017-01-16 (Martin Luther King Day, recurring), 2017-05-29 (Memorial Day), 2017-07-04 (Independence Day), 2017-09-04 (Labor Day), 2017-11-23 (Thanksgiving Day), 2017-11-24 (Day After Thanksgiving), 2017-12-22 (Christmas Eve), 2017-12-25 (Christmas Day), 2017-12-29 (New Years Eve), 2018-01-01 (New Years Day), 2018-01-15 (Martin Luther King Day), 2018-05-31 (Memorial Day), 2018-07-04 (Independence Day), 2018-09-03 (Labor Day).

## Resources

| Resource | Group | Rate | Notes |
| --- | --- | --- | --- |
| FNAP_MECH_DESIGN_EN | FNAL | 156 |  |
| FNAD_MECH_DESIGNER | FNAL | 113 |  |
| FNTD_WELDER | FNAL | 114 |  |
| FNAD_MECH_SYSTM_TECH | FNAL | 83 | $ Mechanical Assembly Technicians are available at any given time |
| FNAP_ELTN_DESIGN_EN | FNAL | 158 |  |
| FNAD_ELEC_TECH | FNAL | 97 |  |
| FNAP_PRJ_MNGR_SR | FNAL | 262 |  |
| FNPD_PRJ_CTRL_LEAD | FNAL | 136 |  |
| FNAP_ADMIN_SPPRT | FNAL | 83 |  |
| FNAD_PRJ_FINANCE | FNAL | 147 |  |
| FNAD_CRYO_EN | FNAL | 158 |  |
| FNAD_MECH_TECH_SPVSR | FNAL | 136 |  |
| FNAD_MECH_DRAFTER | FNAL | 68 |  |
| FNAP_ENGNRING_PHYST | FNAL | 168 |  |
| FNAD_GENERAL_ES&H |  | 163 |  |
| FNTD_MACHINIST |  | 114 |  |
| FN_M&S_STND_FY12 |  |  |  |
| FN_M&S_TRVL_FY12 |  |  |  |
| FNAP_PRJ_MNGR |  | 174 |  |
| LBNL_ELEC_TECH |  |  |  |
| LBNL_MECH_TECH |  |  |  |
| LBNL_METROLOGIST |  |  |  |
| WANG_MECH_TECH |  |  |  |
| WANG_WELDER |  |  |  |
| FNAP_PT_EXP_PHYST |  | 153 |  |
| FNAL_ALEXAHIN |  | 153 |  |
| FNAL_ANKENBRANDT |  | 153 |  |
| FNAL_GIANFELICE |  | 153 |  |
| FNAL_GOLLWITZER |  | 153 |  |
| FNAL_LEBEDEV |  | 153 |  |
| FNAL_NEUFFER |  | 153 |  |
| FNAL_POPOVIC |  | 153 |  |
| BNL_BERG |  |  |  |
| JLAB_BOGACZ |  |  |  |
| BNL_SAYED |  |  |  |
| BNL_STRATAKIS |  |  |  |
| FNAL_SNOPOK |  | 153 |  |
| BNL_KIRK |  |  |  |
| PBL_WEGGEL |  |  |  |
| PBL_SOUCHLAS |  |  |  |
| LBNL_RYNE |  |  |  |
| LBNL_QIANG |  |  |  |
| FNFE_CFS_DESIGN_EN |  | 141 |  |
| FNAD_MAGNT_DESIGN_EN |  | 178 |  |
| JLAB_M&S |  |  |  |
| BNL_M&S |  |  |  |
| FNTD_MAGNT_SCIENTIST |  | 163 |  |
| FNAL_KAPIN |  | 153 |  |
| FNAL_BALBEKOV |  | 153 |  |
| FNAL_BUROV |  | 153 |  |
| FNAL_MOKHOV |  | 153 |  |
| FNAL_STRIGANOV |  | 153 |  |
| FNAL_TROPIN |  | 153 |  |
| SLAC_TERENTIEV |  |  |  |
| FNAL_LIPTON |  | 153 |  |
| MUON_ROBERTS |  |  |  |
| FNAL_YONEHARA |  | 153 |  |
| MUON_YOSHIKAWA |  |  |  |
| MUON_FLANAGAN |  |  |  |
| FNAD_SAFETY |  | 145 |  |
| FNAD_ELTN_TECH |  | 105 |  |
| FNAD_ELEC_DESIGN_EN |  | 153 |  |
| FNAD_AC_EXP_PHYST |  | 168 |  |
| FNPD_METROLOGIST |  | 92 |  |
| FNAL_TM_ELEC |  | 119 |  |
| FNAD_PRJ_FINANCE_NOCOST |  |  |  |
| FNAP_ADMIN_SPPRT_NOCOST |  |  |  |
| FNAP_PRJ_MNGR_NOCOST |  |  |  |
| BNL_PHYSICIST |  |  |  |
| LBNL_M&S |  |  |  |
| BNL_MECH_ENG |  |  |  |
| BNL_MECH_TECH |  |  |  |
| LBNL_MECH_ENG |  |  |  |
| LBNL_WELDER |  |  |  |
| BNL_LABOR |  |  |  |
| JLAB_LABOR |  |  |  |
| LBNL_LABOR |  |  |  |
| MUON_LABOR |  |  |  |
| MUON_M&S |  |  |  |
| PBL_LABOR |  |  |  |
| PBL_M&S |  |  |  |
| SLAC_LABOR |  |  |  |
| SLAC_M&S |  |  |  |
| WANG_LABOR |  |  |  |
| WANG_M&S |  |  |  |
| BNL_M&S_TRVL |  |  |  |
| JLAB_M&S_TRVL |  |  |  |
| LBNL_M&S_TRVL |  |  |  |
| MUON_M&S_TRVL |  |  |  |
| PBL_M&S_TRVL |  |  |  |
| SLAC_M&S_TRVL |  |  |  |
| WANG_M&S_TRVL |  |  |  |
| LBNL_SCIENTIST |  |  |  |
| LBNL_POSTDOC |  |  |  |
| FNUN_P_POSTDOC |  | 94 |  |
| BNL_ADMIN |  |  |  |
| FNAL_MICE_CONT_LABOR_M&S |  |  |  |
| FNAL_MICE_CONT_M&S |  |  |  |

## Schedule

| ID | WBS | Task | Type | Duration | Start | Finish | Predecessors | Complete | Remaining | Baseline start | Baseline finish | Baseline duration | Total slack | Free slack | Work | Actual work | Cost | Baseline cost | Actual cost | MAP WBS | WBS-L3 Text18 | BOE Number | CobraUID | Resp Instit Name/Code | Funding Type |
| --- | --- | --- | --- | --- | --- | --- | --- | --- | --- | --- | --- | --- | --- | --- | --- | --- | --- | --- | --- | --- | --- | --- | --- | --- | --- |
| 1 | 1 | **Muon Accelerator Program** |  | 1790d | 2011-10-01 A | 2018-11-16 |  | 16% | 1504.88d | 2011-10-01 | 2018-11-16 | 1790d | 0d |  | 70882.1h | 5811.6h | 15,993,658 | 15,993,658 | 1,425,492.4 | 29M |  |  |  |  |  |
| 2 | 1.01 | **Program Management** |  | 1755d | 2011-10-01 A | 2018-09-28 |  | 21% | 1379.5d | 2011-10-01 | 2018-09-28 | 1755d | 35d |  |  |  |  |  |  | 29M.01 | 10 |  |  |  |  |
| 3 | 1.01.01 | **Program Coordination and Activities** |  | 1755d | 2011-10-01 A | 2018-09-28 |  | 21% | 1379.5d | 2011-10-01 | 2018-09-28 | 1755d | 35d |  |  |  |  |  |  | 29M.01.01 | 11 | BOE-1.01.01 |  |  |  |
| 4 | 1.01.01.01 | **Project Management for Program Coordination and Activities** |  | 1755d | 2011-10-03 A | 2018-09-28 |  | 21% | 1379.5d | 2011-10-03 | 2018-09-28 | 1755d | 35d |  |  |  |  |  |  |  | 11 |  | 592 |  |  |
| 5 | 1.01.01.01.01 | FY12 Project Management - LOE (FNAL - Labor) |  | 250d | 2011-10-03 A | 2012-09-28 A | 19 | 100% |  | 2011-10-03 | 2012-09-28 | 250d |  |  |  |  |  |  |  |  | 11 |  | 593 | ܁= | ܁" |
| 6 | 1.01.01.01.02 | FY12 Project Management - LOE (FNAL - M&S) |  | 250d | 2011-10-03 A | 2012-09-28 A | 5SS | 100% |  | 2011-10-03 | 2012-09-28 | 250d |  |  |  |  |  |  |  |  | 11 |  | 594 | ܁= | ܁" |
| 7 | 1.01.01.01.03 | FY13 Project Management - LOE (FNAL - Labor) |  | 251d | 2012-10-01 A | 2013-09-30 | 5 | 50% | 125.5d | 2012-10-01 | 2013-09-30 | 251d | 35d | 0d |  |  |  |  |  |  | 11 |  | 595 | ܁= | ܁" |
| 8 | 1.01.01.01.04 | FY13 Project Management - LOE (FNAL - M&S) |  | 251d | 2012-10-01 A | 2013-09-30 | 6 | 50% | 125.5d | 2012-10-01 | 2013-09-30 | 251d | 35d | 0d |  |  |  |  |  |  | 11 |  | 596 | ܁= | ܁" |
| 9 | 1.01.01.01.05 | FY14 Project Management - LOE (FNAL - Labor) |  | 251d | 2013-10-01 | 2014-09-30 | 7 |  |  | 2013-10-01 | 2014-09-30 | 251d | 35d | 0d |  |  |  |  |  |  | 11 |  | 597 | ܁= | ܁" |
| 10 | 1.01.01.01.06 | FY14 Project Management - LOE (FNAL - M&S) |  | 251d | 2013-10-01 | 2014-09-30 | 8 |  |  | 2013-10-01 | 2014-09-30 | 251d | 35d | 0d |  |  |  |  |  |  | 11 |  | 598 | ܁= | ܁" |
| 11 | 1.01.01.01.07 | FY15 Project Management - LOE (FNAL - Labor) |  | 251d | 2014-10-01 | 2015-09-30 | 9 |  |  | 2014-10-01 | 2015-09-30 | 251d | 35d | 0d |  |  |  |  |  |  | 11 |  | 599 | ܁= | ܁" |
| 12 | 1.01.01.01.08 | FY15 Project Management - LOE (FNAL - M&S) |  | 251d | 2014-10-01 | 2015-09-30 | 10 |  |  | 2014-10-01 | 2015-09-30 | 251d | 35d | 0d |  |  |  |  |  |  | 11 |  | 600 | ܁= | ܁" |
| 13 | 1.01.01.01.09 | FY16 Project Management - LOE (FNAL - Labor) |  | 252d | 2015-10-01 | 2016-09-30 | 11 |  |  | 2015-10-01 | 2016-09-30 | 252d | 35d | 0d |  |  |  |  |  |  | 11 |  | 601 | ܁= | ܁" |
| 14 | 1.01.01.01.10 | FY16 Project Management - LOE (FNAL - M&S) |  | 252d | 2015-10-01 | 2016-09-30 | 12 |  |  | 2015-10-01 | 2016-09-30 | 252d | 35d | 0d |  |  |  |  |  |  | 11 |  | 602 | ܁= | ܁" |
| 15 | 1.01.01.01.11 | FY17 Project Management - LOE (FNAL - Labor) |  | 250d | 2016-10-03 | 2017-09-29 | 13 |  |  | 2016-10-03 | 2017-09-29 | 250d | 35d | 0d |  |  |  |  |  |  | 11 |  | 603 | ܁= | ܁" |
| 16 | 1.01.01.01.12 | FY17 Project Management - LOE (FNAL - M&S) |  | 250d | 2016-10-03 | 2017-09-29 | 14 |  |  | 2016-10-03 | 2017-09-29 | 250d | 35d | 0d |  |  |  |  |  |  | 11 |  | 604 | ܁= | ܁" |
| 17 | 1.01.01.01.13 | FY18 Project Management - LOE (FNAL - Labor) |  | 250d | 2017-10-02 | 2018-09-28 | 15 |  |  | 2017-10-02 | 2018-09-28 | 250d | 35d |  |  |  |  |  |  |  | 11 |  | 605 | ܁= | ܁" |
| 18 | 1.01.01.01.14 | FY18 Project Management - LOE (FNAL - M&S) |  | 250d | 2017-10-02 | 2018-09-28 | 16 |  |  | 2017-10-02 | 2018-09-28 | 250d | 35d |  |  |  |  |  |  |  | 11 |  | 606 | ܁= | ܁" |
| 19 | 1.01.01.02 | Start of Project 10-01-2011 (FY12) | milestone | 0d | 2011-10-01 A | 2011-10-01 A |  | 100% |  | 2011-10-01 | 2011-10-01 | 0d |  |  |  |  |  |  |  |  | 11 |  | 377 |  |  |
| 20 | 1.01.01.03 | Project Re-Organization 10-01-2012 (FY13) | milestone | 0d | 2012-10-01 | 2012-10-01 | 19FS+251d |  |  | 2012-10-01 | 2012-10-01 | 0d | 1539d |  |  |  |  |  |  |  | 11 |  | 378 |  |  |
| 21 | 1.01.01.04 | FY13 Funds Available | milestone | 0d | 2012-10-19 | 2012-10-19 | 19FS+265d |  |  | 2012-10-19 | 2012-10-19 | 0d | 35d | 0d |  |  |  |  |  |  | 11 |  | 451 |  |  |
| 22 | 1.01.01.05 | FY14 Funds Available | milestone | 0d | 2013-10-21 | 2013-10-21 | 19FS+516d |  |  | 2013-10-21 | 2013-10-21 | 0d | 1d | 0d |  |  |  |  |  |  | 11 |  | 403 |  |  |
| 23 | 1.01.01.06 | FY15 Funds Available | milestone | 0d | 2014-10-21 | 2014-10-21 | 19FS+767d |  |  | 2014-10-21 | 2014-10-21 | 0d | 12d | 0d |  |  |  |  |  |  | 11 |  | 404 |  |  |
| 24 | 1.01.01.07 | FY16 Funds Available | milestone | 0d | 2015-10-20 | 2015-10-20 | 19FS+1017d |  |  | 2015-10-20 | 2015-10-20 | 0d | 187d | 0d |  |  |  |  |  |  | 11 |  | 524 |  |  |
| 25 | 1.01.01.08 | FY17 Funds Available | milestone | 0d | 2016-10-20 | 2016-10-20 | 19FS+1269d |  |  | 2016-10-20 | 2016-10-20 | 0d | 146d | 0d |  |  |  |  |  |  | 11 |  | 525 |  |  |
| 26 | 1.01.01.09 | FY18 Funds Available | milestone | 0d | 2017-10-20 | 2017-10-20 | 19FS+1520d |  |  | 2017-10-20 | 2017-10-20 | 0d | 35d | 25d |  |  |  |  |  |  | 11 |  | 549 |  |  |
| 27 | 1.01.01.10 | End of Feasibility Assessment Funding | milestone | 0d | 2018-09-28 | 2018-09-28 | 19FS+1755d |  |  | 2018-09-28 | 2018-09-28 | 0d | 35d |  |  |  |  |  |  |  | 11 |  | 587 |  |  |
| 28 | 1.02 | Design and Simulations | milestone | 0d | 2011-10-01 | 2011-10-01 |  |  |  | 2011-10-01 | 2011-10-01 | 0d | 1790d |  |  |  |  |  |  | 29M.02 | 20 |  |  |  |  |
| 29 | 1.03 | Technology Development | milestone | 0d | 2011-10-01 | 2011-10-01 |  |  |  | 2011-10-01 | 2011-10-01 | 0d | 1790d |  |  |  |  |  |  | 29M.03 | 30 |  |  |  |  |
| 30 | 1.04 | Systems Demonstrations | milestone | 0d | 2011-10-01 | 2011-10-01 |  |  |  | 2011-10-01 | 2011-10-01 | 0d | 1790d |  |  |  |  |  |  | 29M.04 | 40 |  |  |  |  |

| ID | WBS | Task | Duration | Start | Finish | Predecessors | Complete | Remaining | Baseline start | Baseline finish | Baseline duration | Total slack | Free slack | Resources | Work | Actual work | Cost | Baseline cost | Actual cost | MAP WBS | CobraUID | WBS-L3 Text18 | BOE Number | Resp Instit Name/Code | Funding Type |
| --- | --- | --- | --- | --- | --- | --- | --- | --- | --- | --- | --- | --- | --- | --- | --- | --- | --- | --- | --- | --- | --- | --- | --- | --- | --- |
| 31 | 1.05 | **MICE Construction** | 1790d | 2011-10-03 A | 2018-11-16 |  | 15% | 1515.35d | 2011-10-03 | 2018-11-16 | 1790d | 0d |  |  | 70882.1h | 5811.6h | 15,993,658 | 15,993,658 | 1,425,492.4 | 29M.05 | 589 | 50 |  |  |  |
| 32 | 1.05.01 | **MICE RF Design, Fabrication and Testing** | 1505d | 2011-10-03 A | 2017-09-29 |  | 17% | 1248.7d | 2011-10-03 | 2017-09-29 | 1505d | 285d |  |  | 7241h | 185.5h | 3,192,910 | 3,192,910 | 134,160 | 29M.05.01 | 361 | 51 | BOE-1.05.01 |  |  |
| 33 | 1.05.01.01 | **MICE Engineering Oversight** | 1255d | 2012-10-01 A | 2017-09-29 |  | 10% | 1129.5d | 2012-10-01 | 2017-09-29 | 1255d | 285d |  |  | 1855h | 185.5h | 382,400 | 382,400 | 38,240 |  | 1080 | 51 |  |  |  |
| 34 | 1.05.01.01.01 | MICE Engineering Oversight FY13 (LBNL - Resources) | 251d | 2012-10-01 A | 2013-09-30 | 21FS-15d | 50% | 125.5d | 2012-10-01 | 2013-09-30 | 251d | 285d | 0d | LBNL_MECH_ENG; LBNL_SCIENTIST; LBNL_POSTDOC; LBNL_LABOR | 371h | 185.5h | 55,300 | 55,300 | 27,650 |  | 1081 | 51 |  | ܁A | ܁` |
| 35 | 1.05.01.01.02 | MICE Engineering Oversight FY13 (LBNL - M&S) | 251d | 2012-10-01 A | 2013-09-30 | 34SS | 50% | 125.5d | 2012-10-01 | 2013-09-30 | 251d | 285d | 0d | LBNL_M&S |  |  | 21,180 | 21,180 | 10,590 |  | 1082 | 51 |  | ܁A | ܁` |
| 36 | 1.05.01.01.03 | MICE Engineering Oversight FY14 (LBNL - Resources) | 251d | 2013-10-01 | 2014-09-30 | 34, 35 |  |  | 2013-10-01 | 2014-09-30 | 251d | 285d | 0d | LBNL_MECH_ENG; LBNL_SCIENTIST; LBNL_POSTDOC; LBNL_LABOR | 371h |  | 55,300 | 55,300 |  |  | 1083 | 51 |  | ܁A | ܁` |
| 37 | 1.05.01.01.04 | MICE Engineering Oversight FY14 (LBNL - M&S) | 251d | 2013-10-01 | 2014-09-30 | 36SS |  |  | 2013-10-01 | 2014-09-30 | 251d | 285d | 0d | LBNL_M&S |  |  | 21,180 | 21,180 |  |  | 1084 | 51 |  | ܁A | ܁` |
| 38 | 1.05.01.01.05 | MICE Engineering Oversight FY15 (LBNL - Resources) | 251d | 2014-10-01 | 2015-09-30 | 36, 37 |  |  | 2014-10-01 | 2015-09-30 | 251d | 285d | 0d | LBNL_MECH_ENG; LBNL_SCIENTIST; LBNL_POSTDOC; LBNL_LABOR | 371h |  | 55,300 | 55,300 |  |  | 1085 | 51 |  | ܁A | ܁` |
| 39 | 1.05.01.01.06 | MICE Engineering Oversight FY15 (LBNL - M&S) | 251d | 2014-10-01 | 2015-09-30 | 38SS |  |  | 2014-10-01 | 2015-09-30 | 251d | 285d | 0d | LBNL_M&S |  |  | 21,180 | 21,180 |  |  | 1086 | 51 |  | ܁A | ܁` |
| 40 | 1.05.01.01.07 | MICE Engineering Oversight FY16 (LBNL - Resources) | 252d | 2015-10-01 | 2016-09-30 | 38, 39 |  |  | 2015-10-01 | 2016-09-30 | 252d | 285d | 0d | LBNL_MECH_ENG; LBNL_SCIENTIST; LBNL_POSTDOC; LBNL_LABOR | 371h |  | 55,300 | 55,300 |  |  | 1087 | 51 |  | ܁A | ܁` |
| 41 | 1.05.01.01.08 | MICE Engineering Oversight FY16 (LBNL - M&S) | 252d | 2015-10-01 | 2016-09-30 | 40SS |  |  | 2015-10-01 | 2016-09-30 | 252d | 285d | 0d | LBNL_M&S |  |  | 21,180 | 21,180 |  |  | 1088 | 51 |  | ܁A | ܁` |
| 42 | 1.05.01.01.09 | MICE Engineering Oversight FY17 (LBNL - Resources) | 250d | 2016-10-03 | 2017-09-29 | 40, 41 |  |  | 2016-10-03 | 2017-09-29 | 250d | 285d | 0d | LBNL_MECH_ENG; LBNL_SCIENTIST; LBNL_POSTDOC; LBNL_LABOR | 371h |  | 55,300 | 55,300 |  |  | 1089 | 51 |  | ܁A | ܁` |
| 43 | 1.05.01.01.10 | MICE Engineering Oversight FY17 (LBNL - M&S) | 250d | 2016-10-03 | 2017-09-29 | 42SS |  |  | 2016-10-03 | 2017-09-29 | 250d | 285d |  | LBNL_M&S |  |  | 21,180 | 21,180 |  |  | 1090 | 51 |  | ܁A | ܁` |
| 44 | 1.05.01.02 | **MICE RFCC Component Design** | 812d | 2011-10-03 A | 2014-12-29 |  | 58% | 340.52d | 2011-10-03 | 2014-12-29 | 812d | 892d |  |  | 452h |  | 79,410 | 79,410 |  |  | 635 | 51 |  |  |  |
| 45 | 1.05.01.02.01 | **201 MHz Tuner/Actuator Design** | 90d | 2011-10-03 A | 2012-02-14 A |  | 100% |  | 2011-10-03 | 2012-02-14 | 90d |  |  |  |  |  |  |  |  |  | 645 | 51 |  |  |  |
| 46 | 1.05.01.02.01.01 | 201 MHz Tuner/Actuator Design (LBNL - Resources) | 90d | 2011-10-03 A | 2012-02-14 A | 19 | 100% |  | 2011-10-03 | 2012-02-14 | 90d |  |  |  |  |  |  |  |  |  | 646 | 51 |  | ܁A | ܁` |
| 47 | 1.05.01.02.01.02 | 201 MHz Tuner/Actuator Design (LBNL - M&S) | 90d | 2011-10-03 A | 2012-02-14 A | 46SS | 100% |  | 2011-10-03 | 2012-02-14 | 90d |  |  |  |  |  |  |  |  |  | 759 | 51 |  | ܁A | ܁` |
| 48 | 1.05.01.02.02 | **201 MHz Coupler Design** | 5d | 2013-02-15 | 2013-02-21 |  |  |  | 2013-02-15 | 2013-02-21 | 5d | 1357d |  |  | 20h |  | 3,510 | 3,510 |  |  | 335 | 51 |  |  |  |
| 49 | 1.05.01.02.02.01 | 201 MHz Coupler Design - Complete (LBNL - Resources) | 5d | 2013-02-15 | 2013-02-21 | 21FS+77d |  |  | 2013-02-15 | 2013-02-21 | 5d | 1357d | 0d | LBNL_MECH_ENG; LBNL_LABOR [351000%] | 20h |  | 3,510 | 3,510 |  |  | 647 | 51 |  | ܁A | ܁` |
| 50 | 1.05.01.02.02.02 | 201 MHz Coupler Design - Complete (LBNL - M&S) | 5d | 2013-02-15 | 2013-02-21 | 49SS |  |  | 2013-02-15 | 2013-02-21 | 5d | 1357d | 0d |  |  |  |  |  |  |  | 760 | 51 |  | ܁A | ܁` |
| 51 | 1.05.01.02.03 | **RFCC Vacuum Vessel Design** | 60d | 2014-10-01 | 2014-12-29 |  |  |  | 2014-10-01 | 2014-12-29 | 60d | 49d |  |  | 432h |  | 75,900 | 75,900 |  |  | 637 | 51 |  |  |  |
| 52 | 1.05.01.02.03.01 | RFCC Vacuum Vessel Design (LBNL - Resources) | 60d | 2014-10-01 | 2014-12-29 | 23FS-15d |  |  | 2014-10-01 | 2014-12-29 | 60d | 49d | 0d | LBNL_MECH_ENG; LBNL_LABOR | 432h |  | 75,900 | 75,900 |  |  | 648 | 51 |  | ܁A | ܁` |
| 53 | 1.05.01.02.03.02 | RFCC Vacuum Vessel Design (LBNL - M&S) | 60d | 2014-10-01 | 2014-12-29 | 52SS |  |  | 2014-10-01 | 2014-12-29 | 60d | 49d | 0d |  |  |  |  |  |  |  | 761 | 51 |  | ܁A | ܁` |
| 54 | 1.05.01.03 | **MICE RF Cavity Fabrication (Prototype)** | 383d | 2012-02-15 A | 2013-08-20 |  | 69% | 118.13d | 2012-02-15 | 2013-08-20 | 383d | 1317d |  |  |  |  | 239,820 | 239,820 | 95,920 |  | 329 | 51 |  |  |  |
| 55 | 1.05.01.03.01 | **201 MHz Cavity Electro-polished (Prototype)** | 30d | 2012-04-11 A | 2012-05-22 A |  | 100% |  | 2012-04-11 | 2012-05-22 | 30d |  |  |  |  |  |  |  |  |  | 334 | 51 |  |  |  |
| 56 | 1.05.01.03.01.01 | 201 MHz Cavity Electro-polished (Prototype) (LBNL - Resources) | 30d | 2012-04-11 A | 2012-05-22 A | 20 | 100% |  | 2012-04-11 | 2012-05-22 | 30d |  |  |  |  |  |  |  |  |  | 677 | 51 |  | ܁A | ܁` |
| 57 | 1.05.01.03.01.02 | 201 MHz Cavity Electro-polished (Prototype) (LBNL - M&S) | 30d | 2012-04-11 A | 2012-05-22 A | 56SS | 100% |  | 2012-04-11 | 2012-05-22 | 30d |  |  |  |  |  |  |  |  |  | 762 | 51 |  | ܁A | ܁` |

| ID | WBS | Task | Type | Duration | Start | Finish | Predecessors | Complete | Remaining | Baseline start | Baseline finish | Baseline duration | Total slack | Free slack | Resources | Work | Cost | Baseline cost | Actual cost | CobraUID | WBS-L3 Text18 | Resp Instit Name/Code | Funding Type | Milestone Levels |
| --- | --- | --- | --- | --- | --- | --- | --- | --- | --- | --- | --- | --- | --- | --- | --- | --- | --- | --- | --- | --- | --- | --- | --- | --- |
| 58 | 1.05.01.03.02 | **201 MHz Tuner Fabrication (Prototype)** |  | 80d | 2012-02-15 A | 2012-06-06 A |  | 100% |  | 2012-02-15 | 2012-06-06 | 80d |  |  |  |  |  |  |  | 330 | 51 |  |  |  |
| 59 | 1.05.01.03.02.01 | 201 MHz Tuner Fabrication (Prototype) (FNAL - Labor) |  | 80d | 2012-02-15 A | 2012-06-06 A | 47 | 100% |  | 2012-02-15 | 2012-06-06 | 80d |  |  |  |  |  |  |  | 678 | 51 | ܁= | ܁" |  |
| 60 | 1.05.01.03.02.02 | 201 MHz Tuner Fabrication (Prototype) (FNAL - M&S) |  | 80d | 2012-02-15 A | 2012-06-06 A | 59SS | 100% |  | 2012-02-15 | 2012-06-06 | 80d |  |  |  |  |  |  |  | 763 | 51 | ܁= | ܁" |  |
| 61 | 1.05.01.03.03 | **201 MHz Actuator Fabrication (Prototype)** |  | 229d | 2012-06-07 A | 2013-05-06 A |  | 100% |  | 2012-06-07 | 2013-05-06 | 229d |  |  |  |  | 95,920 | 95,920 | 95,920 | 331 | 51 |  |  |  |
| 62 | 1.05.01.03.03.01 | 201 MHz Actuator Fabrication (Prototype) (LBNL - Resources) |  | 229d | 2012-06-07 A | 2013-05-06 A | 59, 47 | 100% |  | 2012-06-07 | 2013-05-06 | 229d |  |  |  |  |  |  |  | 679 | 51 | ܁A | ܁` |  |
| 63 | 1.05.01.03.03.02 | 201 MHz Actuator Fabrication (Prototype) (LBNL - M&S) |  | 229d | 2012-06-07 A | 2013-05-06 A | 62SS | 100% |  | 2012-06-07 | 2013-05-06 | 229d |  |  | LBNL_M&S |  | 95,920 | 95,920 | 95,920 | 764 | 51 | ܁A | ܁` |  |
| 64 | 1.05.01.03.04 | **201 MHz Coupler Fabrication (Prototype)** |  | 60d | 2013-04-01 | 2013-06-24 |  |  |  | 2013-04-01 | 2013-06-24 | 60d | 1357d |  |  |  | 143,900 | 143,900 |  | 336 | 51 |  |  |  |
| 65 | 1.05.01.03.04.01 | 201 MHz Coupler Fabrication (Prototype) (FNAL - Labor) |  | 60d | 2013-04-01 | 2013-06-24 | 50FS+26d |  |  | 2013-04-01 | 2013-06-24 | 60d | 1357d | 0d |  |  |  |  |  | 680 | 51 | ܁= | ܁" |  |
| 66 | 1.05.01.03.04.02 | 201 MHz Coupler Fabrication (Prototype) (FNAL - M&S) |  | 60d | 2013-04-01 | 2013-06-24 | 65SS |  |  | 2013-04-01 | 2013-06-24 | 60d | 1357d | 0d | FN_M&S_STND_FY12 |  | 143,900 | 143,900 |  | 765 | 51 | ܁= | ܁" |  |
| 67 | 1.05.01.03.04.03 | L4 - 201 MHz All parts for SC MICE test at FNAL (Prototype) | milestone | 0d | 2013-06-24 | 2013-06-24 | 66, 57, 60, 63 |  |  | 2013-06-24 | 2013-06-24 | 0d | 1357d |  |  |  |  |  |  | 337 | 51 | ܁= |  |  |
| 68 | 1.05.01.03.05 | **201 MHz Assembly MICE SC Test System (Prototype)(Tasks Charged to MuCool Test Area Budget)** |  | 223d | 2012-10-01 A | 2013-08-20 |  | 41% | 131.5d | 2012-10-01 | 2013-08-20 | 223d | 1317d |  |  |  |  |  |  | 338 | 51 |  |  |  |
| 69 | 1.05.01.03.05.01 | 201 MHz Assembly MICE SC Assembly Tooling (Prototype) (FNAL - Labor)(Task Charged to MuCool Test Area Budget) |  | 183d | 2012-10-01 A | 2013-06-24 | 21FS-15d | 50% | 91.5d | 2012-10-01 | 2013-06-24 | 183d | 1317d | 0d |  |  |  |  |  | 1044 | 51 | ܁= | ܁" |  |
| 70 | 1.05.01.03.05.02 | 201 MHz Assembly MICE SC Assembly Tooling (Prototype) (FNAL - M&S)(Task Charged to MuCool Test Area Budget) |  | 183d | 2012-10-01 A | 2013-06-24 | 69SS | 50% | 91.5d | 2012-10-01 | 2013-06-24 | 183d | 1317d | 0d |  |  |  |  |  | 1045 | 51 | ܁= | ܁" |  |
| 71 | 1.05.01.03.05.03 | 201 MHz Assembly MICE SC Test System (Prototype) (FNAL - Labor)(Task Charged to MuCool Test Area Budget) |  | 40d | 2013-06-25 | 2013-08-20 | 69, 70 |  |  | 2013-06-25 | 2013-08-20 | 40d | 1317d | 0d |  |  |  |  |  | 681 | 51 | ܁= | ܁" |  |
| 72 | 1.05.01.03.05.04 | 201 MHz Assembly MICE SC Test System (Prototype) (FNAL - M&S)(Task Charged to MuCool Test Area Budget) |  | 40d | 2013-06-25 | 2013-08-20 | 71SS |  |  | 2013-06-25 | 2013-08-20 | 40d | 1317d | 0d |  |  |  |  |  | 766 | 51 | ܁= | ܁" |  |
| 73 | 1.05.01.03.06 | L4 - MICE SCTS Ready | milestone | 0d | 2013-08-20 | 2013-08-20 | 72, 71 |  |  | 2013-08-20 | 2013-08-20 | 0d | 1317d |  |  |  |  |  |  | 535 | 51 | ܁= |  |  |
| 74 | 1.05.01.03.07 | (RISK)-(R2) - 201 MHz Assembly MICE SC Test System (Prototype) | milestone | 0d | 2013-08-20 | 2013-08-20 | 71, 72 |  |  | 2013-08-20 | 2013-08-20 | 0d | 1317d | 0d |  |  |  |  |  | 982 | 51 | ܁= |  | R2 |
| 75 | 1.05.01.03.08 | 201 MHz Assembly MICE SC Test System (Prototype) - Possible Costs for this R2 Risk (UID-982) |  | 1d | 2013-08-20 | 2013-08-20 | 74FS-1d |  |  | 2013-08-20 | 2013-08-20 | 1d | 1317d |  |  |  |  |  |  | 1118 | 51 | ܁= |  |  |
| 76 | 1.05.01.04 | **MICE RF Cavity Fabrication (Production)** |  | 1125d | 2011-10-03 A | 2016-03-29 |  |  | 1123.42d | 2011-10-03 | 2016-03-29 | 1125d | 665d |  |  | 4228h | 2,046,400 | 2,046,400 |  | 363 | 51 |  |  |  |
| 77 | 1.05.01.04.01 | L4 - 201 MHz EP Review (Complete) | milestone | 0d | 2012-04-10 A | 2012-04-10 A | 19FS+130d | 100% |  | 2012-04-10 | 2012-04-10 | 0d |  |  |  |  |  |  |  | 655 | 51 | ܁A |  |  |
| 78 | 1.05.01.04.02 | **201 MHz Cavity Electro-polished (Production)** |  | 64d | 2013-07-01 | 2013-09-30 |  |  |  | 2013-07-01 | 2013-09-30 | 64d | 275d |  |  | 160h | 50,000 | 50,000 |  | 368 | 51 |  |  |  |
| 79 | 1.05.01.04.02.01 | 201 MHz Cavity Electro-polished (Production) (LBNL - Resource) |  | 64d | 2013-07-01 | 2013-09-30 | 21FS+172d, 77 |  |  | 2013-07-01 | 2013-09-30 | 64d | 275d | 0d | LBNL_MECH_ENG; LBNL_SCIENTIST; LBNL_POSTDOC; LBNL_LABOR | 160h | 25,000 | 25,000 |  | 649 | 51 | ܁A | ܁` |  |
| 80 | 1.05.01.04.02.02 | 201 MHz Cavity Electro-polished (Production) (LBNL - M&S) |  | 64d | 2013-07-01 | 2013-09-30 | 79SS |  |  | 2013-07-01 | 2013-09-30 | 64d | 275d | 0d | LBNL_M&S |  | 25,000 | 25,000 |  | 767 | 51 | ܁A | ܁` |  |
| 81 | 1.05.01.04.03 | **201 MHz Tuner Fabrication (Production Units) (RFCC#1)** |  | 123d | 2013-10-01 | 2014-03-31 |  |  |  | 2013-10-01 | 2014-03-31 | 123d | 275d |  |  |  | 246,200 | 246,200 |  | 364 | 51 |  |  |  |
| 82 | 1.05.01.04.03.01 | 201 MHz Tuner fabrication (Production Units) (RFCC#1) (LBNL - Resources) |  | 123d | 2013-10-01 | 2014-03-31 | 79, 80 |  |  | 2013-10-01 | 2014-03-31 | 123d | 275d | 0d |  |  |  |  |  | 650 | 51 | ܁A | ܁` |  |
| 83 | 1.05.01.04.03.02 | 201 MHz Tuner fabrication (Production Units) (RFCC#1) (LBNL - M&S) |  | 123d | 2013-10-01 | 2014-03-31 | 82SS |  |  | 2013-10-01 | 2014-03-31 | 123d | 275d | 0d | LBNL_M&S |  | 246,200 | 246,200 |  | 769 | 51 | ܁A | ܁` |  |

Notes:
- 58: Predecessor was 498FS+24d (UID209) / (Before merger 19FS+89d)
- 61: This is not Complete Need to get more information (Alan Bross is checking on this)
- 73: Successor was 665 (UID 339)
- 74: IMPACT:(Delay in CCM Prototype Delivery, tests of RF cavity in CCM field, likely delay in CCM #1 and likely delay) - ACTION:(Assess failure and modify design accordingly. This would likely add 1 year to the testing plan and would incur modification costs)
- 78: Predecessor Before Merge 21
- 81: Predecessor Before Merge 22, 42FS+20d

| ID | WBS | Task | Type | Duration | Start | Finish | Predecessors | Complete | Remaining | Baseline start | Baseline finish | Baseline duration | Total slack | Free slack | Resources | Work | Cost | Baseline cost | CobraUID | WBS-L3 Text18 | Resp Instit Name/Code | Funding Type | Milestone Levels |
| --- | --- | --- | --- | --- | --- | --- | --- | --- | --- | --- | --- | --- | --- | --- | --- | --- | --- | --- | --- | --- | --- | --- | --- |
| 84 | 1.05.01.04.04 | **201 MHz Actuator Fabrication (Production Units) (RFCC#1)** |  | 128d | 2014-04-01 | 2014-09-30 |  |  |  | 2014-04-01 | 2014-09-30 | 128d | 275d |  |  |  | 139,200 | 139,200 | 365 | 51 |  |  |  |
| 85 | 1.05.01.04.04.01 | 201 MHz Actuator Fabrication (Production Units) (RFCC#1) (LBNL - Resources) |  | 128d | 2014-04-01 | 2014-09-30 | 82, 83 |  |  | 2014-04-01 | 2014-09-30 | 128d | 275d | 0d |  |  |  |  | 651 | 51 | ܁A | ܁` |  |
| 86 | 1.05.01.04.04.02 | 201 MHz Actuator Fabrication (Production Units) (RFCC#1) (LBNL - M&S) |  | 128d | 2014-04-01 | 2014-09-30 | 85SS |  |  | 2014-04-01 | 2014-09-30 | 128d | 275d | 0d | LBNL_M&S |  | 139,200 | 139,200 | 770 | 51 | ܁A | ܁` |  |
| 87 | 1.05.01.04.05 | **201 MHz Coupler Fabrication (Production Units) (RFCC#1)** |  | 123d | 2014-10-01 | 2015-03-31 |  |  |  | 2014-10-01 | 2015-03-31 | 123d | 275d |  |  |  | 118,400 | 118,400 | 370 | 51 |  |  |  |
| 88 | 1.05.01.04.05.01 | 201 MHz Coupler Fabrication (Production Units) (RFCC#1) (LBNL - Resources) |  | 123d | 2014-10-01 | 2015-03-31 | 85, 86 |  |  | 2014-10-01 | 2015-03-31 | 123d | 275d | 0d |  |  |  |  | 652 | 51 | ܁A | ܁` |  |
| 89 | 1.05.01.04.05.02 | 201 MHz Coupler Fabrication (Production Units) (RFCC#1) (LBNL - M&S) |  | 123d | 2014-10-01 | 2015-03-31 | 88SS |  |  | 2014-10-01 | 2015-03-31 | 123d | 275d | 0d | LBNL_M&S |  | 118,400 | 118,400 | 771 | 51 | ܁A | ܁` |  |
| 90 | 1.05.01.04.06 | **201 MHz Ceramic RF Window (Production) (RFCC#1)** |  | 1d | 2011-10-03 A | 2011-10-03 A |  | 100% |  | 2011-10-03 | 2011-10-03 | 1d |  |  |  |  |  |  | 757 | 51 |  |  |  |
| 91 | 1.05.01.04.06.01 | 201 MHz Ceramic RF Window (Production) (RFCC#1) (LBNL - Resources) |  | 1d | 2011-10-03 A | 2011-10-03 A | 19 | 100% |  | 2011-10-03 | 2011-10-03 | 1d |  |  |  |  |  |  | 772 | 51 | ܁A | ܁` |  |
| 92 | 1.05.01.04.06.02 | 201 MHz Ceramic RF Window (Production) (RFCC#1) (LBNL - M&S) |  | 1d | 2011-10-03 A | 2011-10-03 A | 91SS | 100% |  | 2011-10-03 | 2011-10-03 | 1d |  |  |  |  |  |  | 773 | 51 | ܁A | ܁` |  |
| 93 | 1.05.01.04.07 | **201 MHz Be Cavity Iris Window (Production) (RFCC#1)** |  | 875d | 2011-10-03 A | 2015-03-31 |  | 99% | 0d | 2011-10-03 | 2015-03-31 | 875d | 915d |  |  |  |  |  | 758 | 51 |  |  |  |
| 94 | 1.05.01.04.07.01 | 201 MHz Be Cavity Iris Window (Production) (RFCC#1) (LBNL - Resources) |  | 1d | 2011-10-03 A | 2011-10-03 A | 19 | 100% |  | 2011-10-03 | 2011-10-03 | 1d |  |  |  |  |  |  | 774 | 51 | ܁A | ܁` |  |
| 95 | 1.05.01.04.07.02 | 201 MHz Be Cavity Iris Window (Production) (RFCC#1) (LBNL - M&S) |  | 1d | 2011-10-03 A | 2011-10-03 A | 94SS | 100% |  | 2011-10-03 | 2011-10-03 | 1d |  |  |  |  |  |  | 775 | 51 | ܁A | ܁` |  |
| 96 | 1.05.01.04.07.03 | L4 - All RF Parts for RFCC#1 Ready | milestone | 0d | 2015-03-31 | 2015-03-31 | 79, 82, 85, 88, 91, 94, 89, 92, 95, 80, 83, 86 |  |  | 2015-03-31 | 2015-03-31 | 0d | 915d |  |  |  |  |  | 989 | 51 | ܁A |  |  |
| 97 | 1.05.01.04.08 | **201 MHz Cavity Assembly & Test (Production) (RFCC#1)** |  | 191d | 2014-12-30 | 2015-09-30 |  |  |  | 2014-12-30 | 2015-09-30 | 191d | 49d |  |  | 2299h | 298,000 | 298,000 | 639 | 51 |  |  |  |
| 98 | 1.05.01.04.08.01 | 201 MHz Production Cavity Assembly Tooling (Production) (RFCC#1) (LBNL - Resources) |  | 63d | 2014-12-30 | 2015-03-31 | 23FS-14d, 52, 53 |  |  | 2014-12-30 | 2015-03-31 | 63d | 49d | 0d |  |  |  |  | 1048 | 51 | ܁A | ܁` |  |
| 99 | 1.05.01.04.08.02 | 201 MHz Production Cavity Assembly Tooling (Production) (RFCC#1) (LBNL - M&S) |  | 63d | 2014-12-30 | 2015-03-31 | 98SS |  |  | 2014-12-30 | 2015-03-31 | 63d | 49d | 0d |  |  |  |  | 1049 | 51 | ܁A | ܁` |  |
| 100 | 1.05.01.04.08.03 | 201 MHz Production Cavity Assembly & Test (Production) (RFCC#1) (LBNL - Resources) |  | 128d | 2015-04-01 | 2015-09-30 | 98, 99 |  |  | 2015-04-01 | 2015-09-30 | 128d | 49d | 0d | LBNL_MECH_TECH; LBNL_MECH_ENG; LBNL_SCIENTIST; LBNL_POSTDOC; LBNL_LABOR | 2299h | 298,000 | 298,000 | 653 | 51 | ܁A | ܁` |  |
| 101 | 1.05.01.04.08.04 | 201 MHz Production Cavity Assembly & Test (Production) (RFCC#1) (LBNL - M&S) |  | 128d | 2015-04-01 | 2015-09-30 | 100SS |  |  | 2015-04-01 | 2015-09-30 | 128d | 49d | 0d |  |  |  |  | 967 | 51 | ܁A | ܁` |  |
| 102 | 1.05.01.04.08.05 | L4 - 201 MHz Production Cavity Assembly & Test - Complete (RFCC#1) (Production) | milestone | 0d | 2015-09-30 | 2015-09-30 | 100, 101 |  |  | 2015-09-30 | 2015-09-30 | 0d | 787d |  |  |  |  |  | 373 | 51 | ܁A |  |  |
| 103 | 1.05.01.04.08.06 | (RISK)-(R3) - 201 MHz Production Cavity Assembly & Test (RFCC#1) (Production) | milestone | 0d | 2015-09-30 | 2015-09-30 | 100, 101 |  |  | 2015-09-30 | 2015-09-30 | 0d | 49d | 0d |  |  |  |  | 692 | 51 | ܁A |  | R3 |
| 104 | 1.05.01.04.08.07 | 201 MHz Production Cavity Assembly & Test (RFCC#1) (Production) - Possible Costs for this R3 Risk (UID-373) |  | 1d | 2015-09-30 | 2015-09-30 | 103FS-1d |  |  | 2015-09-30 | 2015-09-30 | 1d | 787d |  |  |  |  |  | 1119 | 51 | ܁= |  |  |
| 105 | 1.05.01.04.09 | **201 MHz Tuner Fabrication (Production Units) (RFCC#2)** |  | 123d | 2014-10-01 | 2015-03-31 |  |  |  | 2014-10-01 | 2015-03-31 | 123d | 398d |  |  |  | 243,000 | 243,000 | 948 | 51 |  |  |  |
| 106 | 1.05.01.04.09.01 | 201 MHz Tuner fabrication (Production Units) (RFCC#2) (LBNL - Resources) |  | 123d | 2014-10-01 | 2015-03-31 | 23FS-15d, 82, 83 |  |  | 2014-10-01 | 2015-03-31 | 123d | 398d | 0d |  |  |  |  | 949 | 51 | ܁A | ܁` |  |
| 107 | 1.05.01.04.09.02 | 201 MHz Tuner fabrication (Production Units) (RFCC#2) (LBNL - M&S) |  | 123d | 2014-10-01 | 2015-03-31 | 106SS |  |  | 2014-10-01 | 2015-03-31 | 123d | 915d |  | LBNL_M&S |  | 243,000 | 243,000 | 950 | 51 | ܁A | ܁` |  |

Notes:
- 84: Predecessor Before Merge 22, 42FS+20d
- 87: Predecessor was 24,527 (UID 524,673) / Predecessor Before Merge 22
- 88: Mark Says - This is dependent on us completing the test of the Prototype coupler in the field of the CCM Prototype. Previously we tied it to the SCTS Test.
- 103: IMPACT:(Re-work of critical hardware and potential delay of RFCC#1 delivery. This test is not presently on the critical path so budget impact anticipated to be more significant probability than a schedule delay) - ACTION:(Assess failure and modify design)
- 105: Predecessor Before Merge 22, 42FS+20d

| ID | WBS | Task | Type | Duration | Start | Finish | Predecessors | Baseline start | Baseline finish | Baseline duration | Total slack | Free slack | Resources | Work | Cost | Baseline cost | CobraUID | WBS-L3 Text18 | Resp Instit Name/Code | Funding Type | Milestone Levels |
| --- | --- | --- | --- | --- | --- | --- | --- | --- | --- | --- | --- | --- | --- | --- | --- | --- | --- | --- | --- | --- | --- |
| 108 | 1.05.01.04.10 | **201 MHz Actuator Fabrication (Production Units) (RFCC#2)** |  | 123d | 2014-10-01 | 2015-03-31 |  | 2014-10-01 | 2015-03-31 | 123d | 398d |  |  |  | 137,400 | 137,400 | 951 | 51 |  |  |  |
| 109 | 1.05.01.04.10.01 | 201 MHz Actuator Fabrication (Production Units) (RFCC#2) (LBNL - Resources) |  | 123d | 2014-10-01 | 2015-03-31 | 23FS-15d, 85, 86 | 2014-10-01 | 2015-03-31 | 123d | 398d | 0d |  |  |  |  | 952 | 51 | ܁A | ܁` |  |
| 110 | 1.05.01.04.10.02 | 201 MHz Actuator Fabrication (Production Units) (RFCC#2) (LBNL - M&S) |  | 123d | 2014-10-01 | 2015-03-31 | 109SS | 2014-10-01 | 2015-03-31 | 123d | 398d | 123d | LBNL_M&S |  | 137,400 | 137,400 | 953 | 51 | ܁A | ܁` |  |
| 111 | 1.05.01.04.11 | **201 MHz Coupler Fabrication (Production Units) (RFCC#2)** |  | 123d | 2015-04-01 | 2015-09-23 |  | 2015-04-01 | 2015-09-23 | 123d | 275d |  |  |  | 117,000 | 117,000 | 954 | 51 |  |  |  |
| 112 | 1.05.01.04.11.01 | 201 MHz Coupler Fabrication (Production Units) (RFCC#2) (LBNL - Resources) |  | 123d | 2015-04-01 | 2015-09-23 | 23FS-15d, 88, 89 | 2015-04-01 | 2015-09-23 | 123d | 275d | 0d |  |  |  |  | 955 | 51 | ܁A | ܁` |  |
| 113 | 1.05.01.04.11.02 | 201 MHz Coupler Fabrication (Production Units) (RFCC#2) (LBNL - M&S) |  | 123d | 2015-04-01 | 2015-09-23 | 112SS | 2015-04-01 | 2015-09-23 | 123d | 275d | 0d | LBNL_M&S |  | 117,000 | 117,000 | 956 | 51 | ܁A | ܁` |  |
| 114 | 1.05.01.04.12 | **201 MHz Ceramic RF Window (Production) (RFCC#2)** |  | 150d | 2014-10-01 | 2015-05-07 |  | 2014-10-01 | 2015-05-07 | 150d | 371d |  |  |  | 233,600 | 233,600 | 957 | 51 |  |  |  |
| 115 | 1.05.01.04.12.01 | 201 MHz Ceramic RF Window (Production) (RFCC#2) (LBNL - Resources) |  | 150d | 2014-10-01 | 2015-05-07 | 23FS-15d | 2014-10-01 | 2015-05-07 | 150d | 371d | 0d |  |  |  |  | 958 | 51 | ܁A | ܁` |  |
| 116 | 1.05.01.04.12.02 | 201 MHz Ceramic RF Window (Production) (RFCC#2) (LBNL - M&S) |  | 150d | 2014-10-01 | 2015-05-07 | 115SS | 2014-10-01 | 2015-05-07 | 150d | 371d | 96d | LBNL_M&S |  | 233,600 | 233,600 | 959 | 51 | ܁A | ܁` |  |
| 117 | 1.05.01.04.13 | **201 MHz Be Cavity Iris Window (Production) (RFCC#2)** |  | 246d | 2014-10-01 | 2015-09-23 |  | 2014-10-01 | 2015-09-23 | 246d | 275d |  |  |  | 233,600 | 233,600 | 960 | 51 |  |  |  |
| 118 | 1.05.01.04.13.01 | 201 MHz Be Cavity Iris Window (Production) (RFCC#2) (LBNL - Resources) |  | 150d | 2014-10-01 | 2015-05-07 | 23FS-15d | 2014-10-01 | 2015-05-07 | 150d | 371d | 0d |  |  |  |  | 961 | 51 | ܁A | ܁` |  |
| 119 | 1.05.01.04.13.02 | 201 MHz Be Cavity Iris Window (Production) (RFCC#2) (LBNL - M&S) |  | 150d | 2014-10-01 | 2015-05-07 | 118SS | 2014-10-01 | 2015-05-07 | 150d | 371d | 96d | LBNL_M&S |  | 233,600 | 233,600 | 962 | 51 | ܁A | ܁` |  |
| 120 | 1.05.01.04.13.03 | L4 - All RF Parts for RFCC#2 Ready | milestone | 0d | 2015-09-23 | 2015-09-23 | 106, 109, 112, 115, 118, 110, 113, 116, 119 | 2015-09-23 | 2015-09-23 | 0d | 275d | 0d |  |  |  |  | 990 | 51 | ܁A |  |  |
| 121 | 1.05.01.04.14 | **201 MHz Cavity Assembly & Test (Production) (RFCC#2)** |  | 127d | 2015-09-24 | 2016-03-29 |  | 2015-09-24 | 2016-03-29 | 127d | 275d |  |  | 1769h | 230,000 | 230,000 | 963 | 51 |  |  |  |
| 122 | 1.05.01.04.14.01 | 201 MHz Production Cavity Assembly & Test (Production) (RFCC#2) (LBNL - Resources) |  | 127d | 2015-09-24 | 2016-03-29 | 120 | 2015-09-24 | 2016-03-29 | 127d | 275d | 0d | LBNL_MECH_TECH; LBNL_MECH_ENG; LBNL_SCIENTIST; LBNL_POSTDOC; LBNL_LABOR | 1769h | 230,000 | 230,000 | 964 | 51 | ܁A | ܁` |  |
| 123 | 1.05.01.04.14.02 | 201 MHz Production Cavity Assembly & Test (Production) (RFCC#2) (LBNL - M&S) |  | 127d | 2015-09-24 | 2016-03-29 | 122SS | 2015-09-24 | 2016-03-29 | 127d | 275d | 0d |  |  |  |  | 968 | 51 | ܁A | ܁` |  |
| 124 | 1.05.01.04.14.03 | L4 - 201 MHz Production Cavity Assembly & Test - Complete (RFCC#2) (Production) | milestone | 0d | 2016-03-29 | 2016-03-29 | 122, 123 | 2016-03-29 | 2016-03-29 | 0d | 275d | 129d |  |  |  |  | 965 | 51 | ܁A |  |  |
| 125 | 1.05.01.04.14.04 | (RISK)-(R4) - 201 MHz Production Cavity Assembly & Test (RFCC#2) (Production) | milestone | 0d | 2016-03-29 | 2016-03-29 | 122, 123 | 2016-03-29 | 2016-03-29 | 0d | 275d | 129d |  |  |  |  | 966 | 51 | ܁A |  | R4 |
| 126 | 1.05.01.05 | **MICE RFCC Vacuum Vessel Fabrication** |  | 335d | 2014-12-30 | 2016-04-28 |  | 2014-12-30 | 2016-04-28 | 335d | 253d |  |  | 706h | 444,880 | 444,880 | 636 | 51 |  |  |  |
| 127 | 1.05.01.05.01 | **RFCC #1 Vacuum Vessel Fabrication** |  | 40d | 2014-12-30 | 2015-02-26 |  | 2014-12-30 | 2015-02-26 | 40d | 253d |  |  |  | 153,100 | 153,100 | 638 | 51 |  |  |  |
| 128 | 1.05.01.05.01.01 | RFCC #1 Vacuum Vessel Fabrication (LBNL - Resources) |  | 40d | 2014-12-30 | 2015-02-26 | 53 | 2014-12-30 | 2015-02-26 | 40d | 253d | 0d |  |  |  |  | 671 | 51 | ܁A | ܁` |  |
| 129 | 1.05.01.05.01.02 | RFCC #1 Vacuum Vessel Fabrication (LBNL - M&S) |  | 40d | 2014-12-30 | 2015-02-26 | 128SS | 2014-12-30 | 2015-02-26 | 40d | 253d | 0d | LBNL_M&S |  | 153,100 | 153,100 | 776 | 51 | ܁A | ܁` |  |
| 130 | 1.05.01.05.02 | **RFCC #1 Vacuum Vessel Assembly & Test** |  | 45d | 2015-02-27 | 2015-04-30 |  | 2015-02-27 | 2015-04-30 | 45d | 253d |  |  | 353h | 57,830 | 57,830 | 640 | 51 |  |  |  |
| 131 | 1.05.01.05.02.01 | RFCC #1 Vacuum Vessel Assembly & Test (LBNL - Resources) |  | 45d | 2015-02-27 | 2015-04-30 | 129 | 2015-02-27 | 2015-04-30 | 45d | 253d | 0d | LBNL_MECH_TECH; LBNL_MECH_ENG; LBNL_SCIENTIST; LBNL_LABOR | 353h | 57,830 | 57,830 | 672 | 51 | ܁A | ܁` |  |
| 132 | 1.05.01.05.02.02 | RFCC #1 Vacuum Vessel Assembly & Test (LBNL - M&S) |  | 45d | 2015-02-27 | 2015-04-30 | 131SS | 2015-02-27 | 2015-04-30 | 45d | 253d | 0d |  |  |  |  | 777 | 51 | ܁A | ܁` |  |
| 133 | 1.05.01.05.02.03 | L4 - RFCC #1 Vacuum Vessel Assembly & Test (Complete) | milestone | 0d | 2015-04-30 | 2015-04-30 | 132 | 2015-04-30 | 2015-04-30 | 0d | 253d | 0d |  |  |  |  | 654 | 51 | ܁A |  |  |

Notes:
- 108: Predecessor Before Merge 22, 42FS+20d
- 111: Predecessor was 24,527 (UID 524,673) / Predecessor Before Merge 22
- 112: Mark Says - This is dependent on us completing the test of the Prototype coupler in the field of the CCM Prototype. Previously we tied it to the SCTS Test.
- 125: IMPACT:() - ACTION:()

| ID | WBS | Task | Type | Duration | Start | Finish | Predecessors | Complete | Remaining | Baseline start | Baseline finish | Baseline duration | Total slack | Free slack | Resources | Work | Actual work | Cost | Baseline cost | Actual cost | CobraUID | WBS-L3 Text18 | Resp Instit Name/Code | Funding Type | BOE Number | MAP WBS | Milestone Levels |
| --- | --- | --- | --- | --- | --- | --- | --- | --- | --- | --- | --- | --- | --- | --- | --- | --- | --- | --- | --- | --- | --- | --- | --- | --- | --- | --- | --- |
| 134 | 1.05.01.05.03 | **RFCC #1 Vacuum Vessel Shipment to FNAL** |  | 10d | 2015-05-01 | 2015-05-14 |  |  |  | 2015-05-01 | 2015-05-14 | 10d | 253d |  |  |  |  | 11,510 | 11,510 |  | 641 | 51 |  |  |  |  |  |
| 135 | 1.05.01.05.03.01 | RFCC #1 Vacuum Vessel Shipment to FNAL (LBNL - Resources) |  | 10d | 2015-05-01 | 2015-05-14 | 133 |  |  | 2015-05-01 | 2015-05-14 | 10d | 253d | 0d |  |  |  |  |  |  | 673 | 51 | ܁A | ܁` |  |  |  |
| 136 | 1.05.01.05.03.02 | RFCC #1 Vacuum Vessel Shipment to FNAL (LBNL - M&S) |  | 10d | 2015-05-01 | 2015-05-14 | 135SS |  |  | 2015-05-01 | 2015-05-14 | 10d | 253d | 0d | LBNL_M&S |  |  | 11,510 | 11,510 |  | 778 | 51 | ܁A | ܁` |  |  |  |
| 137 | 1.05.01.05.03.03 | L4 - RFCC #1 Vacuum Vessel Received at FNAL | milestone | 0d | 2015-05-14 | 2015-05-14 | 136 |  |  | 2015-05-14 | 2015-05-14 | 0d | 253d |  |  |  |  |  |  |  | 657 | 51 | ܁A |  |  |  |  |
| 138 | 1.05.01.05.04 | **RFCC #2 Vacuum Vessel Fabrication** |  | 127d | 2015-05-01 | 2015-10-29 |  |  |  | 2015-05-01 | 2015-10-29 | 127d | 253d |  |  |  |  | 153,100 | 153,100 |  | 642 | 51 |  |  |  |  |  |
| 139 | 1.05.01.05.04.01 | RFCC #2 Vacuum Vessel Fabrication (LBNL - Resources) |  | 127d | 2015-05-01 | 2015-10-29 | 133 |  |  | 2015-05-01 | 2015-10-29 | 127d | 253d | 0d |  |  |  |  |  |  | 674 | 51 | ܁A | ܁` |  |  |  |
| 140 | 1.05.01.05.04.02 | RFCC #2 Vacuum Vessel Fabrication (LBNL - M&S) |  | 127d | 2015-05-01 | 2015-10-29 | 139SS |  |  | 2015-05-01 | 2015-10-29 | 127d | 253d | 0d | LBNL_M&S |  |  | 153,100 | 153,100 |  | 779 | 51 | ܁A | ܁` |  |  |  |
| 141 | 1.05.01.05.05 | **RFCC #2 Vacuum Vessel Assembly & Test** |  | 60d | 2015-10-30 | 2016-02-01 |  |  |  | 2015-10-30 | 2016-02-01 | 60d | 253d |  |  | 353h |  | 57,830 | 57,830 |  | 643 | 51 |  |  |  |  |  |
| 142 | 1.05.01.05.05.01 | RFCC #2 Vacuum Vessel Assembly & Test (LBNL - Resources) |  | 60d | 2015-10-30 | 2016-02-01 | 140, 139 |  |  | 2015-10-30 | 2016-02-01 | 60d | 253d | 0d | LBNL_MECH_TECH; LBNL_MECH_ENG; LBNL_SCIENTIST; LBNL_LABOR | 353h |  | 57,830 | 57,830 |  | 675 | 51 | ܁A | ܁` |  |  |  |
| 143 | 1.05.01.05.05.02 | RFCC #2 Vacuum Vessel Assembly & Test (LBNL - M&S) |  | 60d | 2015-10-30 | 2016-02-01 | 142SS |  |  | 2015-10-30 | 2016-02-01 | 60d | 253d | 0d |  |  |  |  |  |  | 780 | 51 | ܁A | ܁` |  |  |  |
| 144 | 1.05.01.05.05.03 | L4 - RFCC #2 Vacuum Vessel Assembly & Test (Complete) | milestone | 0d | 2016-02-01 | 2016-02-01 | 143 |  |  | 2016-02-01 | 2016-02-01 | 0d | 253d | 0d |  |  |  |  |  |  | 656 | 51 | ܁A |  |  |  |  |
| 145 | 1.05.01.05.06 | **RFCC #2 Vacuum Vessel Shipment to FNAL** |  | 63d | 2016-02-02 | 2016-04-28 |  |  |  | 2016-02-02 | 2016-04-28 | 63d | 253d |  |  |  |  | 11,510 | 11,510 |  | 644 | 51 |  |  |  |  |  |
| 146 | 1.05.01.05.06.01 | RFCC #2 Vacuum Vessel Shipment to FNAL (LBNL - Resources) |  | 63d | 2016-02-02 | 2016-04-28 | 143, 142, 144 |  |  | 2016-02-02 | 2016-04-28 | 63d | 253d | 0d |  |  |  |  |  |  | 676 | 51 | ܁A | ܁` |  |  |  |
| 147 | 1.05.01.05.06.02 | RFCC #2 Vacuum Vessel Shipment to FNAL (LBNL - M&S) |  | 63d | 2016-02-02 | 2016-04-28 | 146SS |  |  | 2016-02-02 | 2016-04-28 | 63d | 253d | 0d | LBNL_M&S |  |  | 11,510 | 11,510 |  | 781 | 51 | ܁A | ܁` |  |  |  |
| 148 | 1.05.01.05.06.03 | L4 - RFCC #2 Vacuum Vessel Received at FNAL | milestone | 0d | 2016-04-28 | 2016-04-28 | 147 |  |  | 2016-04-28 | 2016-04-28 | 0d | 253d | 107d |  |  |  |  |  |  | 658 | 51 | ܁A |  |  |  |  |
| 149 | 1.05.02 | **MICE Magnet Design, Fabrication and Testing** |  | 1754d | 2011-10-03 A | 2018-09-27 |  | 22% | 1360.87d | 2011-10-03 | 2018-09-27 | 1754d | 36d |  |  | 48518.1h | 4432.6h | 9,947,315 | 9,947,315 | 1,075,292.4 | 208 | 52 |  |  | BOE-1.05.02 | 29M.05.02 |  |
| 150 | 1.05.02.01 | **MICE Spectrometer Solenoids** |  | 371d | 2012-10-01 A | 2014-03-26 |  | 50% | 186.86d | 2012-10-01 | 2014-03-26 | 371d | 1169d |  |  | 3577.08h | 1145.15h | 989,683 | 989,683 | 343,724.2 | 453 | 52 |  |  |  |  |  |
| 151 | 1.05.02.01.01 | **Spectrometer Solenoid Controls Upgrade & Validation** |  | 165d | 2012-10-01 A | 2013-05-29 |  | 90% | 16.5d | 2012-10-01 | 2013-05-29 | 165d | 295d |  |  |  |  | 95,920 | 95,920 | 86,328 | 942 | 52 |  |  |  |  |  |
| 152 | 1.05.02.01.01.01 | Spectrometer Solenoid Controls Upgrade & Validation (FNAL - Resources) |  | 165d | 2012-10-01 A | 2013-05-29 | 21FS-15d | 90% | 16.5d | 2012-10-01 | 2013-05-29 | 165d | 295d | 0d |  |  |  |  |  |  | 943 | 52 | ܁= | ܁" |  |  |  |
| 153 | 1.05.02.01.01.02 | Spectrometer Solenoid Controls Upgrade & Validation (FNAL - M&S) |  | 165d | 2012-10-01 A | 2013-05-29 | 152SS | 90% | 16.5d | 2012-10-01 | 2013-05-29 | 165d | 295d | 0d | FN_M&S_STND_FY12 |  |  | 95,920 | 95,920 | 86,328 | 944 | 52 | ܁= | ܁" |  |  |  |
| 154 | 1.05.02.01.01.03 | L4 - Spectrometer Solenoid Controls Operational Readiness Certification | milestone | 0d | 2013-05-29 | 2013-05-29 | 152, 153 |  |  | 2013-05-29 | 2013-05-29 | 0d | 295d | 1d |  |  |  |  |  |  | 946 | 52 | ܁A |  |  |  |  |
| 155 | 1.05.02.01.01.04 | (RISK)-(R2) - Spectrometer Solenoid Controls Operational Readiness Certification | milestone | 0d | 2013-05-29 | 2013-05-29 | 152, 153 |  |  | 2013-05-29 | 2013-05-29 | 0d | 295d | 1d |  |  |  |  |  |  | 947 | 52 | ܁A |  |  |  | R2 |
| 156 | 1.05.02.01.02 | **Spectrometer Solenoid 2** |  | 106d | 2013-02-11 A | 2013-07-10 |  | 50% | 52.74d | 2013-02-11 | 2013-07-10 | 106d | 336d |  |  | 491h | 320h | 190,517 | 190,517 | 81,100 | 454 | 52 |  |  |  |  |  |
| 157 | 1.05.02.01.02.01 | **SS#2 Re-Train and Re-Test** |  | 30d | 2013-02-11 A | 2013-03-22 A |  | 100% |  | 2013-02-11 | 2013-03-22 | 30d |  |  |  | 320h | 320h | 81,100 | 81,100 | 81,100 | 619 | 52 |  |  |  |  |  |
| 158 | 1.05.02.01.02.01.01 | SS#2 Re-Train and Re-Test (LBNL - Resources) |  | 30d | 2013-02-11 A | 2013-03-22 A | 21FS+73d | 100% |  | 2013-02-11 | 2013-03-22 | 30d |  |  | LBNL_MECH_ENG; LBNL_MECH_TECH; LBNL_LABOR | 320h | 320h | 31,900 | 31,900 | 31,900 | 469 | 52 | ܁A | ܁` |  |  |  |
| 159 | 1.05.02.01.02.01.02 | SS#2 Re-Train and Re-Test (LBNL - M&S) |  | 30d | 2013-02-11 A | 2013-03-22 A | 158SS | 100% |  | 2013-02-11 | 2013-03-22 | 30d |  |  |  |  |  |  |  |  | 782 | 52 | ܁A | ܁` |  |  |  |
| 160 | 1.05.02.01.02.01.03 | SS#2 Re-Train and Re-Test (Training Utilities) (FNAL - M&S) |  | 30d | 2013-02-11 A | 2013-03-22 A | 158SS | 100% |  | 2013-02-11 | 2013-03-22 | 30d |  |  | FN_M&S_STND_FY12 |  |  | 49,200 | 49,200 | 49,200 | 618 | 52 | ܁= | ܁" |  |  |  |
| 161 | 1.05.02.01.02.01.04 | (RISK)-(R3) - SS#2 Re-Train and Re-Test | milestone | 0d | 2013-03-22 A | 2013-03-22 A | 158, 159, 160 | 100% |  | 2013-03-22 | 2013-03-22 | 0d |  |  |  |  |  |  |  |  | 693 | 52 | ܁A |  |  |  | R3 |
| 162 | 1.05.02.01.02.01.05 | SS#2 Re-Train and Re-Test - Possible Costs for this R3 Risk (UID-693) |  | 1d | 2013-03-22 A | 2013-03-22 A | 161FS-1d | 100% |  | 2013-03-22 | 2013-03-22 | 1d |  |  |  |  |  |  |  |  | 1120 | 52 | ܁= |  |  |  |  |

Notes:
- 145: Setting this date to FY17 Funding delayed the Successor by 1.5 months / (Ship RF Components for RFCC#2 from LBNL to FNAL)
- 155: IMPACT:(Impacts include delayed magnet training and subsequently difficulty commissioning the full cooling channel beam line) - ACTION:(Continued improvements of SC magnet controls)
- 161: IMPACT:(Delay of MICE Step IV commissioning and experimental operations.) - ACTION: (Assess failure and repair magnet. Likely delay of >6 months r for final delivery)

| ID | WBS | Task | Type | Duration | Start | Finish | Predecessors | Complete | Remaining | Baseline start | Baseline finish | Baseline duration | Total slack | Free slack | Resources | Work | Actual work | Cost | Baseline cost | Actual cost | CobraUID | WBS-L3 Text18 | Resp Instit Name/Code | Funding Type | Milestone Levels |
| --- | --- | --- | --- | --- | --- | --- | --- | --- | --- | --- | --- | --- | --- | --- | --- | --- | --- | --- | --- | --- | --- | --- | --- | --- | --- |
| 163 | 1.05.02.01.02.02 | **Ship Field Mapping Equipment to WANG** |  | 10d | 2013-04-30 A | 2013-05-13 A |  | 100% |  | 2013-04-30 | 2013-05-13 | 10d |  |  |  |  |  |  |  |  | 1012 | 52 |  |  |  |
| 164 | 1.05.02.01.02.02.01 | Ship Field Mapping Equipment to WANG (RAL Expense) |  | 10d | 2013-04-30 A | 2013-05-13 A | 161FS+26d | 100% |  | 2013-04-30 | 2013-05-13 | 10d |  |  |  |  |  |  |  |  | 1013 | 52 | ܁A | ܁` |  |
| 165 | 1.05.02.01.02.03 | **SS#2 Field Map at WANG** |  | 20d | 2013-05-14 | 2013-06-11 |  |  |  | 2013-05-14 | 2013-06-11 | 20d | 336d |  |  | 64h |  | 97,827 | 97,827 |  | 627 | 52 |  |  |  |
| 166 | 1.05.02.01.02.03.01 | SS#2 Field Map (LBNL - Resources) |  | 20d | 2013-05-14 | 2013-06-11 | 164 |  |  | 2013-05-14 | 2013-06-11 | 20d | 336d | 0d | LBNL_MECH_TECH; LBNL_LABOR [789700%] | 64h |  | 7,897 | 7,897 |  | 628 | 52 | ܁A | ܁` |  |
| 167 | 1.05.02.01.02.03.02 | SS#2 Field Map (LBNL - M&S) |  | 20d | 2013-05-14 | 2013-06-11 | 166SS |  |  | 2013-05-14 | 2013-06-11 | 20d | 336d | 0d | LBNL_M&S |  |  | 89,930 | 89,930 |  | 783 | 52 | ܁A | ܁` |  |
| 168 | 1.05.02.01.02.03.03 | SS#2 Field Map (FNAL - Labor) |  | 20d | 2013-05-14 | 2013-06-11 | 166SS |  |  | 2013-05-14 | 2013-06-11 | 20d | 336d | 0d |  |  |  |  |  |  | 630 | 52 | ܁= | ܁" |  |
| 169 | 1.05.02.01.02.03.04 | (RISK)-(R4) - SS#2 Operation Failure with Iron Shield | milestone | 0d | 2013-06-11 | 2013-06-11 | 166, 167, 168 |  |  | 2013-06-11 | 2013-06-11 | 0d | 336d | 0d |  |  |  |  |  |  | 1042 | 52 | ܁= |  | R4 |
| 170 | 1.05.02.01.02.04 | **SS#2 Prepare for Shipment from WANG to UK** |  | 20d | 2013-06-12 | 2013-07-10 |  |  |  | 2013-06-12 | 2013-07-10 | 20d | 336d |  |  | 107h |  | 11,590 | 11,590 |  | 624 | 52 |  |  |  |
| 171 | 1.05.02.01.02.04.01 | SS#2 Prepare for Shipment (LBNL - Resources) |  | 20d | 2013-06-12 | 2013-07-10 | 166, 168, 161, 167, 169 |  |  | 2013-06-12 | 2013-07-10 | 20d | 336d | 0d | LBNL_MECH_TECH; LBNL_MECH_ENG; LBNL_LABOR | 107h |  | 11,590 | 11,590 |  | 470 | 52 | ܁A | ܁` |  |
| 172 | 1.05.02.01.02.04.02 | SS#2 Prepare for Shipment (LBNL - M&S) |  | 20d | 2013-06-12 | 2013-07-10 | 171SS |  |  | 2013-06-12 | 2013-07-10 | 20d | 336d | 0d |  |  |  |  |  |  | 784 | 52 | ܁A | ܁` |  |
| 173 | 1.05.02.01.02.05 | L4 - SS#2 Prepare for Shipment - Complete | milestone | 0d | 2013-07-10 | 2013-07-10 | 171, 172 |  |  | 2013-07-10 | 2013-07-10 | 0d | 336d | 0d |  |  |  |  |  |  | 514 | 52 | ܁A |  |  |
| 174 | 1.05.02.01.03 | **Spectrometer Solenoid 1** |  | 221d | 2012-10-22 A | 2013-09-09 |  | 52% | 107.05d | 2012-10-22 | 2013-09-09 | 221d | 1304d |  |  | 2749h | 825.15h | 563,057 | 563,057 | 176,296.2 | 416 | 52 |  |  |  |
| 175 | 1.05.02.01.03.01 | **SS#1 Assembly at WANG** |  | 151d | 2012-10-22 A | 2013-05-30 |  | 84% | 23.91d | 2012-10-22 | 2013-05-30 | 151d | 294d |  |  | 1739h | 825.15h | 225,140 | 225,140 | 176,296.2 | 622 | 52 |  |  |  |
| 176 | 1.05.02.01.03.01.01 | SS#1 Assembly at WANG (LBNL - Resources) |  | 151d | 2012-10-22 A | 2013-05-30 | 21 | 75% | 37.75d | 2012-10-22 | 2013-05-30 | 151d | 294d | 0d | LBNL_MECH_TECH; LBNL_MECH_ENG; LBNL_LABOR | 1739h | 825.15h | 183,800 | 183,800 | 137,850 | 615 | 52 | ܁A | ܁` |  |
| 177 | 1.05.02.01.03.01.02 | SS#1 Assembly at WANG (LBNL - M&S) |  | 151d | 2012-10-22 A | 2013-05-30 | 176SS | 93% | 10.07d | 2012-10-22 | 2013-05-30 | 151d | 294d | 0d | LBNL_M&S |  |  | 41,340 | 41,340 | 38,446.2 | 785 | 52 | ܁A | ܁` |  |
| 178 | 1.05.02.01.03.02 | **SS#1 Training and Test at WANG** |  | 35d | 2013-05-31 | 2013-07-19 |  |  |  | 2013-05-31 | 2013-07-19 | 35d | 294d |  |  | 839h |  | 228,500 | 228,500 |  | 623 | 52 |  |  |  |
| 179 | 1.05.02.01.03.02.01 | SS#1 Training and Test at WANG (LBNL - Resources) |  | 35d | 2013-05-31 | 2013-07-19 | 176, 177, 154, 155 |  |  | 2013-05-31 | 2013-07-19 | 35d | 294d | 0d | LBNL_MECH_TECH; LBNL_MECH_ENG; LBNL_LABOR | 839h |  | 101,500 | 101,500 |  | 462 | 52 | ܁A | ܁` |  |
| 180 | 1.05.02.01.03.02.02 | SS#1 Training and Test at WANG (LBNL - M&S) |  | 35d | 2013-05-31 | 2013-07-19 | 179SS |  |  | 2013-05-31 | 2013-07-19 | 35d | 309d | 15d |  |  |  |  |  |  | 786 | 52 | ܁A | ܁` |  |
| 181 | 1.05.02.01.03.02.03 | SS#1 Training and Test at WANG (FNAL - Labor) |  | 35d | 2013-05-31 | 2013-07-19 | 179SS |  |  | 2013-05-31 | 2013-07-19 | 35d | 309d | 15d | FN_M&S_STND_FY12 |  |  | 127,000 | 127,000 |  | 626 | 52 | ܁= | ܁" |  |
| 182 | 1.05.02.01.03.02.04 | (RISK)-(R3) - SS#1 Train and Test | milestone | 0d | 2013-07-19 | 2013-07-19 | 179 |  |  | 2013-07-19 | 2013-07-19 | 0d | 294d | 0d |  |  |  |  |  |  | 694 | 52 | ܁A |  | R3 |
| 183 | 1.05.02.01.03.02.05 | SS#1 Train and Test - Possible Costs for this R3 Risk (UID-187) |  | 1d | 2013-07-19 | 2013-07-19 | 182FS-1d |  |  | 2013-07-19 | 2013-07-19 | 1d | 1339d |  |  |  |  |  |  |  | 1121 | 52 | ܁= |  |  |
| 184 | 1.05.02.01.03.02.06 | L4 - SS#1 Training and Test at WANG - Complete | milestone | 0d | 2013-07-19 | 2013-07-19 | 179 |  |  | 2013-07-19 | 2013-07-19 | 0d | 294d | 0d |  |  |  |  |  |  | 1019 | 52 | ܁A |  |  |
| 185 | 1.05.02.01.03.03 | **SS#1 Field Map at WANG** |  | 15d | 2013-07-22 | 2013-08-09 |  |  |  | 2013-07-22 | 2013-08-09 | 15d | 294d |  |  | 64h |  | 97,827 | 97,827 |  | 632 | 52 |  |  |  |
| 186 | 1.05.02.01.03.03.01 | SS#1 Field Map at WANG (LBNL - Resources) |  | 15d | 2013-07-22 | 2013-08-09 | 184, 182 |  |  | 2013-07-22 | 2013-08-09 | 15d | 294d | 0d | LBNL_MECH_TECH; LBNL_LABOR [789700%] | 64h |  | 7,897 | 7,897 |  | 633 | 52 | ܁A | ܁` |  |
| 187 | 1.05.02.01.03.03.02 | SS#1 Field Map at WANG (LBNL - M&S) |  | 15d | 2013-07-22 | 2013-08-09 | 186SS |  |  | 2013-07-22 | 2013-08-09 | 15d | 294d | 0d | LBNL_M&S |  |  | 89,930 | 89,930 |  | 787 | 52 | ܁A | ܁` |  |
| 188 | 1.05.02.01.03.03.03 | SS#1 Field Map at WANG (FNAL - M&S) |  | 15d | 2013-07-22 | 2013-08-09 | 186SS |  |  | 2013-07-22 | 2013-08-09 | 15d | 294d | 0d |  |  |  |  |  |  | 634 | 52 | ܁= | ܁" |  |
| 189 | 1.05.02.01.03.03.04 | (RISK)-(R4) - SS#1 Operation Failure with Iron Shield | milestone | 0d | 2013-08-09 | 2013-08-09 | 186, 187, 188 |  |  | 2013-08-09 | 2013-08-09 | 0d | 294d | 0d |  |  |  |  |  |  | 1043 | 52 | ܁= |  | R4 |

Notes:
- 169: IMPACT:() - ACTION:()
- 171: Requires 14 Calendar days (Start on 12/17/12 Thru 1/3/13)
- 182: IMPACT:(Delay of MICE Step IV commissioning and experimental operations) - ACTION:(Assess failure and repair magnet. Likely delay of >1 year for final delivery)
- 189: IMPACT:() - ACTION:()

| ID | WBS | Task | Type | Duration | Start | Finish | Predecessors | Complete | Remaining | Baseline start | Baseline finish | Baseline duration | Total slack | Free slack | Resources | Work | Actual work | Cost | Baseline cost | Actual cost | CobraUID | WBS-L3 Text18 | Resp Instit Name/Code | Funding Type |
| --- | --- | --- | --- | --- | --- | --- | --- | --- | --- | --- | --- | --- | --- | --- | --- | --- | --- | --- | --- | --- | --- | --- | --- | --- |
| 190 | 1.05.02.01.03.04 | **SS#1 Prepare for Shipment from WANG to UK** |  | 20d | 2013-08-12 | 2013-09-09 |  |  |  | 2013-08-12 | 2013-09-09 | 20d | 294d |  |  | 107h |  | 11,590 | 11,590 |  | 625 | 52 |  |  |
| 191 | 1.05.02.01.03.04.01 | SS#1 Prepare for Shipment from WANG to UK (LBNL - Resources) |  | 20d | 2013-08-12 | 2013-09-09 | 179, 181, 186, 188, 180, 187, 189 |  |  | 2013-08-12 | 2013-09-09 | 20d | 294d | 0d | LBNL_MECH_TECH; LBNL_MECH_ENG; LBNL_LABOR | 107h |  | 11,590 | 11,590 |  | 419 | 52 | ܁A | ܁` |
| 192 | 1.05.02.01.03.04.02 | SS#1 Prepare for Shipment from WANG to UK (LBNL - M&S) |  | 20d | 2013-08-12 | 2013-09-09 | 191SS |  |  | 2013-08-12 | 2013-09-09 | 20d | 294d | 0d |  |  |  |  |  |  | 788 | 52 | ܁A | ܁` |
| 193 | 1.05.02.01.03.05 | L4 - SS#1 Prepare for Shipment from WANG to UK - Complete | milestone | 0d | 2013-09-09 | 2013-09-09 | 191, 192 |  |  | 2013-09-09 | 2013-09-09 | 0d | 294d | 0d |  |  |  |  |  |  | 516 | 52 | ܁A |  |
| 194 | 1.05.02.01.04 | **Spectrometer Solenoid Delivery, Installation, Commissioning** |  | 177d | 2013-07-11 | 2014-03-26 |  |  |  | 2013-07-11 | 2014-03-26 | 177d | 336d |  |  | 337.08h |  | 140,189 | 140,189 |  | 506 | 52 |  |  |
| 195 | 1.05.02.01.04.01 | **SS#2 Shipment to UK** |  | 10d | 2013-07-11 | 2013-07-24 |  |  |  | 2013-07-11 | 2013-07-24 | 10d | 336d |  |  |  |  | 20,000 | 20,000 |  | 1015 | 52 |  |  |
| 196 | 1.05.02.01.04.01.01 | SS#2 Air Shipment to UK (LBNL - M&S) |  | 10d | 2013-07-11 | 2013-07-24 | 173 |  |  | 2013-07-11 | 2013-07-24 | 10d | 336d | 0d | LBNL_M&S |  |  | 20,000 | 20,000 |  | 1016 | 52 | ܁A | ܁` |
| 197 | 1.05.02.01.04.01.02 | L4 - SS#2 Arrives at RAL | milestone | 0d | 2013-07-24 | 2013-07-24 | 196 |  |  | 2013-07-24 | 2013-07-24 | 0d | 336d | 42d |  |  |  |  |  |  | 1017 | 52 | ܁A |  |
| 198 | 1.05.02.01.04.02 | **SS#1 Shipment to UK** |  | 10d | 2013-09-10 | 2013-09-23 |  |  |  | 2013-09-10 | 2013-09-23 | 10d | 294d |  |  |  |  | 20,000 | 20,000 |  | 499 | 52 |  |  |
| 199 | 1.05.02.01.04.02.01 | SS#1 Air Shipment to UK (LBNL - M&S) |  | 10d | 2013-09-10 | 2013-09-23 | 193 |  |  | 2013-09-10 | 2013-09-23 | 10d | 294d | 0d | LBNL_M&S |  |  | 20,000 | 20,000 |  | 500 | 52 | ܁A | ܁` |
| 200 | 1.05.02.01.04.02.02 | L4 - SS#1 Arrives at RAL | milestone | 0d | 2013-09-23 | 2013-09-23 | 199 |  |  | 2013-09-23 | 2013-09-23 | 0d | 294d | 0d |  |  |  |  |  |  | 501 | 52 | ܁A |  |
| 201 | 1.05.02.01.04.03 | **Prepare and Ship Field Mapping Equipment from WANG to UK** |  | 10d | 2013-08-12 | 2013-08-23 |  |  |  | 2013-08-12 | 2013-08-23 | 10d | 1314d |  |  |  |  |  |  |  | 1020 | 52 |  |  |
| 202 | 1.05.02.01.04.03.01 | Prepare and Ship Field Mapping Equipment from WANG to UK (LBNL - Resources) |  | 10d | 2013-08-12 | 2013-08-23 | 189 |  |  | 2013-08-12 | 2013-08-23 | 10d | 1314d | 0d |  |  |  |  |  |  | 1021 | 52 | ܁A | ܁` |
| 203 | 1.05.02.01.04.03.02 | Prepare and Ship Field Mapping Equipment from WANG to UK (LBNL - M&S) |  | 10d | 2013-08-12 | 2013-08-23 | 202SS |  |  | 2013-08-12 | 2013-08-23 | 10d | 1314d | 0d |  |  |  |  |  |  | 1022 | 52 | ܁A | ܁` |
| 204 | 1.05.02.01.04.03.03 | L4 - Ship Field Mapping Equipment Arrives at UK (UK Needs by 10/30/13) | milestone | 0d | 2013-08-23 | 2013-08-23 | 202, 203 |  |  | 2013-08-23 | 2013-08-23 | 0d | 1314d |  |  |  |  |  |  |  | 1023 | 52 | ܁A |  |
| 205 | 1.05.02.01.04.04 | **SS#1 and SS#2 Installation and Commissioning** |  | 125d | 2013-09-24 | 2014-03-26 |  |  |  | 2013-09-24 | 2014-03-26 | 125d | 1169d |  |  | 337.08h |  | 100,189 | 100,189 |  | 505 | 52 |  |  |
| 206 | 1.05.02.01.04.04.01 | SS#1 & SS#2 US Support of Installation and Commissioning (BNL - Resources) |  | 125d | 2013-09-24 | 2014-03-26 | 197, 200 |  |  | 2013-09-24 | 2014-03-26 | 125d | 1169d | 0d | BNL_MECH_ENG; BNL_LABOR | 337.08h |  | 71,639 | 71,639 |  | 704 | 52 | ܁? | ܁` |
| 207 | 1.05.02.01.04.04.02 | SS#1 & SS#2 US Support of Installation and Commissioning (BNL - M&S) |  | 125d | 2013-09-24 | 2014-03-26 | 206SS |  |  | 2013-09-24 | 2014-03-26 | 125d | 1169d | 0d | BNL_M&S |  |  | 28,550 | 28,550 |  | 797 | 52 | ܁? | ܁` |
| 208 | 1.05.02.01.04.05 | L4 - SS#1 & SS#2 Spectrometer Solenoids Ready for Operations | milestone | 0d | 2014-03-26 | 2014-03-26 | 207 |  |  | 2014-03-26 | 2014-03-26 | 0d | 1169d |  |  |  |  |  |  |  | 508 | 52 | ܁? |  |
| 209 | 1.05.02.02 | **MICE Coupling Coils (CC)** |  | 1754d | 2011-10-03 A | 2018-09-27 |  | 18% | 1430.56d | 2011-10-03 | 2018-09-27 | 1754d | 36d |  |  | 44941h | 3287.45h | 8,957,632 | 8,957,632 | 731,568.2 | 261 | 52 |  |  |
| 210 | 1.05.02.02.01 | **MICE Test Facility Contributions (FNAL)** |  | 60d | 2013-05-15 | 2013-08-08 |  |  |  | 2013-05-15 | 2013-08-08 | 60d | 1325d |  |  | 480h |  | 39,840 | 39,840 |  | 1112 | 52 |  |  |
| 211 | 1.05.02.02.01.01 | MICE Test Facility Contributions (FNAL) (FNAL - Labor) |  | 60d | 2013-05-15 | 2013-08-08 | 21FS+140d |  |  | 2013-05-15 | 2013-08-08 | 60d | 1325d |  | FNAD_MECH_SYSTM_TECH | 480h |  | 39,840 | 39,840 |  | 1114 | 52 | ܁= | ܁" |
| 212 | 1.05.02.02.02 | **CC Cold Mass Preparation** |  | 947d | 2012-10-01 A | 2016-07-11 |  | 16% | 790.97d | 2012-10-01 | 2016-07-11 | 947d | 593d |  |  | 7100h | 1344.7h | 1,628,223 | 1,628,223 | 302,835.2 | 709 | 52 |  |  |
| 213 | 1.05.02.02.02.01 | Superconductor - Establish Duty Free Shipping Arrangements (FNAL - Labor) |  | 145d | 2012-10-01 A | 2013-04-30 | 21FS-15d | 25% | 108.75d | 2012-10-01 | 2013-04-30 | 145d | 720d | 0d |  |  |  |  |  |  | 1028 | 52 | ܁= | ܁" |
| 214 | 1.05.02.02.02.02 | Purchase Last 10% of Superconductor Wire (FNAL - M&S) |  | 20d | 2013-05-01 A | 2013-05-29 A | 213 | 100% |  | 2013-05-01 | 2013-05-29 | 20d |  |  | FN_M&S_STND_FY12 |  |  | 40,390 | 40,390 | 40,390 | 1110 | 52 | ܁= | ܁" |

Notes:
- 193: Yellow is Milestones completed in USA
- 197: Green is for milestones outside of USA
- 200: Green is for milestones outside of USA
- 208: Predecessor was 774 (UID 507) / Successor was 892, 679FF (UID 571, 578)

| ID | WBS | Task | Type | Duration | Start | Finish | Predecessors | Complete | Remaining | Baseline start | Baseline finish | Baseline duration | Total slack | Free slack | Resources | Work | Actual work | Cost | Baseline cost | Actual cost | CobraUID | WBS-L3 Text18 | Resp Instit Name/Code | Funding Type | Milestone Levels |
| --- | --- | --- | --- | --- | --- | --- | --- | --- | --- | --- | --- | --- | --- | --- | --- | --- | --- | --- | --- | --- | --- | --- | --- | --- | --- |
| 215 | 1.05.02.02.02.03 | **Cold Mass #1 Preparation (LBNL)** |  | 62d | 2012-10-01 A | 2013-01-02 A |  | 100% |  | 2012-10-01 | 2013-01-02 | 62d |  |  |  |  |  | 73,680 | 73,680 | 73,680 | 714 | 52 |  |  |  |
| 216 | 1.05.02.02.02.03.01 | Cold Mass #1 Preparation (LBNL - Resources) |  | 61d | 2012-10-01 A | 2012-12-28 A | 21FS-15d | 100% |  | 2012-10-01 | 2012-12-28 | 61d |  |  |  |  |  |  |  |  | 715 | 52 | ܁A | ܁` |  |
| 217 | 1.05.02.02.02.03.02 | Cold Mass #1 Preparation (LBNL - M&S) |  | 61d | 2012-10-01 A | 2012-12-28 A | 216SS | 100% |  | 2012-10-01 | 2012-12-28 | 61d |  |  | LBNL_M&S |  |  | 73,680 | 73,680 | 73,680 | 716 | 52 | ܁A | ܁` |  |
| 218 | 1.05.02.02.02.03.03 | L4 - Cold Mass #1 Arrives at Fermilab | milestone | 0d | 2013-01-02 A | 2013-01-02 A | 216FS+1d, 217FS+1d | 100% |  | 2013-01-02 | 2013-01-02 | 0d |  |  |  |  |  |  |  |  | 717 | 52 | ܁A |  |  |
| 219 | 1.05.02.02.02.04 | **Cold Mass #1 Preparation & Test (FNAL)** |  | 126d | 2013-01-03 A | 2013-07-01 |  | 50% | 63.25d | 2013-01-03 | 2013-07-01 | 126d | 1352d |  |  | 1415h | 707.5h | 210,305 | 210,305 | 105,152.5 | 718 | 52 |  |  |  |
| 220 | 1.05.02.02.02.04.01 | Cold Mass #1 Preparation & Test (FNAL - Labor) |  | 126d | 2013-01-03 A | 2013-07-01 | 216, 218 | 50% | 63d | 2013-01-03 | 2013-07-01 | 126d | 164d | 0d | FNAD_MECH_SYSTM_TECH [105%]; FNAD_MAGNT_DESIGN_EN [12%]; FNAD_AC_EXP_PHYST [24%] | 1415h | 707.5h | 150,305 | 150,305 | 75,152.5 | 719 | 52 | ܁= | ܁" |  |
| 221 | 1.05.02.02.02.04.02 | Cold Mass #1 Preparation & Test (FNAL - M&S) |  | 126d | 2013-01-03 A | 2013-07-01 | 220SS | 50% | 63d | 2013-01-03 | 2013-07-01 | 126d | 164d | 0d | FN_M&S_STND_FY12 |  |  | 60,000 | 60,000 | 30,000 | 720 | 52 | ܁= | ܁" |  |
| 222 | 1.05.02.02.02.04.03 | L4 - Signoff for Further Coil Winding at QiHuan | milestone | 0d | 2013-05-20 | 2013-05-20 | 220FS-30d, 221FS-30d |  |  | 2013-05-20 | 2013-05-20 | 0d | 727d | 7d |  |  |  |  |  |  | 721 | 52 | ܁= |  |  |
| 223 | 1.05.02.02.02.04.04 | L4 - CC Coil #1 Test Complete | milestone | 0d | 2013-07-01 | 2013-07-01 | 220, 221 |  |  | 2013-07-01 | 2013-07-01 | 0d | 164d |  |  |  |  |  |  |  | 722 | 52 | ܁= |  |  |
| 224 | 1.05.02.02.02.04.05 | (RISK)-(R2) - CC Coil #1 Test | milestone | 0d | 2013-07-01 | 2013-07-01 | 220, 221 |  |  | 2013-07-01 | 2013-07-01 | 0d | 164d | 0d |  |  |  |  |  |  | 723 | 52 | ܁= |  | R2 |
| 225 | 1.05.02.02.02.04.06 | CC Coil #1 Test - Possible Costs for this R2 Risk (UID-723) |  | 1d | 2013-07-01 | 2013-07-01 | 224FS-1d |  |  | 2013-07-01 | 2013-07-01 | 1d | 1352d |  |  |  |  |  |  |  | 1117 | 52 | ܁= |  |  |
| 226 | 1.05.02.02.02.05 | **Superconductor Test (Cold Masses 2 - 4)** |  | 61d | 2012-10-01 A | 2012-12-28 |  | 90% | 6.1d | 2012-10-01 | 2012-12-28 | 61d | 804d |  |  | 708h | 637.2h | 92,903 | 92,903 | 83,612.7 | 724 | 52 |  |  |  |
| 227 | 1.05.02.02.02.05.01 | Superconductor Test (FNAL - Labor) |  | 61d | 2012-10-01 A | 2012-12-28 | 21FS-15d | 90% | 6.1d | 2012-10-01 | 2012-12-28 | 61d | 804d | 0d | FNAD_MECH_SYSTM_TECH [73%]; FNAD_AC_EXP_PHYST [73%] | 708h | 637.2h | 88,854 | 88,854 | 79,968.6 | 725 | 52 | ܁= | ܁" |  |
| 228 | 1.05.02.02.02.05.02 | Superconductor Test (FNAL - M&S) |  | 61d | 2012-10-01 A | 2012-12-28 | 227SS | 90% | 6.1d | 2012-10-01 | 2012-12-28 | 61d | 804d | 84d | FN_M&S_STND_FY12 [404900%] |  |  | 4,049 | 4,049 | 3,644.1 | 726 | 52 | ܁= | ܁" |  |
| 229 | 1.05.02.02.02.06 | **Superconductor Preparation & Shipment to China (Cold Mass 2)** |  | 20d | 2013-05-01 | 2013-05-29 |  |  |  | 2013-05-01 | 2013-05-29 | 20d | 720d |  |  | 40h |  | 16,320 | 16,320 |  | 1025 | 52 |  |  |  |
| 230 | 1.05.02.02.02.06.01 | Superconductor Preparation & Shipment to China (Cold Mass 2) (FNAL - Labor) |  | 20d | 2013-05-01 | 2013-05-29 | 228, 213, 227 |  |  | 2013-05-01 | 2013-05-29 | 20d | 720d | 0d | FNAD_MECH_SYSTM_TECH [25%] | 40h |  | 3,320 | 3,320 |  | 1026 | 52 | ܁= | ܁" |  |
| 231 | 1.05.02.02.02.06.02 | Superconductor Preparation & Shipment to China (Cold Mass 2) (FNAL - M&S) |  | 20d | 2013-05-01 | 2013-05-29 | 230SS |  |  | 2013-05-01 | 2013-05-29 | 20d | 720d | 0d | FN_M&S_STND_FY12 |  |  | 13,000 | 13,000 |  | 1027 | 52 | ܁= | ܁" |  |
| 232 | 1.05.02.02.02.06.03 | L4 - Superconductor Preparation & Shipment to China (Cold Mass 2) Arrives at China | milestone | 0d | 2013-05-29 | 2013-05-29 | 230, 231 |  |  | 2013-05-29 | 2013-05-29 | 0d | 720d | 0d |  |  |  |  |  |  | 1029 | 52 | ܁= |  |  |
| 233 | 1.05.02.02.02.07 | **Superconductor Preparation & Shipment to China (Cold Mass 3)** |  | 20d | 2013-08-09 | 2013-09-06 |  |  |  | 2013-08-09 | 2013-09-06 | 20d | 840d |  |  | 40h |  | 16,320 | 16,320 |  | 1034 | 52 |  |  |  |
| 234 | 1.05.02.02.02.07.01 | Superconductor Preparation & Shipment to China (Cold Mass 3) (FNAL - Labor) |  | 20d | 2013-08-09 | 2013-09-06 | 232FS+50d |  |  | 2013-08-09 | 2013-09-06 | 20d | 840d | 0d | FNAD_MECH_SYSTM_TECH [25%] | 40h |  | 3,320 | 3,320 |  | 1036 | 52 | ܁= | ܁" |  |
| 235 | 1.05.02.02.02.07.02 | Superconductor Preparation & Shipment to China (Cold Mass 3) (FNAL - M&S) |  | 20d | 2013-08-09 | 2013-09-06 | 234SS |  |  | 2013-08-09 | 2013-09-06 | 20d | 840d | 0d | FN_M&S_STND_FY12 |  |  | 13,000 | 13,000 |  | 1037 | 52 | ܁= | ܁" |  |
| 236 | 1.05.02.02.02.07.03 | L4 - Superconductor Preparation & Shipment to China (Cold Mass 3) Arrives at China | milestone | 0d | 2013-09-06 | 2013-09-06 | 234, 235 |  |  | 2013-09-06 | 2013-09-06 | 0d | 840d | 0d |  |  |  |  |  |  | 1038 | 52 | ܁= |  |  |
| 237 | 1.05.02.02.02.08 | **Superconductor Preparation & Shipment to China (Cold Mass 4)** |  | 20d | 2013-11-18 | 2013-12-17 |  |  |  | 2013-11-18 | 2013-12-17 | 20d | 950d |  |  | 40h |  | 16,320 | 16,320 |  | 1035 | 52 |  |  |  |
| 238 | 1.05.02.02.02.08.01 | Superconductor Preparation & Shipment to China (Cold Mass 4) (FNAL - Labor) |  | 20d | 2013-11-18 | 2013-12-17 | 236FS+50d |  |  | 2013-11-18 | 2013-12-17 | 20d | 950d | 0d | FNAD_MECH_SYSTM_TECH [25%] | 40h |  | 3,320 | 3,320 |  | 1039 | 52 | ܁= | ܁" |  |
| 239 | 1.05.02.02.02.08.02 | Superconductor Preparation & Shipment to China (Cold Mass 4) (FNAL - M&S) |  | 20d | 2013-11-18 | 2013-12-17 | 238SS |  |  | 2013-11-18 | 2013-12-17 | 20d | 950d | 0d | FN_M&S_STND_FY12 |  |  | 13,000 | 13,000 |  | 1040 | 52 | ܁= | ܁" |  |
| 240 | 1.05.02.02.02.08.03 | L4 - Superconductor Preparation & Shipment to China (Cold Mass 4) Arrives at China | milestone | 0d | 2013-12-17 | 2013-12-17 | 238, 239 |  |  | 2013-12-17 | 2013-12-17 | 0d | 950d | 30d |  |  |  |  |  |  | 1041 | 52 | ܁= |  |  |

Notes:
- 224: IMPACT:(Delay of Assembly and Testing of CCM Prototype) - ACTION: (Assess failure and incorporate necessary modifications into preparation of 2nd cold mass)

| ID | WBS | Task | Type | Duration | Start | Finish | Predecessors | Baseline start | Baseline finish | Baseline duration | Total slack | Free slack | Resources | Work | Cost | Baseline cost | CobraUID | WBS-L3 Text18 | Resp Instit Name/Code | Funding Type | Milestone Levels |
| --- | --- | --- | --- | --- | --- | --- | --- | --- | --- | --- | --- | --- | --- | --- | --- | --- | --- | --- | --- | --- | --- |
| 241 | 1.05.02.02.02.09 | **Coil Winding Test at Start of Cold Mass 2 (China)** |  | 10d | 2013-05-30 | 2013-06-12 |  | 2013-05-30 | 2013-06-12 | 10d | 720d |  |  | 102h | 40,930 | 40,930 | 727 | 52 |  |  |  |
| 242 | 1.05.02.02.02.09.01 | Coil Winding Test (China) (LBNL - Resources) |  | 10d | 2013-05-30 | 2013-06-12 | 222, 232 | 2013-05-30 | 2013-06-12 | 10d | 720d | 0d | LBNL_MECH_ENG; LBNL_LABOR | 102h | 17,910 | 17,910 | 728 | 52 | ܁A | ܁` |  |
| 243 | 1.05.02.02.02.09.02 | Coil Winding Test (China) (LBNL - M&S) |  | 10d | 2013-05-30 | 2013-06-12 | 242SS | 2013-05-30 | 2013-06-12 | 10d | 720d | 0d | LBNL_M&S |  | 23,020 | 23,020 | 729 | 52 | ܁A | ܁` |  |
| 244 | 1.05.02.02.02.10 | **Cold Mass #2 Winding (China)** |  | 80d | 2013-06-13 | 2013-10-04 |  | 2013-06-13 | 2013-10-04 | 80d | 720d |  |  | 170h | 75,900 | 75,900 | 730 | 52 |  |  |  |
| 245 | 1.05.02.02.02.10.01 | Cold Mass #2 Winding (China) (LBNL - Resources) |  | 80d | 2013-06-13 | 2013-10-04 | 242, 243 | 2013-06-13 | 2013-10-04 | 80d | 720d | 0d | LBNL_MECH_ENG; LBNL_LABOR | 170h | 29,850 | 29,850 | 731 | 52 | ܁A | ܁` |  |
| 246 | 1.05.02.02.02.10.02 | Cold Mass #2 Winding (China) (LBNL - M&S) |  | 80d | 2013-06-13 | 2013-10-04 | 245SS | 2013-06-13 | 2013-10-04 | 80d | 720d | 0d | LBNL_M&S |  | 46,050 | 46,050 | 732 | 52 | ܁A | ܁` |  |
| 247 | 1.05.02.02.02.10.03 | (RISK)-(R3) - Cold Mass #2 Winding (China) | milestone | 0d | 2013-10-04 | 2013-10-04 | 245, 246 | 2013-10-04 | 2013-10-04 | 0d | 720d | 0d |  |  |  |  | 733 | 52 | ܁A |  | R3 |
| 248 | 1.05.02.02.02.10.04 | Cold Mass #2 Winding (China) - Possible Costs for this R3 Risk (UID-733) |  | 1d | 2013-10-04 | 2013-10-04 | 247FS-1d | 2013-10-04 | 2013-10-04 | 1d | 1285d |  |  |  |  |  | 1122 | 52 | ܁= |  |  |
| 249 | 1.05.02.02.02.11 | **Cold Mass #2 Shipping from China to LBNL** |  | 25d | 2013-10-07 | 2013-11-08 |  | 2013-10-07 | 2013-11-08 | 25d | 720d |  |  |  | 13,800 | 13,800 | 734 | 52 |  |  |  |
| 250 | 1.05.02.02.02.11.01 | Cold Mass #2 Shipping from China to LBNL (LBNL - Resources) |  | 25d | 2013-10-07 | 2013-11-08 | 247 | 2013-10-07 | 2013-11-08 | 25d | 720d | 0d |  |  |  |  | 735 | 52 | ܁A | ܁` |  |
| 251 | 1.05.02.02.02.11.02 | Cold Mass #2 Shipping from China to LBNL (LBNL - M&S) |  | 25d | 2013-10-07 | 2013-11-08 | 250SS | 2013-10-07 | 2013-11-08 | 25d | 720d | 0d | LBNL_M&S |  | 13,800 | 13,800 | 736 | 52 | ܁A | ܁` |  |
| 252 | 1.05.02.02.02.11.03 | L4 - Cold Mass #2 Arrives at LBNL | milestone | 0d | 2013-11-08 | 2013-11-08 | 250, 251 | 2013-11-08 | 2013-11-08 | 0d | 720d | 32d |  |  |  |  | 737 | 52 | ܁A |  |  |
| 253 | 1.05.02.02.02.12 | **Cold Mass #3 Winding (China)** |  | 80d | 2013-10-07 | 2014-02-04 |  | 2013-10-07 | 2014-02-04 | 80d | 820d |  |  | 170h | 75,900 | 75,900 | 739 | 52 |  |  |  |
| 254 | 1.05.02.02.02.12.01 | Cold Mass #3 Winding (China) (LBNL - Resources) |  | 80d | 2013-10-07 | 2014-02-04 | 247, 236 | 2013-10-07 | 2014-02-04 | 80d | 820d | 0d | LBNL_MECH_ENG; LBNL_LABOR | 170h | 29,850 | 29,850 | 740 | 52 | ܁A | ܁` |  |
| 255 | 1.05.02.02.02.12.02 | Cold Mass #3 Winding (China) (LBNL - M&S) |  | 80d | 2013-10-07 | 2014-02-04 | 254SS | 2013-10-07 | 2014-02-04 | 80d | 820d | 0d | LBNL_M&S |  | 46,050 | 46,050 | 741 | 52 | ܁A | ܁` |  |
| 256 | 1.05.02.02.02.12.03 | (RISK)-(R4) - Cold Mass #3 Winding (China) | milestone | 0d | 2014-02-04 | 2014-02-04 | 254, 255 | 2014-02-04 | 2014-02-04 | 0d | 820d | 0d |  |  |  |  | 742 | 52 | ܁A |  | R4 |
| 257 | 1.05.02.02.02.13 | **Cold Mass #3 Shipping from China to LBNL** |  | 25d | 2014-02-05 | 2014-03-11 |  | 2014-02-05 | 2014-03-11 | 25d | 820d |  |  |  | 13,800 | 13,800 | 743 | 52 |  |  |  |
| 258 | 1.05.02.02.02.13.01 | Cold Mass #3 Shipping from China to LBNL (LBNL - Resources) |  | 25d | 2014-02-05 | 2014-03-11 | 256, 252 | 2014-02-05 | 2014-03-11 | 25d | 820d | 0d |  |  |  |  | 744 | 52 | ܁A | ܁` |  |
| 259 | 1.05.02.02.02.13.02 | Cold Mass #3 Shipping from China to LBNL (LBNL - M&S) |  | 25d | 2014-02-05 | 2014-03-11 | 258SS | 2014-02-05 | 2014-03-11 | 25d | 820d | 0d | LBNL_M&S |  | 13,800 | 13,800 | 745 | 52 | ܁A | ܁` |  |
| 260 | 1.05.02.02.02.13.03 | L4 - Cold Mass #3 Arrives at LBNL | milestone | 0d | 2014-03-11 | 2014-03-11 | 258, 259 | 2014-03-11 | 2014-03-11 | 0d | 820d | 55d |  |  |  |  | 746 | 52 | ܁A |  |  |
| 261 | 1.05.02.02.02.14 | **Cold Mass #4 Winding (China)** |  | 80d | 2014-02-05 | 2014-05-28 |  | 2014-02-05 | 2014-05-28 | 80d | 920d |  |  | 170h | 75,900 | 75,900 | 748 | 52 |  |  |  |
| 262 | 1.05.02.02.02.14.01 | Cold Mass #4 Winding (China) (LBNL - Resources) |  | 80d | 2014-02-05 | 2014-05-28 | 256, 240 | 2014-02-05 | 2014-05-28 | 80d | 920d | 0d | LBNL_MECH_ENG; LBNL_LABOR | 170h | 29,850 | 29,850 | 749 | 52 | ܁A | ܁` |  |
| 263 | 1.05.02.02.02.14.02 | Cold Mass #4 Winding (China) (LBNL - M&S) |  | 80d | 2014-02-05 | 2014-05-28 | 262SS | 2014-02-05 | 2014-05-28 | 80d | 920d | 0d | LBNL_M&S |  | 46,050 | 46,050 | 750 | 52 | ܁A | ܁` |  |
| 264 | 1.05.02.02.02.14.03 | (RISK)-(R4) - Cold Mass #4 Winding (China) | milestone | 0d | 2014-05-28 | 2014-05-28 | 262, 263 | 2014-05-28 | 2014-05-28 | 0d | 920d | 0d |  |  |  |  | 751 | 52 | ܁A |  | R4 |

Notes:
- 247: IMPACT:(Delay in CCM Prototype and likely delay in MICE Step V in the event that the prototype cold mass (#1) fails. Relatively minor impact otherwise) - ACTION:(Further development of winding procedures)
- 256: IMPACT:() - ACTION:()
- 264: IMPACT:() - ACTION:()

| ID | WBS | Task | Type | Duration | Start | Finish | Predecessors | Baseline start | Baseline finish | Baseline duration | Total slack | Free slack | Resources | Work | Cost | Baseline cost | CobraUID | WBS-L3 Text18 | Resp Instit Name/Code | Funding Type | Milestone Levels |
| --- | --- | --- | --- | --- | --- | --- | --- | --- | --- | --- | --- | --- | --- | --- | --- | --- | --- | --- | --- | --- | --- |
| 265 | 1.05.02.02.02.15 | **Cold Mass #4 Shipping from China to LBNL** |  | 25d | 2014-05-29 | 2014-07-02 |  | 2014-05-29 | 2014-07-02 | 25d | 920d |  |  |  | 13,800 | 13,800 | 752 | 52 |  |  |  |
| 266 | 1.05.02.02.02.15.01 | Cold Mass #4 Shipping from China to LBNL (LBNL - Resources) |  | 25d | 2014-05-29 | 2014-07-02 | 264, 260 | 2014-05-29 | 2014-07-02 | 25d | 920d | 0d |  |  |  |  | 753 | 52 | ܁A | ܁` |  |
| 267 | 1.05.02.02.02.15.02 | Cold Mass #4 Shipping from China to LBNL (LBNL - M&S) |  | 25d | 2014-05-29 | 2014-07-02 | 266SS | 2014-05-29 | 2014-07-02 | 25d | 920d | 0d | LBNL_M&S |  | 13,800 | 13,800 | 754 | 52 | ܁A | ܁` |  |
| 268 | 1.05.02.02.02.15.03 | L4 - Cold Mass #4 Arrives at LBNL | milestone | 0d | 2014-07-02 | 2014-07-02 | 266, 267 | 2014-07-02 | 2014-07-02 | 0d | 920d | 327d |  |  |  |  | 755 | 52 | ܁A |  |  |
| 269 | 1.05.02.02.02.16 | **Cold Mass #2 Preparation and Ship** |  | 80d | 2014-01-02 | 2014-04-24 |  | 2014-01-02 | 2014-04-24 | 80d | 688d |  |  |  | 73,680 | 73,680 | 810 | 52 |  |  |  |
| 270 | 1.05.02.02.02.16.01 | Cold Mass #2 Preparation and Ship (LBNL - Resources) |  | 80d | 2014-01-02 | 2014-04-24 | 22FS+46d, 252 | 2014-01-02 | 2014-04-24 | 80d | 688d | 0d |  |  |  |  | 812 | 52 | ܁A | ܁` |  |
| 271 | 1.05.02.02.02.16.02 | Cold Mass #2 Preparation and Ship (LBNL - M&S) |  | 80d | 2014-01-02 | 2014-04-24 | 270SS | 2014-01-02 | 2014-04-24 | 80d | 688d | 0d | LBNL_M&S |  | 73,680 | 73,680 | 813 | 52 | ܁A | ܁` |  |
| 272 | 1.05.02.02.02.16.03 | L4 - Cold Mass #2 Arrives at FNAL | milestone | 0d | 2014-04-24 | 2014-04-24 | 270, 271 | 2014-04-24 | 2014-04-24 | 0d | 688d | 0d |  |  |  |  | 811 | 52 | ܁A |  |  |
| 273 | 1.05.02.02.02.17 | **Cold Mass #2 Preparation & Test (FNAL)** |  | 100d | 2014-04-25 | 2014-09-16 |  | 2014-04-25 | 2014-09-16 | 100d | 688d |  |  | 1415h | 210,305 | 210,305 | 814 | 52 |  |  |  |
| 274 | 1.05.02.02.02.17.01 | Cold Mass #2 Preparation & Test (FNAL - Labor) |  | 100d | 2014-04-25 | 2014-09-16 | 272 | 2014-04-25 | 2014-09-16 | 100d | 688d | 0d | FNAD_MECH_SYSTM_TECH [130%]; FNAD_MAGNT_DESIGN_EN [16%]; FNAD_AC_EXP_PHYST [31%] | 1415h | 150,305 | 150,305 | 815 | 52 | ܁= | ܁" |  |
| 275 | 1.05.02.02.02.17.02 | Cold Mass #2 Preparation & Test (FNAL - M&S) |  | 100d | 2014-04-25 | 2014-09-16 | 274SS | 2014-04-25 | 2014-09-16 | 100d | 688d | 0d | FN_M&S_STND_FY12 |  | 60,000 | 60,000 | 816 | 52 | ܁= | ܁" |  |
| 276 | 1.05.02.02.02.17.03 | L4 - Cold Mass #2 Ready for Use | milestone | 0d | 2014-09-16 | 2014-09-16 | 274, 275 | 2014-09-16 | 2014-09-16 | 0d | 688d | 25d |  |  |  |  | 817 | 52 | ܁= |  |  |
| 277 | 1.05.02.02.02.17.04 | (RISK)-(R4) - Cold Mass #2 Preparation & Test (FNAL) | milestone | 0d | 2014-09-16 | 2014-09-16 | 274, 275 | 2014-09-16 | 2014-09-16 | 0d | 688d | 25d |  |  |  |  | 818 | 52 | ܁= |  | R4 |
| 278 | 1.05.02.02.02.18 | **Cold Mass #3 Preparation and Ship** |  | 80d | 2014-10-22 | 2015-02-19 |  | 2014-10-22 | 2015-02-19 | 80d | 663d |  |  |  | 73,680 | 73,680 | 819 | 52 |  |  |  |
| 279 | 1.05.02.02.02.18.01 | Cold Mass #3 Preparation and Ship (LBNL - Resources) |  | 80d | 2014-10-22 | 2015-02-19 | 260, 23, 276, 277 | 2014-10-22 | 2015-02-19 | 80d | 663d | 0d |  |  |  |  | 820 | 52 | ܁A | ܁` |  |
| 280 | 1.05.02.02.02.18.02 | Cold Mass #3 Preparation and Ship (LBNL - M&S) |  | 80d | 2014-10-22 | 2015-02-19 | 279SS | 2014-10-22 | 2015-02-19 | 80d | 663d | 0d | LBNL_M&S |  | 73,680 | 73,680 | 821 | 52 | ܁A | ܁` |  |
| 281 | 1.05.02.02.02.18.03 | L4 - Cold Mass #3 Ready for Use | milestone | 0d | 2015-02-19 | 2015-02-19 | 279, 280 | 2015-02-19 | 2015-02-19 | 0d | 663d | 0d |  |  |  |  | 822 | 52 | ܁A |  |  |
| 282 | 1.05.02.02.02.19 | **Cold Mass #3 Preparation & Test (FNAL)** |  | 100d | 2015-02-20 | 2015-07-13 |  | 2015-02-20 | 2015-07-13 | 100d | 663d |  |  | 1415h | 210,305 | 210,305 | 823 | 52 |  |  |  |
| 283 | 1.05.02.02.02.19.01 | Cold Mass #3 Preparation & Test (FNAL - Labor) |  | 100d | 2015-02-20 | 2015-07-13 | 281 | 2015-02-20 | 2015-07-13 | 100d | 663d | 0d | FNAD_MECH_SYSTM_TECH [130%]; FNAD_MAGNT_DESIGN_EN [16%]; FNAD_AC_EXP_PHYST [31%] | 1415h | 150,305 | 150,305 | 824 | 52 | ܁= | ܁" |  |
| 284 | 1.05.02.02.02.19.02 | Cold Mass #3 Preparation & Test (FNAL - M&S) |  | 100d | 2015-02-20 | 2015-07-13 | 283SS | 2015-02-20 | 2015-07-13 | 100d | 663d | 0d | FN_M&S_STND_FY12 |  | 60,000 | 60,000 | 825 | 52 | ܁= | ܁" |  |
| 285 | 1.05.02.02.02.19.03 | L4 - Cold Mass #3 Ready for Use | milestone | 0d | 2015-07-13 | 2015-07-13 | 283, 284 | 2015-07-13 | 2015-07-13 | 0d | 663d | 0d |  |  |  |  | 826 | 52 | ܁= |  |  |
| 286 | 1.05.02.02.02.19.04 | (RISK)-(R4) - Cold Mass #3 Preparation & Test (FNAL) | milestone | 0d | 2015-07-13 | 2015-07-13 | 285 | 2015-07-13 | 2015-07-13 | 0d | 663d | 70d |  |  |  |  | 1024 | 52 | ܁= |  | R4 |
| 287 | 1.05.02.02.02.20 | **Cold Mass #4 Preparation and Ship** |  | 80d | 2015-10-21 | 2016-02-18 |  | 2015-10-21 | 2016-02-18 | 80d | 593d |  |  |  | 73,680 | 73,680 | 827 | 52 |  |  |  |
| 288 | 1.05.02.02.02.20.01 | Cold Mass #4 Preparation and Ship (LBNL - Resources) |  | 80d | 2015-10-21 | 2016-02-18 | 268, 24, 285, 286 | 2015-10-21 | 2016-02-18 | 80d | 593d | 0d |  |  |  |  | 828 | 52 | ܁A | ܁` |  |
| 289 | 1.05.02.02.02.20.02 | Cold Mass #4 Preparation and Ship (LBNL - M&S) |  | 80d | 2015-10-21 | 2016-02-18 | 288SS | 2015-10-21 | 2016-02-18 | 80d | 593d | 0d | LBNL_M&S |  | 73,680 | 73,680 | 829 | 52 | ܁A | ܁` |  |
| 290 | 1.05.02.02.02.20.03 | L4 - Cold Mass #4 Ready for Use | milestone | 0d | 2016-02-18 | 2016-02-18 | 288, 289 | 2016-02-18 | 2016-02-18 | 0d | 593d | 0d |  |  |  |  | 830 | 52 | ܁A |  |  |

Notes:
- 277: IMPACT:() - ACTION:()
- 286: IMPACT:() - ACTION:()

| ID | WBS | Task | Type | Duration | Start | Finish | Predecessors | Complete | Remaining | Baseline start | Baseline finish | Baseline duration | Total slack | Free slack | Resources | Work | Actual work | Cost | Baseline cost | Actual cost | CobraUID | WBS-L3 Text18 | Resp Instit Name/Code | Funding Type | Milestone Levels | Risk ID |
| --- | --- | --- | --- | --- | --- | --- | --- | --- | --- | --- | --- | --- | --- | --- | --- | --- | --- | --- | --- | --- | --- | --- | --- | --- | --- | --- |
| 291 | 1.05.02.02.02.21 | **Cold Mass #4 Preparation & Test (FNAL)** |  | 100d | 2016-02-19 | 2016-07-11 |  |  |  | 2016-02-19 | 2016-07-11 | 100d | 593d |  |  | 1415h |  | 210,305 | 210,305 |  | 831 | 52 |  |  |  |  |
| 292 | 1.05.02.02.02.21.01 | Cold Mass #4 Preparation & Test (FNAL - Labor) |  | 100d | 2016-02-19 | 2016-07-11 | 290 |  |  | 2016-02-19 | 2016-07-11 | 100d | 593d | 0d | FNAD_MECH_SYSTM_TECH [130%]; FNAD_MAGNT_DESIGN_EN [16%]; FNAD_AC_EXP_PHYST [31%] | 1415h |  | 150,305 | 150,305 |  | 832 | 52 | ܁= | ܁" |  |  |
| 293 | 1.05.02.02.02.21.02 | Cold Mass #4 Preparation & Test (FNAL - M&S) |  | 100d | 2016-02-19 | 2016-07-11 | 292SS |  |  | 2016-02-19 | 2016-07-11 | 100d | 593d | 0d | FN_M&S_STND_FY12 |  |  | 60,000 | 60,000 |  | 833 | 52 | ܁= | ܁" |  |  |
| 294 | 1.05.02.02.02.21.03 | L4 - Cold Mass #4 Ready for Use (Only Needed if Failure of Cold Mass #1, #2, or #3) No Successor | milestone | 0d | 2016-07-11 | 2016-07-11 | 292, 293 |  |  | 2016-07-11 | 2016-07-11 | 0d | 593d |  |  |  |  |  |  |  | 834 | 52 | ܁= |  |  |  |
| 295 | 1.05.02.02.03 | **CC Cryostat Design** |  | 501d | 2011-10-03 A | 2013-09-30 |  | 90% | 49.69d | 2011-10-03 | 2013-09-30 | 501d | 1289d |  |  | 884h | 864h | 181,260 | 181,260 | 145,008 | 710 | 52 |  |  |  |  |
| 296 | 1.05.02.02.03.01 | **CC Cryostat Design (China & LBNL)** |  | 305d | 2011-10-03 A | 2012-12-18 A |  | 100% |  | 2011-10-03 | 2012-12-18 | 305d |  |  |  |  |  |  |  |  | 836 | 52 |  |  |  |  |
| 297 | 1.05.02.02.03.01.01 | CC Cryostat Design (LBNL - Resources) |  | 305d | 2011-10-03 A | 2012-12-18 A | 19 | 100% |  | 2011-10-03 | 2012-12-18 | 305d |  |  |  |  |  |  |  |  | 839 | 52 | ܁A | ܁` |  |  |
| 298 | 1.05.02.02.03.01.02 | CC Cryostat Design (LBNL - M&S) |  | 305d | 2011-10-03 A | 2012-12-18 A | 297SS | 100% |  | 2011-10-03 | 2012-12-18 | 305d |  |  |  |  |  |  |  |  | 840 | 52 | ܁A | ܁` |  |  |
| 299 | 1.05.02.02.03.02 | **CC Thermal Shield Design** |  | 150d | 2013-02-28 A | 2013-09-30 |  | 80% | 30d | 2013-02-28 | 2013-09-30 | 150d | 1289d |  |  | 442h | 442h | 90,630 | 90,630 | 72,504 | 837 | 52 |  |  |  |  |
| 300 | 1.05.02.02.03.02.01 | CC Thermal Shield Design (LBNL - Resources) |  | 150d | 2013-02-28 A | 2013-09-30 | 21FS+86d | 80% | 30d | 2013-02-28 | 2013-09-30 | 150d | 1289d | 0d | LBNL_MECH_ENG; LBNL_LABOR | 442h | 442h | 76,830 | 76,830 | 61,464 | 841 | 52 | ܁A | ܁` |  |  |
| 301 | 1.05.02.02.03.02.02 | CC Thermal Shield Design (LBNL - M&S) |  | 150d | 2013-02-28 A | 2013-09-30 | 300SS | 80% | 30d | 2013-02-28 | 2013-09-30 | 150d | 161d | 0d | LBNL_M&S |  |  | 13,800 | 13,800 | 11,040 | 842 | 52 | ܁A | ܁` |  |  |
| 302 | 1.05.02.02.03.03 | **CC Cold Mass Cooling Loop Design** |  | 150d | 2013-02-28 A | 2013-09-30 |  | 80% | 30d | 2013-02-28 | 2013-09-30 | 150d | 1289d |  |  | 442h | 422h | 90,630 | 90,630 | 72,504 | 838 | 52 |  |  |  |  |
| 303 | 1.05.02.02.03.03.01 | CC Cold Mass Cooling Loop Design (LBNL - Resources) |  | 150d | 2013-02-28 A | 2013-09-30 | 300SS, 301SS | 80% | 30d | 2013-02-28 | 2013-09-30 | 150d | 1289d | 0d | LBNL_MECH_ENG; LBNL_LABOR | 442h | 422h | 76,830 | 76,830 | 61,464 | 843 | 52 | ܁A | ܁` |  |  |
| 304 | 1.05.02.02.03.03.02 | CC Cold Mass Cooling Loop Design (LBNL - M&S) |  | 150d | 2013-02-28 A | 2013-09-30 | 303SS | 80% | 30d | 2013-02-28 | 2013-09-30 | 150d | 161d |  | LBNL_M&S |  |  | 13,800 | 13,800 | 11,040 | 844 | 52 | ܁A | ܁` |  |  |
| 305 | 1.05.02.02.04 | **CC Cryostat Fabrication** |  | 981d | 2012-10-01 A | 2016-08-26 |  | 10% | 886.48d | 2012-10-01 | 2016-08-26 | 981d | 559d |  |  | 10503h | 1078.75h | 3,206,047 | 3,206,047 | 283,725 | 711 | 52 |  |  |  |  |
| 306 | 1.05.02.02.04.01 | **CC Cryostat Fabrication #1 (CCM Prototype)** |  | 312d | 2012-10-01 A | 2013-12-30 |  | 25% | 234d | 2012-10-01 | 2013-12-30 | 312d | 0d |  |  | 4315h | 1078.75h | 1,134,900 | 1,134,900 | 283,725 | 835 | 52 |  |  |  |  |
| 307 | 1.05.02.02.04.01.01 | CC Cryostat Fabrication #1 (CCM Prototype) (LBNL - Resources) |  | 312d | 2012-10-01 A | 2013-12-30 | 21FS-15d, 298FS-60d, 304FF-100d, 301FF-100d, 297FS-60d | 25% | 234d | 2012-10-01 | 2013-12-30 | 312d | 0d |  | LBNL_MECH_TECH; LBNL_MECH_ENG; LBNL_SCIENTIST; LBNL_POSTDOC; LBNL_LABOR | 4315h | 1078.75h | 547,800 | 547,800 | 136,950 | 845 | 52 | ܁A | ܁` |  |  |
| 308 | 1.05.02.02.04.01.02 | CC Cryostat Fabrication #1 (CCM Prototype) (LBNL - M&S) |  | 312d | 2012-10-01 A | 2013-12-30 | 307SS, 304FF-100d, 301FF-100d | 25% | 234d | 2012-10-01 | 2013-12-30 | 312d | 0d |  | LBNL_M&S |  |  | 587,100 | 587,100 | 146,775 | 846 | 52 | ܁A | ܁` |  |  |
| 309 | 1.05.02.02.04.02 | **CC Cryostat #1 (CCM Prototype) Prepare for Shipment to FNAL** |  | 30d | 2014-01-02 | 2014-02-13 |  |  |  | 2014-01-02 | 2014-02-13 | 30d | 0d |  |  |  |  | 11,512 | 11,512 |  | 848 | 52 |  |  |  |  |
| 310 | 1.05.02.02.04.02.01 | CC Cryostat #1 (CCM Prototype) Prepare for Shipment to FNAL (LBNL - Resources) |  | 30d | 2014-01-02 | 2014-02-13 | 307, 308 |  |  | 2014-01-02 | 2014-02-13 | 30d | 0d |  |  |  |  |  |  |  | 849 | 52 | ܁A | ܁` |  |  |
| 311 | 1.05.02.02.04.02.02 | CC Cryostat #1 (CCM Prototype) Prepare for Shipment to FNAL (LBNL - M&S) |  | 30d | 2014-01-02 | 2014-02-13 | 310SS |  |  | 2014-01-02 | 2014-02-13 | 30d | 0d |  | LBNL_M&S |  |  | 11,512 | 11,512 |  | 850 | 52 | ܁A | ܁` |  |  |
| 312 | 1.05.02.02.04.02.03 | L4 - CC Cryostat #1 (CCM Prototype) Assembly Ready for Shipment to FNAL | milestone | 0d | 2014-02-13 | 2014-02-13 | 310, 311 |  |  | 2014-02-13 | 2014-02-13 | 0d | 0d |  |  |  |  |  |  |  | 847 | 52 | ܁A |  |  |  |
| 313 | 1.05.02.02.04.03 | **CC Cryostat #1 (CCM Prototype) Shipping to FNAL** |  | 10d | 2014-02-14 | 2014-02-27 |  |  |  | 2014-02-14 | 2014-02-27 | 10d | 0d |  |  |  |  | 34,537 | 34,537 |  | 969 | 52 |  |  |  |  |
| 314 | 1.05.02.02.04.03.01 | CC Cryostat #1 (CCM Prototype) Shipping to FNAL (LBNL - Resources) |  | 10d | 2014-02-14 | 2014-02-27 | 312 |  |  | 2014-02-14 | 2014-02-27 | 10d | 0d |  |  |  |  |  |  |  | 970 | 52 | ܁A | ܁` |  |  |
| 315 | 1.05.02.02.04.03.02 | CC Cryostat #1 (CCM Prototype) Shipping to FNAL (LBNL - M&S) |  | 10d | 2014-02-14 | 2014-02-27 | 314SS |  |  | 2014-02-14 | 2014-02-27 | 10d | 0d |  | LBNL_M&S |  |  | 34,537 | 34,537 |  | 971 | 52 | ܁A | ܁` |  |  |
| 316 | 1.05.02.02.04.03.03 | L4 - CC Cryostat #1 (CCM Prototype) Arrived at FNAL | milestone | 0d | 2014-02-27 | 2014-02-27 | 314, 315 |  |  | 2014-02-27 | 2014-02-27 | 0d | 0d |  |  |  |  |  |  |  | 972 | 52 | ܁A |  |  |  |
| 317 | 1.05.02.02.04.03.04 | (RISK)-(R2) - CC Cryostat #1 (CCM Prototype) Arrived at FNAL | milestone | 0d | 2014-02-27 | 2014-02-27 | 314, 315 |  |  | 2014-02-27 | 2014-02-27 | 0d | 1188d | 0d |  |  |  |  |  |  | 981 | 52 | ܁A |  | R2 | 4, 10 |
| 318 | 1.05.02.02.04.03.05 | CC Cryostat #1 (CCM Prototype) Arrived at FNAL - Possible Costs for this R2 Risk (UID-981) |  | 1d | 2014-02-27 | 2014-02-27 | 317FS-1d |  |  | 2014-02-27 | 2014-02-27 | 1d | 1188d |  |  |  |  |  |  |  | 1123 | 52 | ܁= |  |  | 4, 10 |

Notes:
- 317: IMPACT:(Delay in SCTS Test in MTA. Potential delay in CCM prototype testing with RF cavity in MTA)(Delay in final design of MICE RF system) - ACTION:(Coupler re-design and repeat testing with likely 9 month delay to some parts of 201 MHz test program)

| ID | WBS | Task | Type | Duration | Start | Finish | Predecessors | Baseline start | Baseline finish | Baseline duration | Total slack | Free slack | Resources | Work | Cost | Baseline cost | CobraUID | WBS-L3 Text18 | Resp Instit Name/Code | Funding Type |
| --- | --- | --- | --- | --- | --- | --- | --- | --- | --- | --- | --- | --- | --- | --- | --- | --- | --- | --- | --- | --- |
| 319 | 1.05.02.02.04.04 | **CC Cryostat Fabrication #2 (CCM #1)** |  | 189d | 2014-02-14 | 2014-11-10 |  | 2014-02-14 | 2014-11-10 | 189d | 87d |  |  | 3094h | 966,500 | 966,500 | 852 | 52 |  |  |
| 320 | 1.05.02.02.04.04.01 | CC Cryostat Fabrication #2 (CCM #1) (LBNL - Resources) |  | 189d | 2014-02-14 | 2014-11-10 | 312 | 2014-02-14 | 2014-11-10 | 189d | 87d | 0d | LBNL_MECH_TECH; LBNL_SCIENTIST; LBNL_POSTDOC; LBNL_LABOR | 3094h | 379,400 | 379,400 | 853 | 52 | ܁A | ܁` |
| 321 | 1.05.02.02.04.04.02 | CC Cryostat Fabrication #2 (CCM #1) (LBNL - M&S) |  | 189d | 2014-02-14 | 2014-11-10 | 320SS | 2014-02-14 | 2014-11-10 | 189d | 87d | 0d | LBNL_M&S |  | 587,100 | 587,100 | 854 | 52 | ܁A | ܁` |
| 322 | 1.05.02.02.04.05 | **CC Cryostat #2 (CCM #1) Prepare for Shipment to FNAL** |  | 30d | 2014-11-11 | 2014-12-26 |  | 2014-11-11 | 2014-12-26 | 30d | 87d |  |  |  | 11,512 | 11,512 | 855 | 52 |  |  |
| 323 | 1.05.02.02.04.05.01 | CC Cryostat #2 (CCM #1) Prepare for Shipment to FNAL (LBNL - Resources) |  | 30d | 2014-11-11 | 2014-12-26 | 321, 320 | 2014-11-11 | 2014-12-26 | 30d | 87d | 0d |  |  |  |  | 856 | 52 | ܁A | ܁` |
| 324 | 1.05.02.02.04.05.02 | CC Cryostat #2 (CCM #1) Prepare for Shipment to FNAL (LBNL - M&S) |  | 30d | 2014-11-11 | 2014-12-26 | 323SS | 2014-11-11 | 2014-12-26 | 30d | 87d | 0d | LBNL_M&S |  | 11,512 | 11,512 | 857 | 52 | ܁A | ܁` |
| 325 | 1.05.02.02.04.05.03 | L4 - CC Cryostat #2 (CCM #1) Ready for Shipment to FNAL | milestone | 0d | 2014-12-26 | 2014-12-26 | 323, 324 | 2014-12-26 | 2014-12-26 | 0d | 87d | 0d |  |  |  |  | 858 | 52 | ܁A |  |
| 326 | 1.05.02.02.04.06 | **CC Cryostat #2 (CCM #1 ) Shipping to FNAL** |  | 10d | 2014-12-29 | 2015-01-13 |  | 2014-12-29 | 2015-01-13 | 10d | 87d |  |  |  | 34,537 | 34,537 | 973 | 52 |  |  |
| 327 | 1.05.02.02.04.06.01 | CC Cryostat #2 (CCM #1 ) Shipping to FNAL (LBNL - Resources) |  | 10d | 2014-12-29 | 2015-01-13 | 325 | 2014-12-29 | 2015-01-13 | 10d | 87d | 0d |  |  |  |  | 974 | 52 | ܁A | ܁` |
| 328 | 1.05.02.02.04.06.02 | CC Cryostat #2 (CCM #1 ) Shipping to FNAL (LBNL - M&S) |  | 10d | 2014-12-29 | 2015-01-13 | 327SS | 2014-12-29 | 2015-01-13 | 10d | 87d | 0d | LBNL_M&S |  | 34,537 | 34,537 | 975 | 52 | ܁A | ܁` |
| 329 | 1.05.02.02.04.06.03 | L4 - CC Cryostat #2 (CCM #1) Arrived at FNAL | milestone | 0d | 2015-01-13 | 2015-01-13 | 327, 328 | 2015-01-13 | 2015-01-13 | 0d | 87d | 67d |  |  |  |  | 976 | 52 | ܁A |  |
| 330 | 1.05.02.02.04.07 | **CC Cryostat Fabrication #3 (CCM #2)** |  | 188d | 2015-10-01 | 2016-06-30 |  | 2015-10-01 | 2016-06-30 | 188d | 559d |  |  | 3094h | 966,500 | 966,500 | 859 | 52 |  |  |
| 331 | 1.05.02.02.04.07.01 | CC Cryostat Fabrication #3 (CCM #2) (LBNL - Resources) |  | 188d | 2015-10-01 | 2016-06-30 | 24FS-14d, 329 | 2015-10-01 | 2016-06-30 | 188d | 559d | 0d | LBNL_MECH_TECH; LBNL_SCIENTIST; LBNL_POSTDOC; LBNL_LABOR | 3094h | 379,400 | 379,400 | 860 | 52 | ܁A | ܁` |
| 332 | 1.05.02.02.04.07.02 | CC Cryostat Fabrication #3 (CCM #2) (LBNL - M&S) |  | 188d | 2015-10-01 | 2016-06-30 | 331SS | 2015-10-01 | 2016-06-30 | 188d | 559d | 0d | LBNL_M&S |  | 587,100 | 587,100 | 861 | 52 | ܁A | ܁` |
| 333 | 1.05.02.02.04.08 | **CC Cryostat #3 (CCM #2) Prepare for Shipment to FNAL** |  | 30d | 2016-07-01 | 2016-08-12 |  | 2016-07-01 | 2016-08-12 | 30d | 559d |  |  |  | 11,512 | 11,512 | 862 | 52 |  |  |
| 334 | 1.05.02.02.04.08.01 | CC Cryostat #3 (CCM #2) Prepare for Shipping to FNAL (LBNL - Resources) |  | 30d | 2016-07-01 | 2016-08-12 | 332 | 2016-07-01 | 2016-08-12 | 30d | 559d | 0d |  |  |  |  | 863 | 52 | ܁A | ܁` |
| 335 | 1.05.02.02.04.08.02 | CC Cryostat #3 (CCM #2) Prepare for Shipping to FNAL (LBNL - M&S) |  | 30d | 2016-07-01 | 2016-08-12 | 334SS | 2016-07-01 | 2016-08-12 | 30d | 559d | 0d | LBNL_M&S |  | 11,512 | 11,512 | 864 | 52 | ܁A | ܁` |
| 336 | 1.05.02.02.04.08.03 | L4 - CC Cryostat #3 (CCM #2) Ready for Shipment to FNAL | milestone | 0d | 2016-08-12 | 2016-08-12 | 334, 335 | 2016-08-12 | 2016-08-12 | 0d | 559d | 0d |  |  |  |  | 865 | 52 | ܁A |  |
| 337 | 1.05.02.02.04.09 | **CC Cryostat #3 (CCM #2 ) Shipping to FNAL** |  | 10d | 2016-08-15 | 2016-08-26 |  | 2016-08-15 | 2016-08-26 | 10d | 559d |  |  |  | 34,537 | 34,537 | 977 | 52 |  |  |
| 338 | 1.05.02.02.04.09.01 | CC Cryostat #3 (CCM #2 ) Shipping to FNAL (LBNL - Resources) |  | 10d | 2016-08-15 | 2016-08-26 | 336 | 2016-08-15 | 2016-08-26 | 10d | 559d | 0d |  |  |  |  | 978 | 52 | ܁A | ܁` |
| 339 | 1.05.02.02.04.09.02 | CC Cryostat #3 (CCM #2 ) Shipping to FNAL (LBNL - M&S) |  | 10d | 2016-08-15 | 2016-08-26 | 338SS | 2016-08-15 | 2016-08-26 | 10d | 559d | 0d | LBNL_M&S |  | 34,537 | 34,537 | 979 | 52 | ܁A | ܁` |
| 340 | 1.05.02.02.04.09.03 | L4 - CC Cryostat #3 (CCM #2) Arrived at FNAL | milestone | 0d | 2016-08-26 | 2016-08-26 | 338, 339 | 2016-08-26 | 2016-08-26 | 0d | 559d |  |  |  |  |  | 980 | 52 | ܁A |  |
| 341 | 1.05.02.02.05 | **CC Magnet Assembly** |  | 1253d | 2013-10-01 | 2018-09-27 |  | 2013-10-01 | 2018-09-27 | 1253d | 1d |  |  | 25974h | 3,902,262 | 3,902,262 | 712 | 52 |  |  |
| 342 | 1.05.02.02.05.01 | **CC Assembly Area Preparation** |  | 100d | 2013-10-01 | 2014-02-26 |  | 2013-10-01 | 2014-02-26 | 100d | 1d |  |  | 4368h | 636,744 | 636,744 | 866 | 52 |  |  |
| 343 | 1.05.02.02.05.01.01 | CC Assembly Area Preparation (FNAL - Labor) |  | 100d | 2013-10-01 | 2014-02-26 | 22FS-15d | 2013-10-01 | 2014-02-26 | 100d | 1d | 0d | FNAD_MECH_SYSTM_TECH [470%]; FNAD_MAGNT_DESIGN_EN [605%]; FNAD_MECH_DRAFTER [290%] | 4368h | 532,544 | 532,544 | 876 | 52 | ܁= | ܁" |
| 344 | 1.05.02.02.05.01.02 | CC Assembly Area Preparation (FNAL - M&S) |  | 100d | 2013-10-01 | 2014-02-26 | 343SS | 2013-10-01 | 2014-02-26 | 100d | 1d | 0d | FN_M&S_STND_FY12 |  | 104,200 | 104,200 | 877 | 52 | ܁= | ܁" |
| 345 | 1.05.02.02.05.01.03 | L4 - CC Assembly Area Operational | milestone | 0d | 2014-02-26 | 2014-02-26 | 344, 343 | 2014-02-26 | 2014-02-26 | 0d | 1d |  |  |  |  |  | 881 | 52 | ܁= |  |

| ID | WBS | Task | Type | Duration | Start | Finish | Predecessors | Baseline start | Baseline finish | Baseline duration | Total slack | Free slack | Resources | Work | Cost | Baseline cost | CobraUID | WBS-L3 Text18 | Resp Instit Name/Code | Funding Type | Milestone Levels | Risk ID |
| --- | --- | --- | --- | --- | --- | --- | --- | --- | --- | --- | --- | --- | --- | --- | --- | --- | --- | --- | --- | --- | --- | --- |
| 346 | 1.05.02.02.05.02 | **CCM Prototype Assembly at FNAL** |  | 251d | 2014-02-28 | 2015-02-27 |  | 2014-02-28 | 2015-02-27 | 251d | 0d |  |  | 3416h | 391,690 | 391,690 | 868 | 52 |  |  |  |  |
| 347 | 1.05.02.02.05.02.01 | CCM Prototype Assembly at FNAL (FNAL - Labor) |  | 251d | 2014-02-28 | 2015-02-27 | 22, 316, 223, 224, 345 | 2014-02-28 | 2015-02-27 | 251d | 0d |  | FNAP_MECH_DESIGN_EN [54%]; FNAD_MECH_DRAFTER [3%]; FNAD_MECH_SYSTM_TECH [166%] | 3416h | 342,720 | 342,720 | 869 | 52 | ܁= | ܁" |  |  |
| 348 | 1.05.02.02.05.02.02 | CCM Prototype Assembly at FNAL (FNAL - M&S) |  | 251d | 2014-02-28 | 2015-02-27 | 347SS | 2014-02-28 | 2015-02-27 | 251d | 0d |  | FN_M&S_STND_FY12 |  | 48,970 | 48,970 | 870 | 52 | ܁= | ܁" |  |  |
| 349 | 1.05.02.02.05.02.03 | L4 - CCM Prototype Assembly at FNAL - Complete - Operational | milestone | 0d | 2015-02-27 | 2015-02-27 | 348 | 2015-02-27 | 2015-02-27 | 0d | 0d |  |  |  |  |  | 871 | 52 | ܁= |  |  |  |
| 350 | 1.05.02.02.05.03 | **CCM Prototype Test at FNAL** |  | 35d | 2015-03-02 | 2015-04-17 |  | 2015-03-02 | 2015-04-17 | 35d | 0d |  |  | 1168h | 131,805 | 131,805 | 872 | 52 |  |  |  |  |
| 351 | 1.05.02.02.05.03.01 | Labor for CCM Prototype Test at FNAL (FNAL - Labor) |  | 35d | 2015-03-02 | 2015-04-17 | 349 | 2015-03-02 | 2015-04-17 | 35d | 0d |  | FNAP_MECH_DESIGN_EN [140%]; FNAD_MECH_SYSTM_TECH [280%] | 1168h | 124,976 | 124,976 | 873 | 52 | ܁= | ܁" |  |  |
| 352 | 1.05.02.02.05.03.02 | M&S for CCM Prototype Test at FNAL (FNAL - M&S) |  | 35d | 2015-03-02 | 2015-04-17 | 351SS | 2015-03-02 | 2015-04-17 | 35d | 0d |  | FN_M&S_STND_FY12 [682900%] |  | 6,829 | 6,829 | 874 | 52 | ܁= | ܁" |  |  |
| 353 | 1.05.02.02.05.03.03 | L4 - CCM Prototype Testing Complete - Ready to be moved to MTA | milestone | 0d | 2015-04-17 | 2015-04-17 | 352, 351 | 2015-04-17 | 2015-04-17 | 0d | 0d |  |  |  |  |  | 875 | 52 | ܁= |  |  |  |
| 354 | 1.05.02.02.05.03.04 | (RISK)-(R4) - CCM Prototype Testing | milestone | 0d | 2015-04-17 | 2015-04-17 | 352, 351 | 2015-04-17 | 2015-04-17 | 0d | 0d |  |  |  |  |  | 878 | 52 | ܁= |  | R4 |  |
| 355 | 1.05.02.02.05.04 | **CCM Prototype Moved to MTA** |  | 64d | 2015-04-20 | 2015-07-20 |  | 2015-04-20 | 2015-07-20 | 64d | 0d |  |  |  | 244,000 | 244,000 | 880 | 52 |  |  |  |  |
| 356 | 1.05.02.02.05.04.01 | CCM Prototype Moved to MTA (FNAL - Labor) |  | 64d | 2015-04-20 | 2015-07-20 | 353, 354 | 2015-04-20 | 2015-07-20 | 64d | 0d |  |  |  |  |  | 882 | 52 | ܁= | ܁" |  |  |
| 357 | 1.05.02.02.05.04.02 | CCM Prototype Moved to MTA (FNAL - M&S) |  | 64d | 2015-04-20 | 2015-07-20 | 356SS | 2015-04-20 | 2015-07-20 | 64d | 0d |  | FN_M&S_STND_FY12 |  | 244,000 | 244,000 | 883 | 52 | ܁= | ܁" |  |  |
| 358 | 1.05.02.02.05.05 | **RFCC Prototype Test (RFCC_Lite - Single Cavity)(Tasks Charged to MuCool Test Area Budget)** |  | 100d | 2015-07-21 | 2015-12-10 |  | 2015-07-21 | 2015-12-10 | 100d | 0d |  |  |  |  |  | 884 | 52 |  |  |  |  |
| 359 | 1.05.02.02.05.05.01 | RFCC Prototype Test (RFCC_Lite - Single Cavity) (FNAL - Labor)(Task Charged to MuCool Test Area Budget) |  | 100d | 2015-07-21 | 2015-12-10 | 357 | 2015-07-21 | 2015-12-10 | 100d | 0d |  |  |  |  |  | 885 | 52 | ܁= | ܁" |  |  |
| 360 | 1.05.02.02.05.05.02 | RFCC Prototype Test (RFCC_Lite - Single Cavity) (FNAL - M&S)(Task Charged to MuCool Test Area Budget) |  | 100d | 2015-07-21 | 2015-12-10 | 359SS | 2015-07-21 | 2015-12-10 | 100d | 0d |  |  |  |  |  | 886 | 52 | ܁= | ܁" |  |  |
| 361 | 1.05.02.02.05.05.03 | (RISK)-(R2) - RFCC Prototype Test (RFCC_Lite - Single Cavity)(Task Charged to MuCool Test Area Budget) | milestone | 0d | 2015-12-10 | 2015-12-10 | 359, 360 | 2015-12-10 | 2015-12-10 | 0d | 0d |  |  |  |  |  | 901 | 52 | ܁= |  | R2 | 5, 11 |
| 362 | 1.05.02.02.05.05.04 | RFCC Prototype Test (RFCC_Lite - Single Cavity) - Possible Costs for this R2 Risk (UID-901)(Task Charged to MuCool Test Area Budget) |  | 1d | 2015-12-10 | 2015-12-10 | 361FS-1d | 2015-12-10 | 2015-12-10 | 1d | 738d |  |  |  |  |  | 1124 | 52 | ܁= |  |  | 5, 11 |
| 363 | 1.05.02.02.05.06 | **Optional: RFCC Prototype Integration** |  | 196d | 2017-02-28 | 2017-12-05 |  | 2017-02-28 | 2017-12-05 | 196d | 240d |  |  |  |  |  | 983 | 52 |  |  |  |  |
| 364 | 1.05.02.02.05.06.01 | Optional: RFCC Prototype RF to CC Fit-up |  | 30d | 2017-02-28 | 2017-04-10 | 403, 349 | 2017-02-28 | 2017-04-10 | 30d | 240d | 0d |  |  |  |  | 984 | 52 | ܁= | ܁" |  |  |
| 365 | 1.05.02.02.05.06.02 | L4 - Optional: RFCC Prototype Ready to Ship to RAL | milestone | 0d | 2017-04-10 | 2017-04-10 | 364 | 2017-04-10 | 2017-04-10 | 0d | 240d | 0d |  |  |  |  | 985 | 52 | ܁= |  |  |  |
| 366 | 1.05.02.02.05.06.03 | Optional: RFCC Prototype Shipment to RAL |  | 46d | 2017-04-11 | 2017-06-14 | 365 | 2017-04-11 | 2017-06-14 | 46d | 240d | 0d |  |  |  |  | 986 | 52 | ܁= | ܁" |  |  |
| 367 | 1.05.02.02.05.06.04 | L4 - Optional: MICE RFCC Prototype Arrives at RAL | milestone | 0d | 2017-06-14 | 2017-06-14 | 366 | 2017-06-14 | 2017-06-14 | 0d | 240d | 0d |  |  |  |  | 987 | 52 | ܁= |  |  |  |
| 368 | 1.05.02.02.05.06.05 | Optional: MICE RFCC Prototype Integration at RAL (No Successor) |  | 120d | 2017-06-15 | 2017-12-05 | 367 | 2017-06-15 | 2017-12-05 | 120d | 240d |  |  |  |  |  | 988 | 52 | ܁= | ܁" |  |  |
| 369 | 1.05.02.02.05.07 | **CCM#1 Assembly at FNAL** |  | 188d | 2015-04-20 | 2016-01-20 |  | 2015-04-20 | 2016-01-20 | 188d | 20d |  |  | 3416h | 391,690 | 391,690 | 887 | 52 |  |  |  |  |
| 370 | 1.05.02.02.05.07.01 | CCM#1 Assembly at FNAL (FNAL - Labor) |  | 188d | 2015-04-20 | 2016-01-20 | 352, 351 | 2015-04-20 | 2016-01-20 | 188d | 20d | 0d | FNAP_MECH_DESIGN_EN [54%]; FNAD_MECH_DRAFTER [3%]; FNAD_MECH_SYSTM_TECH [166%] | 3416h | 342,720 | 342,720 | 888 | 52 | ܁= | ܁" |  |  |
| 371 | 1.05.02.02.05.07.02 | CCM#1 Assembly at FNAL (FNAL - M&S) |  | 188d | 2015-04-20 | 2016-01-20 | 370SS, 329 | 2015-04-20 | 2016-01-20 | 188d | 20d | 0d | FN_M&S_STND_FY12 |  | 48,970 | 48,970 | 889 | 52 | ܁= | ܁" |  |  |
| 372 | 1.05.02.02.05.07.03 | L4 - CCM#1 Assembly at FNAL - Complete | milestone | 0d | 2016-01-20 | 2016-01-20 | 371 | 2016-01-20 | 2016-01-20 | 0d | 20d | 0d |  |  |  |  | 1133 | 52 | ܁= |  |  |  |

Notes:
- 346: Predecessor Before Merge 22,153,181
- 353: Predecessor was 843 (UID 393) / Successor was 670, 649 (UID 278, 1088)
- 354: IMPACT:() - ACTION:()
- 361: IMPACT:(Delay in RFCC#1 delivery to RAL along with delays in MICE Step V/VI operation. Likely delays of > 1 year in experimental program) - ACTION:(Evaluation of design limitations and development of mitigation plan)
- 370: Predecessor Before Merge 24,153,185,197

| ID | WBS | Task | Type | Duration | Start | Finish | Predecessors | Baseline start | Baseline finish | Baseline duration | Total slack | Free slack | Resources | Work | Cost | Baseline cost | CobraUID | WBS-L3 Text18 | Resp Instit Name/Code | Funding Type |
| --- | --- | --- | --- | --- | --- | --- | --- | --- | --- | --- | --- | --- | --- | --- | --- | --- | --- | --- | --- | --- |
| 373 | 1.05.02.02.05.08 | **CCM#1 Testing at FNAL** |  | 64d | 2016-01-21 | 2016-04-19 |  | 2016-01-21 | 2016-04-19 | 64d | 20d |  |  | 1016h | 119,277 | 119,277 | 890 | 52 |  |  |
| 374 | 1.05.02.02.05.08.01 | CCM#1 Testing at FNAL (FNAL - Labor) |  | 64d | 2016-01-21 | 2016-04-19 | 370, 371, 372 | 2016-01-21 | 2016-04-19 | 64d | 20d | 0d | FNAD_MECH_SYSTM_TECH [140%]; FNAD_MAGNT_DESIGN_EN [57%] | 1016h | 112,448 | 112,448 | 891 | 52 | ܁= | ܁" |
| 375 | 1.05.02.02.05.08.02 | CCM#1 Testing at FNAL (FNAL - M&S) |  | 64d | 2016-01-21 | 2016-04-19 | 374SS | 2016-01-21 | 2016-04-19 | 64d | 20d | 0d | FN_M&S_STND_FY12 [682900%] |  | 6,829 | 6,829 | 892 | 52 | ܁= | ܁" |
| 376 | 1.05.02.02.05.08.03 | L4 - CCM#1 Testing at FNAL - Complete | milestone | 0d | 2016-04-19 | 2016-04-19 | 375 | 2016-04-19 | 2016-04-19 | 0d | 20d |  |  |  |  |  | 1134 | 52 | ܁= |  |
| 377 | 1.05.02.02.05.09 | **RFCC#1 Integration** |  | 168d | 2015-12-11 | 2016-08-11 |  | 2015-12-11 | 2016-08-11 | 168d | 0d |  |  | 3181h | 596,430 | 596,430 | 893 | 52 |  |  |
| 378 | 1.05.02.02.05.09.01 | RFCC#1 - Purchase & Assemble Components (LBNL - Resources) |  | 17.62d | 2015-12-11 | 2016-05-17 | 103, 361 | 2015-12-11 | 2016-05-17 | 17.62d | 0d |  | LBNL_MECH_TECH; LBNL_MECH_ENG; LBNL_SCIENTIST; LBNL_POSTDOC; LBNL_LABOR | 317h | 46,059 | 46,059 | 894 | 52 | ܁A | ܁` |
| 379 | 1.05.02.02.05.09.02 | RFCC#1 - Purchase & Assemble Components (LBNL - M&S) |  | 108d | 2015-12-11 | 2016-05-17 | 378SS | 2015-12-11 | 2016-05-17 | 108d | 0d |  | LBNL_M&S |  | 80,585 | 80,585 | 902 | 52 | ܁A | ܁` |
| 380 | 1.05.02.02.05.09.03 | RFCC#1 RF to CCM#1 Fit-up (LBNL - Labor) (May become FNAL Task) |  | 60d | 2016-05-18 | 2016-08-11 | 378, 137, 379, 375, 376 | 2016-05-18 | 2016-08-11 | 60d | 0d |  | LBNL_LABOR; LBNL_MECH_TECH; LBNL_MECH_ENG; LBNL_SCIENTIST; LBNL_POSTDOC | 2864h | 414,527 | 414,527 | 895 | 52 | ܁A | ܁` |
| 381 | 1.05.02.02.05.09.04 | RFCC#1 RF to CCM#1 Fit-up (LBNL - M&S) (May become FNAL Task) |  | 60d | 2016-05-18 | 2016-08-11 | 380SS | 2016-05-18 | 2016-08-11 | 60d | 0d |  | LBNL_M&S |  | 55,259 | 55,259 | 903 | 52 | ܁A | ܁` |
| 382 | 1.05.02.02.05.09.05 | L4 - RFCC#1 Ready to Ship to RAL | milestone | 0d | 2016-08-11 | 2016-08-11 | 380, 378, 379, 381 | 2016-08-11 | 2016-08-11 | 0d | 0d |  |  |  |  |  | 896 | 52 | ܁A |  |
| 383 | 1.05.02.02.05.10 | **RFCC#1 Preparation for Shipment to RAL** |  | 30d | 2016-08-12 | 2016-09-23 |  | 2016-08-12 | 2016-09-23 | 30d | 0d |  |  | 976h | 130,236 | 130,236 | 897 | 52 |  |  |
| 384 | 1.05.02.02.05.10.01 | RFCC#1 Preparation for Shipment to RAL (FNAL - Labor) |  | 30d | 2016-08-12 | 2016-09-23 | 382 | 2016-08-12 | 2016-09-23 | 30d | 0d |  | FNAP_MECH_DESIGN_EN [75%]; FNAD_MECH_DRAFTER [75%]; FNAD_MECH_SYSTM_TECH [260%] | 976h | 91,216 | 91,216 | 898 | 52 | ܁= | ܁" |
| 385 | 1.05.02.02.05.10.02 | RFCC#1 Preparation for Shipment to RAL (FNAL - M&S) |  | 30d | 2016-08-12 | 2016-09-23 | 384SS | 2016-08-12 | 2016-09-23 | 30d | 0d |  | FN_M&S_STND_FY12 |  | 39,020 | 39,020 | 899 | 52 | ܁= | ܁" |
| 386 | 1.05.02.02.05.11 | **RFCC#1 Shipping to RAL** |  | 60d | 2016-09-26 | 2016-12-20 |  | 2016-09-26 | 2016-12-20 | 60d | 180d |  |  |  | 29,270 | 29,270 | 931 | 52 |  |  |
| 387 | 1.05.02.02.05.11.01 | RFCC#1 Shipment to RAL - Labor |  | 60d | 2016-09-26 | 2016-12-20 | 384, 385 | 2016-09-26 | 2016-12-20 | 60d | 180d | 0d |  |  |  |  | 933 | 52 | ܁= | ܁" |
| 388 | 1.05.02.02.05.11.02 | RFCC#1 Shipment to RAL (FNAL - M&S) |  | 60d | 2016-09-26 | 2016-12-20 | 387SS | 2016-09-26 | 2016-12-20 | 60d | 180d | 0d | FN_M&S_STND_FY12 |  | 29,270 | 29,270 | 934 | 52 | ܁= | ܁" |
| 389 | 1.05.02.02.05.11.03 | L4 - MICE RFCC#1 Arrives at RAL (UK Desired by 01/03/17) | milestone | 0d | 2016-12-20 | 2016-12-20 | 387, 388 | 2016-12-20 | 2016-12-20 | 0d | 180d | 0d |  |  |  |  | 932 | 52 | ܁= |  |
| 390 | 1.05.02.02.05.12 | **RFCC#1 Installation & Commissioning at RAL** |  | 60d | 2016-12-21 | 2017-03-21 |  | 2016-12-21 | 2017-03-21 | 60d | 420d |  |  | 588h | 97,881 | 97,881 | 904 | 52 |  |  |
| 391 | 1.05.02.02.05.12.01 | RFCC#1 Installation & Commissioning at RAL (FNAL - Labor) |  | 60d | 2016-12-21 | 2017-03-21 | 389 | 2016-12-21 | 2017-03-21 | 60d | 420d | 0d | FNAD_MECH_SYSTM_TECH [30%]; FNAD_MAGNT_DESIGN_EN [30%]; FNAD_AC_EXP_PHYST [30%]; FNUN_P_POSTDOC [30%] | 588h | 76,881 | 76,881 | 905 | 52 | ܁= | ܁" |
| 392 | 1.05.02.02.05.12.02 | RFCC#1 Installation & Commissioning at RAL (FNAL - M&S) |  | 60d | 2016-12-21 | 2017-03-21 | 391SS | 2016-12-21 | 2017-03-21 | 60d | 420d | 0d | FN_M&S_STND_FY12 |  | 21,000 | 21,000 | 906 | 52 | ܁= | ܁" |
| 393 | 1.05.02.02.05.12.03 | L4 - RFCC#1 Installation & Commissioning at RAL - Complete | milestone | 0d | 2017-03-21 | 2017-03-21 | 392, 391 | 2017-03-21 | 2017-03-21 | 0d | 420d |  |  |  |  |  | 907 | 52 | ܁= |  |
| 394 | 1.05.02.02.05.13 | **CCM#2 Assembly at FNAL** |  | 190d | 2016-09-26 | 2017-06-28 |  | 2016-09-26 | 2017-06-28 | 190d | 0d |  |  | 3416h | 391,690 | 391,690 | 908 | 52 |  |  |
| 395 | 1.05.02.02.05.13.01 | CCM#2 Assembly at FNAL (FNAL - Labor) |  | 190d | 2016-09-26 | 2017-06-28 | 385 | 2016-09-26 | 2017-06-28 | 190d | 0d |  | FNAD_MECH_SYSTM_TECH [166%]; FNAP_MECH_DESIGN_EN [54%]; FNAD_MECH_DRAFTER [3%] | 3416h | 342,720 | 342,720 | 909 | 52 | ܁= | ܁" |
| 396 | 1.05.02.02.05.13.02 | CCM#2 Assembly at FNAL (FNAL - M&S) |  | 190d | 2016-09-26 | 2017-06-28 | 395SS | 2016-09-26 | 2017-06-28 | 190d | 0d |  | FN_M&S_STND_FY12 |  | 48,970 | 48,970 | 910 | 52 | ܁= | ܁" |
| 397 | 1.05.02.02.05.13.03 | L4 - CCM#2 Assembly at FNAL - Complete | milestone | 0d | 2017-06-28 | 2017-06-28 | 396 | 2017-06-28 | 2017-06-28 | 0d | 0d |  |  |  |  |  | 1135 | 52 | ܁= |  |

Notes:
- 374: Predecessor Before Merge 24,153,185,197
- 378: Predecessor was 806FF, 708, 673 (UID 381, 373, 527)
- 389: Predecessor was 865 (UID 258) / Predecessor was 867, 685 (UID 313, 582)
- 393: Predecessor was 865 (UID 258) / Predecessor was 867, 685 (UID 313, 582)
- 395: Predecessor Before Merge 24,153,185,197

| ID | WBS | Task | Type | Duration | Start | Finish | Predecessors | Baseline start | Baseline finish | Baseline duration | Total slack | Free slack | Resources | Work | Cost | Baseline cost | CobraUID | WBS-L3 Text18 | Resp Instit Name/Code | Funding Type |
| --- | --- | --- | --- | --- | --- | --- | --- | --- | --- | --- | --- | --- | --- | --- | --- | --- | --- | --- | --- | --- |
| 398 | 1.05.02.02.05.14 | **CCM#2 Testing at FNAL** |  | 60d | 2017-06-29 | 2017-09-22 |  | 2017-06-29 | 2017-09-22 | 60d | 0d |  |  | 1016h | 119,277 | 119,277 | 911 | 52 |  |  |
| 399 | 1.05.02.02.05.14.01 | CCM#2 Testing at FNAL (FNAL - Labor) |  | 60d | 2017-06-29 | 2017-09-22 | 395, 396, 397 | 2017-06-29 | 2017-09-22 | 60d | 0d |  | FNAD_MECH_SYSTM_TECH [150%]; FNAD_MAGNT_DESIGN_EN [62%] | 1016h | 112,448 | 112,448 | 912 | 52 | ܁= | ܁" |
| 400 | 1.05.02.02.05.14.02 | CCM#2 Testing at FNAL (FNAL - M&S) |  | 60d | 2017-06-29 | 2017-09-22 | 399SS | 2017-06-29 | 2017-09-22 | 60d | 0d |  | FN_M&S_STND_FY12 [682900%] |  | 6,829 | 6,829 | 913 | 52 | ܁= | ܁" |
| 401 | 1.05.02.02.05.14.03 | L4 - CCM#2 Testing at FNAL - Complete | milestone | 0d | 2017-09-22 | 2017-09-22 | 400 | 2017-09-22 | 2017-09-22 | 0d | 0d |  |  |  |  |  | 1136 | 52 | ܁= |  |
| 402 | 1.05.02.02.05.15 | **RFCC#2 Integration** |  | 286d | 2016-09-30 | 2017-11-17 |  | 2016-09-30 | 2017-11-17 | 286d | 0d |  |  | 1945h | 376,341 | 376,341 | 914 | 52 |  |  |
| 403 | 1.05.02.02.05.15.01 | RFCC#2 - Purchase & Assemble Components (LBNL - Resources) |  | 17.62d | 2016-09-30 | 2017-02-27 | 148, 124, 125, 361, 25FS-15d | 2016-09-30 | 2017-02-27 | 17.62d | 146d | 0d | LBNL_MECH_TECH; LBNL_MECH_ENG; LBNL_SCIENTIST; LBNL_POSTDOC; LBNL_LABOR | 195h | 25,546 | 25,546 | 915 | 52 | ܁A | ܁` |
| 404 | 1.05.02.02.05.15.02 | RFCC#2 - Purchase & Assemble Components (LBNL - M&S) |  | 100d | 2016-09-30 | 2017-02-27 | 403SS | 2016-09-30 | 2017-02-27 | 100d | 186d |  | LBNL_M&S |  | 80,585 | 80,585 | 916 | 52 | ܁A | ܁` |
| 405 | 1.05.02.02.05.15.03 | RFCC#2 - RF to CCM#2 Fit-up (LBNL - Labor) (May become FNAL Task) |  | 40d | 2017-09-25 | 2017-11-17 | 403, 399, 400, 401 | 2017-09-25 | 2017-11-17 | 40d | 0d |  | LBNL_ELEC_TECH; LBNL_MECH_ENG; LBNL_SCIENTIST; LBNL_POSTDOC; MUON_LABOR | 1750h | 229,917 | 229,917 | 917 | 52 | ܁A | ܁` |
| 406 | 1.05.02.02.05.15.04 | RFCC#2 - RF to CCM#2 Fit-up (LBNL - M&S) (May become FNAL Task) |  | 40d | 2017-09-25 | 2017-11-17 | 405SS | 2017-09-25 | 2017-11-17 | 40d | 0d |  | LBNL_M&S |  | 40,293 | 40,293 | 918 | 52 | ܁A | ܁` |
| 407 | 1.05.02.02.05.15.05 | L4 - RFCC#2 Ready to Ship to RAL | milestone | 0d | 2017-11-17 | 2017-11-17 | 403, 404, 405, 406 | 2017-11-17 | 2017-11-17 | 0d | 0d |  |  |  |  |  | 919 | 52 | ܁A |  |
| 408 | 1.05.02.02.05.16 | **RFCC#2 Preparation for Shipment to RAL** |  | 30d | 2017-11-20 | 2018-01-08 |  | 2017-11-20 | 2018-01-08 | 30d | 0d |  |  | 880h | 118,780 | 118,780 | 920 | 52 |  |  |
| 409 | 1.05.02.02.05.16.01 | RFCC#2 Preparation for Shipment to RAL (FNAL - Labor) |  | 30d | 2017-11-20 | 2018-01-08 | 407 | 2017-11-20 | 2018-01-08 | 30d | 0d |  | FNAD_MECH_SYSTM_TECH [260%]; FNAD_MAGNT_DESIGN_EN [40%]; FNAD_MECH_DRAFTER [67%] | 880h | 79,760 | 79,760 | 921 | 52 | ܁= | ܁" |
| 410 | 1.05.02.02.05.16.02 | RFCC#2 Preparation for Shipment to RAL (FNAL - M&S) |  | 30d | 2017-11-20 | 2018-01-08 | 409SS | 2017-11-20 | 2018-01-08 | 30d | 0d |  | FN_M&S_STND_FY12 |  | 39,020 | 39,020 | 922 | 52 | ܁= | ܁" |
| 411 | 1.05.02.02.05.17 | **RFCC#2 Shipping to RAL** |  | 60d | 2018-01-09 | 2018-04-03 |  | 2018-01-09 | 2018-04-03 | 60d | 0d |  |  |  | 29,270 | 29,270 | 935 | 52 |  |  |
| 412 | 1.05.02.02.05.17.01 | RFCC#2 Shipment to RAL - (FNAL - Labor) |  | 60d | 2018-01-09 | 2018-04-03 | 410 | 2018-01-09 | 2018-04-03 | 60d | 0d |  |  |  |  |  | 936 | 52 | ܁= | ܁" |
| 413 | 1.05.02.02.05.17.02 | RFCC#2 Shipment to RAL (FNAL - M&S) |  | 60d | 2018-01-09 | 2018-04-03 | 412SS | 2018-01-09 | 2018-04-03 | 60d | 0d |  | FN_M&S_STND_FY12 |  | 29,270 | 29,270 | 937 | 52 | ܁= | ܁" |
| 414 | 1.05.02.02.05.17.03 | L4 - MICE RFCC#2 Arrives at RAL (UK Desired by 04/01/18) | milestone | 0d | 2018-04-03 | 2018-04-03 | 412, 413 | 2018-04-03 | 2018-04-03 | 0d | 0d |  |  |  |  |  | 938 | 52 | ܁= |  |
| 415 | 1.05.02.02.05.18 | **RFCC#2 Installation & Commissioning at RAL** |  | 124d | 2018-04-04 | 2018-09-27 |  | 2018-04-04 | 2018-09-27 | 124d | 36d |  |  | 588h | 97,881 | 97,881 | 924 | 52 |  |  |
| 416 | 1.05.02.02.05.18.01 | RFCC#2 Installation & Commissioning at RAL (FNAL - Labor) |  | 124d | 2018-04-04 | 2018-09-27 | 414 | 2018-04-04 | 2018-09-27 | 124d | 36d | 0d | FNAD_MECH_SYSTM_TECH [30%]; FNAD_MAGNT_DESIGN_EN [30%]; FNAD_AC_EXP_PHYST [30%]; FNUN_P_POSTDOC [30%] | 588h | 76,881 | 76,881 | 925 | 52 | ܁= | ܁" |
| 417 | 1.05.02.02.05.18.02 | RFCC#2 Installation & Commissioning at RAL (FNAL - M&S) |  | 124d | 2018-04-04 | 2018-09-27 | 416SS | 2018-04-04 | 2018-09-27 | 124d | 36d | 0d | FN_M&S_STND_FY12 |  | 21,000 | 21,000 | 926 | 52 | ܁= | ܁" |
| 418 | 1.05.02.02.05.18.03 | L4 - RFCC#2 Installation & Commissioning at RAL - Complete | milestone | 0d | 2018-09-27 | 2018-09-27 | 416, 417 | 2018-09-27 | 2018-09-27 | 0d | 36d |  |  |  |  |  | 927 | 52 | ܁= |  |
| 419 | 1.05.02.02.05.19 | **Assembly Area Decommissioning** |  | 64d | 2018-01-09 | 2018-04-09 |  | 2018-01-09 | 2018-04-09 | 64d | 156d |  |  |  |  |  | 939 | 52 |  |  |
| 420 | 1.05.02.02.05.19.01 | Assembly Area Decommissioning (FNAL - Labor) |  | 64d | 2018-01-09 | 2018-04-09 | 412SS, 413SS | 2018-01-09 | 2018-04-09 | 64d | 156d | 0d |  |  |  |  | 940 | 52 | ܁= | ܁" |
| 421 | 1.05.02.02.05.19.02 | Assembly Area Decommissioning (FNAL - M&S) (Completion of Project for Successor) |  | 64d | 2018-01-09 | 2018-04-09 | 420SS | 2018-01-09 | 2018-04-09 | 64d | 156d | 0d |  |  |  |  | 941 | 52 | ܁= | ܁" |
| 422 | 1.05.02.02.05.19.03 | L4 - Assembly Area Decommissioning - Completed | milestone | 0d | 2018-04-09 | 2018-04-09 | 421 | 2018-04-09 | 2018-04-09 | 0d | 156d |  |  |  |  |  | 1137 | 52 | ܁= |  |

Notes:
- 399: Predecessor Before Merge 24,153,185,197
- 403: Predecessor was 806FF, 708, 673 (UID 381, 373, 527)
- 414: Predecessor was 865 (UID 258) / Predecessor was 867, 685 (UID 313, 582)
- 418: Predecessor was 865 (UID 258) / Predecessor was 867, 685 (UID 313, 582)
- 420: Predecessor Before Merge 24,153,185,197

| ID | WBS | Task | Type | Duration | Start | Finish | Predecessors | Complete | Remaining | Actual finish | Baseline start | Baseline finish | Baseline duration | Total slack | Free slack | Resources | Work | Actual work | Cost | Baseline cost | Actual cost | BOE Number | MAP WBS | CobraUID | WBS-L3 Text18 | Resp Instit Name/Code | Funding Type | Milestone Levels | Risk ID |
| --- | --- | --- | --- | --- | --- | --- | --- | --- | --- | --- | --- | --- | --- | --- | --- | --- | --- | --- | --- | --- | --- | --- | --- | --- | --- | --- | --- | --- | --- |
| 423 | 1.05.03 | **MICE Magnetic Shielding** |  | 1378d | 2012-10-01 A | 2018-03-30 |  | 12% | 1215.98d |  | 2012-10-01 | 2018-03-30 | 1378d | 162d |  |  | 3492h | 1193.5h | 1,071,150 | 1,071,150 | 170,540 | BOE-1.05.03 | 29M.05.03 | 529 | 53 |  |  |  |  |
| 424 | 1.05.03.01 | **MICE Step IV Shielding** |  | 502d | 2012-10-01 A | 2014-09-30 |  | 38% | 310.19d |  | 2012-10-01 | 2014-09-30 | 502d | 1038d |  |  | 1503h | 1193.5h | 356,380 | 356,380 | 170,540 |  |  | 568 | 53 |  |  |  |  |
| 425 | 1.05.03.01.01 | **MICE Step IV Magnetic Shielding Conceptual Design Studies** |  | 123d | 2012-10-01 A | 2013-03-29 A |  | 100% |  |  | 2012-10-01 | 2013-03-29 | 123d |  |  |  | 884h | 884h | 131,000 | 131,000 | 131,000 |  |  | 530 | 53 |  |  |  |  |
| 426 | 1.05.03.01.01.01 | MICE Step IV Magnetic Shielding Conceptual Design Studies (BNL - Resources) |  | 123d | 2012-10-01 A | 2013-03-29 A | 21FS-15d | 100% |  |  | 2012-10-01 | 2013-03-29 | 123d |  |  | BNL_PHYSICIST; BNL_LABOR | 884h | 884h | 131,000 | 131,000 | 131,000 |  |  | 696 | 53 | ܁? | ܁` |  |  |
| 427 | 1.05.03.01.01.02 | MICE Step IV Magnetic Shielding Conceptual Design Studies (BNL - M&S) |  | 123d | 2012-10-01 A | 2013-03-29 A | 426SS | 100% |  |  | 2012-10-01 | 2013-03-29 | 123d |  |  |  |  |  |  |  |  |  |  | 790 | 53 | ܁? | ܁` |  |  |
| 428 | 1.05.03.01.02 | **MICE Step IV Magnetic Shielding 2 Week Review Window** |  | 128d | 2013-04-01 A | 2013-09-30 |  | 100% |  | 2013-04-12 | 2013-04-01 | 2013-04-12 | 128d |  |  |  |  |  |  |  |  |  |  | 531 | 53 |  |  |  |  |
| 429 | 1.05.03.01.02.01 | MICE Step IV Magnetic Shielding 2 Week Review Window (BNL - Resources) |  | 10d | 2013-04-01 A | 2013-04-12 A | 426, 427 | 100% |  |  | 2013-04-01 | 2013-04-12 | 10d |  |  |  |  |  |  |  |  |  |  | 697 | 53 | ܁? | ܁` |  |  |
| 430 | 1.05.03.01.02.02 | MICE Step IV Magnetic Shielding 2 Week Review Window (BNL - M&S) |  | 10d | 2013-04-01 A | 2013-04-12 A | 429SS | 100% |  |  | 2013-04-01 | 2013-04-12 | 10d |  |  |  |  |  |  |  |  |  |  | 791 | 53 | ܁? | ܁` |  |  |
| 431 | 1.05.03.01.03 | **MICE Step IV Magnetic Shielding Detailed Engineering** |  | 118d | 2013-04-15 A | 2013-09-30 |  | 50% | 59.25d |  | 2013-04-15 | 2013-09-30 | 118d | 1289d |  |  | 619h | 309.5h | 79,080 | 79,080 | 39,540 |  |  | 532 | 53 |  |  |  |  |
| 432 | 1.05.03.01.03.01 | MICE Step IV Magnetic Shielding Detailed Engineering (BNL - Resources) |  | 118d | 2013-04-15 A | 2013-09-30 | 429, 430 | 50% | 59d |  | 2013-04-15 | 2013-09-30 | 118d | 516d | 0d | BNL_ADMIN; BNL_MECH_TECH; BNL_MECH_ENG; BNL_LABOR | 619h | 309.5h | 67,110 | 67,110 | 33,555 |  |  | 698 | 53 | ܁? | ܁` |  |  |
| 433 | 1.05.03.01.03.02 | MICE Step IV Magnetic Shielding Detailed Engineering (BNL - M&S) |  | 118d | 2013-04-15 A | 2013-09-30 | 432SS | 50% | 59d |  | 2013-04-15 | 2013-09-30 | 118d | 516d | 0d | BNL_M&S |  |  | 11,970 | 11,970 | 5,985 |  |  | 792 | 53 | ܁? | ܁` |  |  |
| 434 | 1.05.03.01.03.03 | L4 - MICE Step IV Magnetic Shield Fabrication Decision | milestone | 0d | 2013-09-30 | 2013-09-30 | 432, 433 |  |  |  | 2013-09-30 | 2013-09-30 | 0d | 516d | 0d |  |  |  |  |  |  |  |  | 533 | 53 | ܁? |  |  |  |
| 435 | 1.05.03.01.03.04 | (RISK)-(R3) - MICE Step IV Magnetic Shield Fabrication Decision | milestone | 0d | 2013-09-30 | 2013-09-30 | 434 |  |  |  | 2013-09-30 | 2013-09-30 | 0d | 516d | 0d |  |  |  |  |  |  |  |  | 1010 | 53 | ܁? |  | R3 | 12 |
| 436 | 1.05.03.01.03.05 | MICE Step IV Magnetic Shield Fabrication Decision - Possible Costs for this R3 Risk (UID-1010) |  | 1d | 2013-09-30 | 2013-09-30 | 435FS-1d |  |  |  | 2013-09-30 | 2013-09-30 | 1d | 1289d |  |  |  |  |  |  |  |  |  | 1125 | 53 | ܁= |  |  | 12 |
| 437 | 1.05.03.01.04 | **MICE Step IV Magnetic Shielding Fabricate Parts** |  | 61d | 2013-10-01 | 2013-12-30 |  |  |  |  | 2013-10-01 | 2013-12-30 | 61d | 516d |  |  |  |  | 146,300 | 146,300 |  |  |  | 534 | 53 |  |  |  |  |
| 438 | 1.05.03.01.04.01 | MICE Step IV Magnetic Shielding Fabricate Parts (BNL - Resources) |  | 61d | 2013-10-01 | 2013-12-30 | 434, 435 |  |  |  | 2013-10-01 | 2013-12-30 | 61d | 516d | 0d |  |  |  |  |  |  |  |  | 700 | 53 | ܁? | ܁` |  |  |
| 439 | 1.05.03.01.04.02 | MICE Step IV Magnetic Shielding Fabricate Parts (BNL - M&S) |  | 61d | 2013-10-01 | 2013-12-30 | 438SS |  |  |  | 2013-10-01 | 2013-12-30 | 61d | 516d | 0d | BNL_M&S |  |  | 146,300 | 146,300 |  |  |  | 794 | 53 | ܁? | ܁` |  |  |
| 440 | 1.05.03.01.05 | **MICE Step IV Magnetic Shielding Shipped to RAL** |  | 62d | 2014-01-02 | 2014-03-31 |  |  |  |  | 2014-01-02 | 2014-03-31 | 62d | 516d |  |  |  |  |  |  |  |  |  | 993 | 53 |  |  |  |  |
| 441 | 1.05.03.01.05.01 | MICE Step IV Magnetic Shielding Shipped to RAL (BNL - Resources) |  | 62d | 2014-01-02 | 2014-03-31 | 438, 439 |  |  |  | 2014-01-02 | 2014-03-31 | 62d | 516d | 0d |  |  |  |  |  |  |  |  | 994 | 53 | ܁? | ܁` |  |  |
| 442 | 1.05.03.01.05.02 | MICE Step IV Magnetic Shielding Shipped to RAL (BNL - M&S) |  | 62d | 2014-01-02 | 2014-03-31 | 441SS |  |  |  | 2014-01-02 | 2014-03-31 | 62d | 516d | 0d |  |  |  |  |  |  |  |  | 995 | 53 | ܁? | ܁` |  |  |
| 443 | 1.05.03.01.05.03 | L4 - MICE Step IV Magnetic Shielding Received at RAL | milestone | 0d | 2014-03-31 | 2014-03-31 | 441, 442 |  |  |  | 2014-03-31 | 2014-03-31 | 0d | 516d | 0d |  |  |  |  |  |  |  |  | 996 | 53 | ܁? |  |  |  |
| 444 | 1.05.03.01.06 | **MICE Step IV Magnetic Shielding Installation at RAL** |  | 128d | 2014-04-01 | 2014-09-30 |  |  |  |  | 2014-04-01 | 2014-09-30 | 128d | 1038d |  |  |  |  |  |  |  |  |  | 997 | 53 |  |  |  |  |
| 445 | 1.05.03.01.06.01 | MICE Step IV Magnetic Shielding Installation at RAL (BNL - Resources) |  | 128d | 2014-04-01 | 2014-09-30 | 443 |  |  |  | 2014-04-01 | 2014-09-30 | 128d | 1038d | 0d |  |  |  |  |  |  |  |  | 998 | 53 | ܁? | ܁` |  |  |
| 446 | 1.05.03.01.06.02 | MICE Step IV Magnetic Shielding Installation at RAL (BNL - M&S) |  | 128d | 2014-04-01 | 2014-09-30 | 445SS |  |  |  | 2014-04-01 | 2014-09-30 | 128d | 1038d |  |  |  |  |  |  |  |  |  | 999 | 53 | ܁? | ܁` |  |  |
| 447 | 1.05.03.01.07 | L4 - MICE IV Magnetic Shielding - Complete | milestone | 0d | 2014-09-30 | 2014-09-30 | 426, 429, 432, 438, 441, 445 |  |  |  | 2014-09-30 | 2014-09-30 | 0d | 1038d |  |  |  |  |  |  |  |  |  | 991 | 53 | ܁? |  |  |  |

Notes:
- 425: Predecessor Before Merge 21FS+8d
- 435: IMPACT:(Inability to deploy partial yoke shielding for Step IV resulting in increased experimental risk. Step IV baseline assumes no requirement for partial yoke solution, hence minimizing immediate impact) - ACTION:(Discontinue work on Step IV Partial )

| ID | WBS | Task | Type | Duration | Start | Finish | Predecessors | Baseline start | Baseline finish | Baseline duration | Total slack | Free slack | Resources | Work | Cost | Baseline cost | CobraUID | WBS-L3 Text18 | Resp Instit Name/Code | Funding Type | Milestone Levels | Risk ID |
| --- | --- | --- | --- | --- | --- | --- | --- | --- | --- | --- | --- | --- | --- | --- | --- | --- | --- | --- | --- | --- | --- | --- |
| 448 | 1.05.03.02 | **MICE Step V-VI Shielding** |  | 876d | 2014-10-01 | 2018-03-30 |  | 2014-10-01 | 2018-03-30 | 876d | 12d |  |  | 1989h | 714,770 | 714,770 | 570 | 53 |  |  |  |  |
| 449 | 1.05.03.02.01 | **MICE Step V-VI Magnetic Shielding Conceptual Design Studies** |  | 251d | 2014-10-01 | 2015-09-30 |  | 2014-10-01 | 2015-09-30 | 251d | 12d |  |  | 1061h | 157,100 | 157,100 | 571 | 53 |  |  |  |  |
| 450 | 1.05.03.02.01.01 | MICE Step V-VI Magnetic Shielding Conceptual Design Studies (BNL - Resources) |  | 251d | 2014-10-01 | 2015-09-30 | 23FS-15d | 2014-10-01 | 2015-09-30 | 251d | 12d | 0d | BNL_PHYSICIST; BNL_LABOR | 1061h | 157,100 | 157,100 | 702 | 53 | ܁? | ܁` |  |  |
| 451 | 1.05.03.02.01.02 | MICE Step V-VI Magnetic Shielding Conceptual Design Studies (BNL - M&S) |  | 251d | 2014-10-01 | 2015-09-30 | 450SS | 2014-10-01 | 2015-09-30 | 251d | 12d | 0d |  |  |  |  | 795 | 53 | ܁? | ܁` |  |  |
| 452 | 1.05.03.02.02 | **MICE Step V-VI Magnetic Shielding 2 Week Review Window** |  | 10d | 2015-07-01 | 2015-07-15 |  | 2015-07-01 | 2015-07-15 | 10d | 12d |  |  |  |  |  | 572 | 53 |  |  |  |  |
| 453 | 1.05.03.02.02.01 | MICE Step V-VI Magnetic Shielding 2 Week Review Window (BNL - Resources) |  | 10d | 2015-07-01 | 2015-07-15 | 450SS+187d, 451SS+187d | 2015-07-01 | 2015-07-15 | 10d | 12d | 0d |  |  |  |  | 703 | 53 | ܁? | ܁` |  |  |
| 454 | 1.05.03.02.02.02 | MICE Step V-VI Magnetic Shielding 2 Week Review Window (BNL - M&S) |  | 10d | 2015-07-01 | 2015-07-15 | 453SS | 2015-07-01 | 2015-07-15 | 10d | 12d | 0d |  |  |  |  | 796 | 53 | ܁? | ܁` |  |  |
| 455 | 1.05.03.02.03 | **MICE Step V-VI Magnetic Shielding Detailed Engineering** |  | 178d | 2015-07-16 | 2016-03-31 |  | 2015-07-16 | 2016-03-31 | 178d | 12d |  |  | 928h | 118,650 | 118,650 | 573 | 53 |  |  |  |  |
| 456 | 1.05.03.02.03.01 | MICE Step V-VI Magnetic Shielding Detailed Engineering (BNL - Resources) |  | 178d | 2015-07-16 | 2016-03-31 | 453, 454 | 2015-07-16 | 2016-03-31 | 178d | 12d | 0d | BNL_ADMIN; BNL_MECH_TECH; BNL_MECH_ENG; BNL_LABOR | 928h | 100,700 | 100,700 | 704 | 53 | ܁? | ܁` |  |  |
| 457 | 1.05.03.02.03.02 | MICE Step V-VI Magnetic Shielding Detailed Engineering (BNL - M&S) |  | 178d | 2015-07-16 | 2016-03-31 | 456SS | 2015-07-16 | 2016-03-31 | 178d | 12d | 0d | BNL_M&S |  | 17,950 | 17,950 | 797 | 53 | ܁? | ܁` |  |  |
| 458 | 1.05.03.02.03.03 | L4 - MICE Step V-VI Magnetic Shielding Detailed Engineering | milestone | 0d | 2016-03-31 | 2016-03-31 | 456, 457 | 2016-03-31 | 2016-03-31 | 0d | 12d | 0d |  |  |  |  | 574 | 53 | ܁? |  |  |  |
| 459 | 1.05.03.02.03.04 | (RISK)-(R2) - MICE Step V-VI Magnetic Shielding 2 Week Review Window | milestone | 0d | 2016-03-31 | 2016-03-31 | 458 | 2016-03-31 | 2016-03-31 | 0d | 12d | 0d |  |  |  |  | 1011 | 53 | ܁? |  | R2 | 13 |
| 460 | 1.05.03.02.03.05 | MICE Step V-VI Magnetic Shielding 2 Week Review Window - Possible Costs for this R2 Risk (UID-1011) |  | 1d | 2016-03-31 | 2016-03-31 | 459FS-1d | 2016-03-31 | 2016-03-31 | 1d | 663d |  |  |  |  |  | 1126 | 53 | ܁= |  |  | 13 |
| 461 | 1.05.03.02.04 | **MICE Step V-VI Magnetic Shielding Fabricate Parts** |  | 128d | 2016-04-01 | 2016-09-30 |  | 2016-04-01 | 2016-09-30 | 128d | 12d |  |  |  | 439,020 | 439,020 | 575 | 53 |  |  |  |  |
| 462 | 1.05.03.02.04.01 | MICE Step V-VI Magnetic Shielding Fabricate Parts (BNL - Resources) |  | 128d | 2016-04-01 | 2016-09-30 | 458, 459 | 2016-04-01 | 2016-09-30 | 128d | 12d | 0d |  |  |  |  | 706 | 53 | ܁? | ܁` |  |  |
| 463 | 1.05.03.02.04.02 | MICE Step V-VI Magnetic Shielding Fabricate Parts (BNL - M&S) |  | 128d | 2016-04-01 | 2016-09-30 | 462SS | 2016-04-01 | 2016-09-30 | 128d | 535d |  | BNL_M&S |  | 439,020 | 439,020 | 799 | 53 | ܁? | ܁` |  |  |
| 464 | 1.05.03.02.05 | **MICE Step V-VI Magnetic Shielding Shipped to RAL** |  | 187d | 2016-07-01 | 2017-03-31 |  | 2016-07-01 | 2017-03-31 | 187d | 12d |  |  |  |  |  | 1000 | 53 |  |  |  |  |
| 465 | 1.05.03.02.05.01 | MICE Step V-VI Magnetic Shielding Shipped to RAL (BNL - Resources) |  | 187d | 2016-07-01 | 2017-03-31 | 462SS+64d | 2016-07-01 | 2017-03-31 | 187d | 12d | 0d |  |  |  |  | 1001 | 53 | ܁? | ܁` |  |  |
| 466 | 1.05.03.02.05.02 | MICE Step V-VI Magnetic Shielding Shipped to RAL (BNL - M&S) |  | 187d | 2016-07-01 | 2017-03-31 | 465SS | 2016-07-01 | 2017-03-31 | 187d | 12d | 0d |  |  |  |  | 1002 | 53 | ܁? | ܁` |  |  |
| 467 | 1.05.03.02.05.03 | L4 - MICE Step V-VI Magnetic Shielding Received at RAL | milestone | 0d | 2017-03-31 | 2017-03-31 | 465, 466 | 2017-03-31 | 2017-03-31 | 0d | 12d | 0d |  |  |  |  | 1003 | 53 | ܁? |  |  |  |
| 468 | 1.05.03.02.06 | **MICE Step V Magnetic Shielding Installation at RAL** |  | 190d | 2017-01-03 | 2017-09-29 |  | 2017-01-03 | 2017-09-29 | 190d | 285d |  |  |  |  |  | 1004 | 53 |  |  |  |  |
| 469 | 1.05.03.02.06.01 | MICE Step V Magnetic Shielding Installation at RAL (BNL - Resources) |  | 190d | 2017-01-03 | 2017-09-29 | 465SS+124d | 2017-01-03 | 2017-09-29 | 190d | 285d | 0d |  |  |  |  | 1005 | 53 | ܁? | ܁` |  |  |
| 470 | 1.05.03.02.06.02 | MICE Step V Magnetic Shielding Installation at RAL (BNL - M&S) |  | 190d | 2017-01-03 | 2017-09-29 | 469SS | 2017-01-03 | 2017-09-29 | 190d | 285d |  |  |  |  |  | 1006 | 53 | ܁? | ܁` |  |  |
| 471 | 1.05.03.02.07 | **MICE Step VI Magnetic Shielding Installation at RAL** |  | 186d | 2017-07-03 | 2018-03-30 |  | 2017-07-03 | 2018-03-30 | 186d | 162d |  |  |  |  |  | 1007 | 53 |  |  |  |  |
| 472 | 1.05.03.02.07.01 | MICE Step VI Magnetic Shielding Installation at RAL (BNL - Resources) |  | 186d | 2017-07-03 | 2018-03-30 | 467FS+64d | 2017-07-03 | 2018-03-30 | 186d | 162d | 0d |  |  |  |  | 1008 | 53 | ܁? | ܁` |  |  |
| 473 | 1.05.03.02.07.02 | MICE Step VI Magnetic Shielding Installation at RAL (BNL - M&S) |  | 186d | 2017-07-03 | 2018-03-30 | 472SS | 2017-07-03 | 2018-03-30 | 186d | 162d |  |  |  |  |  | 1009 | 53 | ܁? | ܁` |  |  |
| 474 | 1.05.03.02.08 | L4 - MICE V-VI Magnetic Shielding - Complete | milestone | 0d | 2018-03-30 | 2018-03-30 | 450, 453, 456, 462, 465, 469, 472 | 2018-03-30 | 2018-03-30 | 0d | 162d |  |  |  |  |  | 992 | 53 | ܁? |  |  |  |

Notes:
- 449: Predecessor Before Merge 23,116
- 459: IMPACT:(Likely impact is inability to operate MICE Step V-VI resulting in no remittance reduction measurement from MICE unless drastic re-engineering of the MICE Hall were implemented. In such a scenario, would likely be a showstopper further effort)

| ID | WBS | Task | Duration | Start | Finish | Predecessors | Complete | Remaining | Baseline start | Baseline finish | Baseline duration | Total slack | Free slack | Resources | Work | Cost | Baseline cost | Actual cost | BOE Number | MAP WBS | CobraUID | WBS-L3 Text18 | Resp Instit Name/Code | Funding Type |
| --- | --- | --- | --- | --- | --- | --- | --- | --- | --- | --- | --- | --- | --- | --- | --- | --- | --- | --- | --- | --- | --- | --- | --- | --- |
| 475 | 1.05.04 | **MICE Detector Design, Fabrication and Testing** | 1755d | 2011-10-03 A | 2018-09-28 |  | 24% | 1339.76d | 2011-10-03 | 2018-09-28 | 1755d | 35d |  |  | 958h | 320,474 | 320,474 | 45,500 | BOE-1.05.04 | 29M.05.04 | 591 | 54 |  |  |
| 476 | 1.05.04.01 | **MICE Detectors (US Contributions)** | 1505d | 2012-10-01 A | 2018-09-28 |  | 19% | 1222.67d | 2012-10-01 | 2018-09-28 | 1505d | 35d |  |  | 958h | 230,474 | 230,474 |  |  |  | 663 | 54 |  |  |
| 477 | 1.05.04.01.01 | **MICE-US Tracker Detector** | 1505d | 2012-10-01 A | 2018-09-28 |  | 8% | 1379.5d | 2012-10-01 | 2018-09-28 | 1505d | 35d |  |  | 958h | 170,524 | 170,524 |  |  |  | 664 | 54 |  |  |
| 478 | 1.05.04.01.01.01 | MICE-US Tracker Detector FY13 (FNAL - Labor) | 251d | 2012-10-01 A | 2013-09-30 | 21FS-15d | 50% | 125.5d | 2012-10-01 | 2013-09-30 | 251d | 35d | 0d |  |  |  |  |  |  |  | 682 | 54 | ܁= | ܁" |
| 479 | 1.05.04.01.01.02 | MICE-US Tracker Detector FY13 (FNAL - M&S) | 251d | 2012-10-01 A | 2013-09-30 | 478SS | 50% | 125.5d | 2012-10-01 | 2013-09-30 | 251d | 35d | 0d |  |  |  |  |  |  |  | 800 | 54 | ܁= | ܁" |
| 480 | 1.05.04.01.01.03 | MICE-US Tracker Detector FY14 FNAL - Labor) | 251d | 2013-10-01 | 2014-09-30 | 478, 479 |  |  | 2013-10-01 | 2014-09-30 | 251d | 35d | 0d | FNAD_MAGNT_DESIGN_EN [29%] | 589h | 104,842 | 104,842 |  |  |  | 1050 | 54 | ܁= | ܁" |
| 481 | 1.05.04.01.01.04 | MICE-US Tracker Detector FY14 (FNAL - M&S) | 251d | 2013-10-01 | 2014-09-30 | 480SS |  |  | 2013-10-01 | 2014-09-30 | 251d | 35d | 0d |  |  |  |  |  |  |  | 1051 | 54 | ܁= | ܁" |
| 482 | 1.05.04.01.01.05 | MICE-US Tracker Detector FY15 (FNAL - Labor) | 251d | 2014-10-01 | 2015-09-30 | 480, 481 |  |  | 2014-10-01 | 2015-09-30 | 251d | 35d | 0d | FNAD_MAGNT_DESIGN_EN [7%] | 147h | 26,166 | 26,166 |  |  |  | 1052 | 54 | ܁= | ܁" |
| 483 | 1.05.04.01.01.06 | MICE-US Tracker Detector FY15 (FNAL - M&S) | 251d | 2014-10-01 | 2015-09-30 | 482SS |  |  | 2014-10-01 | 2015-09-30 | 251d | 35d | 0d |  |  |  |  |  |  |  | 1053 | 54 | ܁= | ܁" |
| 484 | 1.05.04.01.01.07 | MICE-US Tracker Detector FY16 (FNAL - Labor) | 252d | 2015-10-01 | 2016-09-30 | 482, 483 |  |  | 2015-10-01 | 2016-09-30 | 252d | 35d | 0d | FNAD_MAGNT_DESIGN_EN [4%] | 74h | 13,172 | 13,172 |  |  |  | 1054 | 54 | ܁= | ܁" |
| 485 | 1.05.04.01.01.08 | MICE-US Tracker Detector FY16 (FNAL - M&S) | 252d | 2015-10-01 | 2016-09-30 | 484SS |  |  | 2015-10-01 | 2016-09-30 | 252d | 35d | 0d |  |  |  |  |  |  |  | 1055 | 54 | ܁= | ܁" |
| 486 | 1.05.04.01.01.09 | MICE-US Tracker Detector FY17 (FNAL - Labor) | 250d | 2016-10-03 | 2017-09-29 | 484, 485 |  |  | 2016-10-03 | 2017-09-29 | 250d | 35d | 0d | FNAD_MAGNT_DESIGN_EN [4%] | 74h | 13,172 | 13,172 |  |  |  | 1056 | 54 | ܁= | ܁" |
| 487 | 1.05.04.01.01.10 | MICE-US Tracker Detector FY17 (FNAL - M&S) | 250d | 2016-10-03 | 2017-09-29 | 486SS |  |  | 2016-10-03 | 2017-09-29 | 250d | 35d | 0d |  |  |  |  |  |  |  | 1057 | 54 | ܁= | ܁" |
| 488 | 1.05.04.01.01.11 | MICE-US Tracker Detector FY18 (FNAL - Labor) | 250d | 2017-10-02 | 2018-09-28 | 486, 487 |  |  | 2017-10-02 | 2018-09-28 | 250d | 35d | 0d | FNAD_MAGNT_DESIGN_EN [4%] | 74h | 13,172 | 13,172 |  |  |  | 1058 | 54 | ܁= | ܁" |
| 489 | 1.05.04.01.01.12 | MICE-US Tracker Detector FY18 (FNAL - M&S) | 250d | 2017-10-02 | 2018-09-28 | 488SS |  |  | 2017-10-02 | 2018-09-28 | 250d | 35d |  |  |  |  |  |  |  |  | 1059 | 54 | ܁= | ܁" |
| 490 | 1.05.04.01.02 | **MICE-US Cherenkov Detector** | 502d | 2012-10-01 A | 2014-09-30 |  | 50% | 251d | 2012-10-01 | 2014-09-30 | 502d | 1038d |  |  |  | 59,950 | 59,950 |  |  |  | 667 | 54 |  |  |
| 491 | 1.05.04.01.02.01 | MICE-US Cherenkov Detector FY13 (FNAL - Labor) | 251d | 2012-10-01 A | 2013-09-30 A | 21FS-15d | 100% |  | 2012-10-01 | 2013-09-30 | 251d |  |  |  |  |  |  |  |  |  | 683 | 54 | ܁= | ܁" |
| 492 | 1.05.04.01.02.02 | MICE-US Cherenkov Detector FY13 (FNAL - M&S) | 251d | 2012-10-01 A | 2013-09-30 A | 491SS | 100% |  | 2012-10-01 | 2013-09-30 | 251d |  |  |  |  |  |  |  |  |  | 801 | 54 | ܁= | ܁" |
| 493 | 1.05.04.01.02.03 | MICE-US Cherenkov Detector FY14 (FNAL - Labor) | 251d | 2013-10-01 | 2014-09-30 | 491, 492 |  |  | 2013-10-01 | 2014-09-30 | 251d | 1038d | 0d |  |  |  |  |  |  |  | 1060 | 54 | ܁= | ܁" |
| 494 | 1.05.04.01.02.04 | MICE-US Cherenkov Detector FY14 (FNAL - M&S) | 251d | 2013-10-01 | 2014-09-30 | 493SS |  |  | 2013-10-01 | 2014-09-30 | 251d | 1038d |  | FN_M&S_STND_FY12 |  | 59,950 | 59,950 |  |  |  | 1061 | 54 | ܁= | ܁" |
| 495 | 1.05.04.02 | **MICE Absorbers (US Contributions)** | 521d | 2011-10-03 A | 2013-10-28 |  | 74% | 134.93d | 2011-10-03 | 2013-10-28 | 521d | 1269d |  |  |  | 90,000 | 90,000 | 45,500 |  |  | 665 | 54 |  |  |
| 496 | 1.05.04.02.01 | **MICE-US LiH Disk Fabrication** | 125d | 2011-10-03 A | 2012-04-03 A |  | 100% |  | 2011-10-03 | 2012-04-03 | 125d |  |  |  |  |  |  |  |  |  | 666 | 54 |  |  |
| 497 | 1.05.04.02.01.01 | MICE-US LiH Disk Fabrication (FNAL - Labor) | 125d | 2011-10-03 A | 2012-04-03 A | 19 | 100% |  | 2011-10-03 | 2012-04-03 | 125d |  |  |  |  |  |  |  |  |  | 684 | 54 | ܁= | ܁" |
| 498 | 1.05.04.02.01.02 | MICE-US LiH Disk Fabrication (FNAL - M&S) | 125d | 2011-10-03 A | 2012-04-03 A | 497SS | 100% |  | 2011-10-03 | 2012-04-03 | 125d |  |  |  |  |  |  |  |  |  | 802 | 54 | ܁= | ܁" |

| ID | WBS | Task | Type | Duration | Start | Finish | Predecessors | Complete | Remaining | Baseline start | Baseline finish | Baseline duration | Total slack | Free slack | Resources | Work | Cost | Baseline cost | Actual cost | CobraUID | WBS-L3 Text18 | Resp Instit Name/Code | Funding Type | BOE Number | MAP WBS | Milestone Levels | Risk ID |
| --- | --- | --- | --- | --- | --- | --- | --- | --- | --- | --- | --- | --- | --- | --- | --- | --- | --- | --- | --- | --- | --- | --- | --- | --- | --- | --- | --- |
| 499 | 1.05.04.02.02 | **MICE-US LiH Shipping** |  | 20d | 2013-06-13 | 2013-07-11 |  |  |  | 2013-06-13 | 2013-07-11 | 20d | 1345d |  |  |  | 10,000 | 10,000 |  | 668 | 54 |  |  |  |  |  |  |
| 500 | 1.05.04.02.02.01 | MICE-US LiH Shipping - (FNAL - Labor) |  | 20d | 2013-06-13 | 2013-07-11 | 497FS+300d |  |  | 2013-06-13 | 2013-07-11 | 20d | 1345d |  |  |  |  |  |  | 685 | 54 | ܁= | ܁" |  |  |  |  |
| 501 | 1.05.04.02.02.02 | MICE-US LiH Shipping - (FNAL - M&S) |  | 20d | 2013-06-13 | 2013-07-11 | 497FS+300d |  |  | 2013-06-13 | 2013-07-11 | 20d | 1345d |  | FN_M&S_STND_FY12 |  | 10,000 | 10,000 |  | 803 | 54 | ܁= | ܁" |  |  |  |  |
| 502 | 1.05.04.02.03 | **MICE-US LiH Wedge Fabrication** |  | 30d | 2012-10-01 A | 2012-11-09 |  | 65% | 10.5d | 2012-10-01 | 2012-11-09 | 30d | 1510d |  |  |  | 70,000 | 70,000 | 45,500 | 669 | 54 |  |  |  |  |  |  |
| 503 | 1.05.04.02.03.01 | MICE-US LiH Wedge Fabrication (FNAL - Labor) |  | 30d | 2012-10-01 A | 2012-11-09 | 21FS-15d | 65% | 10.5d | 2012-10-01 | 2012-11-09 | 30d | 1510d | 0d |  |  |  |  |  | 686 | 54 | ܁= | ܁" |  |  |  |  |
| 504 | 1.05.04.02.03.02 | MICE-US LiH Wedge Fabrication (FNAL - M&S) |  | 30d | 2012-10-01 A | 2012-11-09 | 503SS | 65% | 10.5d | 2012-10-01 | 2012-11-09 | 30d | 1510d |  | FN_M&S_STND_FY12 |  | 70,000 | 70,000 | 45,500 | 804 | 54 | ܁= | ܁" |  |  |  |  |
| 505 | 1.05.04.02.04 | **MICE-US LiH Wedge Shipping** |  | 20d | 2013-10-01 | 2013-10-28 |  |  |  | 2013-10-01 | 2013-10-28 | 20d | 1269d |  |  |  | 10,000 | 10,000 |  | 670 | 54 |  |  |  |  |  |  |
| 506 | 1.05.04.02.04.01 | MICE-US LiH Wedge Shipping (FNAL - Labor) |  | 20d | 2013-10-01 | 2013-10-28 | 22FS-15d |  |  | 2013-10-01 | 2013-10-28 | 20d | 1269d | 0d |  |  |  |  |  | 687 | 54 | ܁= | ܁" |  |  |  |  |
| 507 | 1.05.04.02.04.02 | MICE-US LiH Wedge Shipping (FNAL - M&S) |  | 20d | 2013-10-01 | 2013-10-28 | 506SS |  |  | 2013-10-01 | 2013-10-28 | 20d | 1269d |  | FN_M&S_STND_FY12 |  | 10,000 | 10,000 |  | 805 | 54 | ܁= | ܁" |  |  |  |  |
| 508 | 1.05.05 | **MICE US Component Integration** |  | 1540d | 2012-10-01 | 2018-11-16 |  |  |  | 2012-10-01 | 2018-11-16 | 1540d | 0d |  |  | 10673h | 1,461,809 | 1,461,809 |  | 590 | 55 |  |  | BOE-1.05.05 | 29M.05.05 |  |  |
| 509 | 1.05.05.01 | **MICE-US RF Component Integration** |  | 937d | 2015-03-02 | 2018-11-16 |  |  |  | 2015-03-02 | 2018-11-16 | 937d | 0d |  |  |  |  |  |  | 659 | 55 |  |  |  |  |  |  |
| 510 | 1.05.05.01.01 | MICE-US RFCC_Lite Component Integration (FNAL - Labor) |  | 250d | 2015-03-02 | 2016-02-26 | 349 |  |  | 2015-03-02 | 2016-02-26 | 250d | 87d | 0d |  |  |  |  |  | 1072 | 55 | ܁= | ܁" |  |  |  |  |
| 511 | 1.05.05.01.02 | MICE-US RFCC_Lite Component Integration (FNAL - M&S) |  | 250d | 2015-03-02 | 2016-02-26 | 510SS |  |  | 2015-03-02 | 2016-02-26 | 250d | 87d | 0d |  |  |  |  |  | 1073 | 55 | ܁= | ܁" |  |  |  |  |
| 512 | 1.05.05.01.03 | (RISK)-(R4) - RFCC_Lite Component Integration | milestone | 0d | 2016-02-26 | 2016-02-26 | 510, 511 |  |  | 2016-02-26 | 2016-02-26 | 0d | 687d |  |  |  |  |  |  | 708 | 55 | ܁= |  |  |  | R4 |  |
| 513 | 1.05.05.01.04 | MICE-US RFCC#1 Component Integration (FNAL - Labor) |  | 100d | 2017-03-22 | 2017-08-10 | 389FS+60d, 25FS-14d |  |  | 2017-03-22 | 2017-08-10 | 100d | 320d | 0d |  |  |  |  |  | 688 | 55 | ܁= | ܁" |  |  |  |  |
| 514 | 1.05.05.01.05 | MICE-US RFCC#1 Component Integration (FNAL - M&S) |  | 100d | 2017-03-22 | 2017-08-10 | 513SS |  |  | 2017-03-22 | 2017-08-10 | 100d | 320d | 0d |  |  |  |  |  | 806 | 55 | ܁= | ܁" |  |  |  |  |
| 515 | 1.05.05.01.06 | (RISK)-(R4) - RFCC#1 Component Integration | milestone | 0d | 2017-08-10 | 2017-08-10 | 513, 514 |  |  | 2017-08-10 | 2017-08-10 | 0d | 320d |  |  |  |  |  |  | 1078 | 55 | ܁= |  |  |  | R4 |  |
| 516 | 1.05.05.01.07 | MICE-US RFCC#2 Component Integration (FNAL - Labor) |  | 100d | 2018-06-28 | 2018-11-16 | 414FS+60d, 26FS-15d |  |  | 2018-06-28 | 2018-11-16 | 100d | 0d |  |  |  |  |  |  | 1062 | 55 | ܁= | ܁" |  |  |  |  |
| 517 | 1.05.05.01.08 | MICE-US RFCC#2 Component Integration (FNAL - M&S) |  | 100d | 2018-06-28 | 2018-11-16 | 516SS |  |  | 2018-06-28 | 2018-11-16 | 100d | 0d |  |  |  |  |  |  | 1063 | 55 | ܁= | ܁" |  |  |  |  |
| 518 | 1.05.05.02 | **MICE-US SS Component Integration** |  | 400d | 2013-09-24 | 2015-04-29 |  |  |  | 2013-09-24 | 2015-04-29 | 400d | 294d |  |  |  |  |  |  | 660 | 55 |  |  |  |  |  |  |
| 519 | 1.05.05.02.01 | MICE-US SS#1 & SS#2 Component Integration (FNAL - Labor) |  | 400d | 2013-09-24 | 2015-04-29 | 197, 200 |  |  | 2013-09-24 | 2015-04-29 | 400d | 294d | 0d |  |  |  |  |  | 689 | 55 | ܁= | ܁" |  |  |  |  |
| 520 | 1.05.05.02.02 | MICE-US SS#1 & SS#2 Component Integration (FNAL - M&S) |  | 400d | 2013-09-24 | 2015-04-29 | 519SS |  |  | 2013-09-24 | 2015-04-29 | 400d | 294d | 0d |  |  |  |  |  | 807 | 55 | ܁= | ܁" |  |  |  |  |
| 521 | 1.05.05.02.03 | (RISK)-(R3) - MICE-US SS Component Integration | milestone | 0d | 2015-04-29 | 2015-04-29 | 519, 520 |  |  | 2015-04-29 | 2015-04-29 | 0d | 894d | 0d |  |  |  |  |  | 1074 | 55 | ܁= |  |  |  | R3 | 7, 15 |
| 522 | 1.05.05.02.04 | MICE-US SS Component Integration - Possible Costs for this R3 Risk (UID-1074) |  | 1d | 2015-04-29 | 2015-04-29 | 521FS-1d |  |  | 2015-04-29 | 2015-04-29 | 1d | 894d |  |  |  |  |  |  | 1127 | 55 | ܁= |  |  |  |  | 7, 15 |

Notes:
- 512: IMPACT:() - ACTION:()
- 515: IMPACT:() - ACTION:()
- 521: IMPACT:(Impacts include delayed magnet training and subsequently difficulty commissioning the full cooling channel beam line)(Likely impact is a 6-12 month delay in MICE Step V readiness) - ACTION:(Continued improvements of SC magnet controls)

| ID | WBS | Task | Type | Duration | Start | Finish | Predecessors | Baseline start | Baseline finish | Baseline duration | Total slack | Free slack | Resources | Work | Cost | Baseline cost | CobraUID | WBS-L3 Text18 | Resp Instit Name/Code | Funding Type | Milestone Levels | Risk ID |
| --- | --- | --- | --- | --- | --- | --- | --- | --- | --- | --- | --- | --- | --- | --- | --- | --- | --- | --- | --- | --- | --- | --- |
| 523 | 1.05.05.03 | **MICE-US CC Component Integration** |  | 677d | 2016-02-29 | 2018-11-02 |  | 2016-02-29 | 2018-11-02 | 677d | 10d |  |  |  |  |  | 661 | 55 |  |  |  |  |
| 524 | 1.05.05.03.01 | MICE-US RFCC#1 Component Integration (FNAL - Labor) |  | 350d | 2016-02-29 | 2017-07-18 | 389FS-300d, 511, 520, 24FS-14d | 2016-02-29 | 2017-07-18 | 350d | 87d | 0d |  |  |  |  | 690 | 55 | ܁= | ܁" |  |  |
| 525 | 1.05.05.03.02 | MICE-US RFCC#1 Component Integration (FNAL - M&S) |  | 350d | 2016-02-29 | 2017-07-18 | 524SS, 511, 520 | 2016-02-29 | 2017-07-18 | 350d | 87d | 0d |  |  |  |  | 808 | 55 | ܁= | ܁" |  |  |
| 526 | 1.05.05.03.03 | (RISK)-(R2) - MICE-US CC Component Integration | milestone | 0d | 2017-07-18 | 2017-07-18 | 524, 525 | 2017-07-18 | 2017-07-18 | 0d | 337d | 0d |  |  |  |  | 1075 | 55 | ܁= |  | R2 | 16, 17 |
| 527 | 1.05.05.03.04 | MICE-US CC Component Integration - Possible Costs for this R2 Risk (UID-1075) |  | 1d | 2017-07-18 | 2017-07-18 | 526FS-1d | 2017-07-18 | 2017-07-18 | 1d | 337d |  |  |  |  |  | 1128 | 55 | ܁= |  |  | 1573085 |
| 528 | 1.05.05.03.05 | MICE-US RFCC#2 Component Integration (FNAL - Labor) |  | 250d | 2017-11-06 | 2018-11-02 | 414FS-100d, 26FS-15d | 2017-11-06 | 2018-11-02 | 250d | 10d | 0d |  |  |  |  | 1066 | 55 | ܁= | ܁" |  |  |
| 529 | 1.05.05.03.06 | MICE-US RFCC#2 Component Integration (FNAL - M&S) |  | 250d | 2017-11-06 | 2018-11-02 | 528SS, 525 | 2017-11-06 | 2018-11-02 | 250d | 10d |  |  |  |  |  | 1067 | 55 | ܁= | ܁" |  |  |
| 530 | 1.05.05.04 | **MICE-US Shielding Component Integration** |  | 1156d | 2014-04-01 | 2018-11-02 |  | 2014-04-01 | 2018-11-02 | 1156d | 10d |  |  |  |  |  | 662 | 55 |  |  |  |  |
| 531 | 1.05.05.04.01 | MICE-US Shielding Step IV Component Integration (FNAL - Labor) |  | 250d | 2014-04-01 | 2015-03-30 | 22FS+60d, 443 | 2014-04-01 | 2015-03-30 | 250d | 516d | 0d |  |  |  |  | 691 | 55 | ܁= | ܁" |  |  |
| 532 | 1.05.05.04.02 | MICE-US Shielding Step IV Component Integration (FNAL - M&S) |  | 250d | 2014-04-01 | 2015-03-30 | 531SS | 2014-04-01 | 2015-03-30 | 250d | 516d | 0d |  |  |  |  | 809 | 55 | ܁= | ܁" |  |  |
| 533 | 1.05.05.04.03 | (RISK)-(R3) - MICE-US Shielding Step IV Component Integration | milestone | 0d | 2015-03-30 | 2015-03-30 | 531, 532 | 2015-03-30 | 2015-03-30 | 0d | 916d | 0d |  |  |  |  | 1076 | 55 | ܁= |  | R3 | 14 |
| 534 | 1.05.05.04.04 | MICE-US Shielding Step IV Component Integration - Possible Costs for this R3 Risk (UID-1076) |  | 1d | 2015-03-30 | 2015-03-30 | 533FS-1d | 2015-03-30 | 2015-03-30 | 1d | 916d |  |  |  |  |  | 1129 | 55 | ܁= |  |  | 14 |
| 535 | 1.05.05.04.05 | MICE-US Shielding Step V Component Integration (FNAL - Labor) |  | 250d | 2017-04-03 | 2018-03-30 | 467, 532 | 2017-04-03 | 2018-03-30 | 250d | 12d | 0d |  |  |  |  | 1068 | 55 | ܁= | ܁" |  |  |
| 536 | 1.05.05.04.06 | MICE-US Shielding Step V Component Integration (FNAL - M&S) |  | 250d | 2017-04-03 | 2018-03-30 | 535SS, 532 | 2017-04-03 | 2018-03-30 | 250d | 12d | 0d |  |  |  |  | 1069 | 55 | ܁= | ܁" |  |  |
| 537 | 1.05.05.04.07 | (RISK)-(R3) - MICE-US Shielding Step V Component Integration | milestone | 0d | 2018-03-30 | 2018-03-30 | 535, 536 | 2018-03-30 | 2018-03-30 | 0d | 162d | 0d |  |  |  |  | 1077 | 55 | ܁= |  | R3 | 18 |
| 538 | 1.05.05.04.08 | MICE-US Shielding Step V Component Integration - Possible Costs for this R3 Risk (UID-1077) |  | 1d | 2018-03-30 | 2018-03-30 | 537FS-1d | 2018-03-30 | 2018-03-30 | 1d | 162d |  |  |  |  |  | 1130 | 55 | ܁= |  |  | 18 |
| 539 | 1.05.05.04.09 | MICE-US Shielding Step VI Component Integration (FNAL - Labor) |  | 150d | 2018-04-04 | 2018-11-02 | 414, 536 | 2018-04-04 | 2018-11-02 | 150d | 10d | 0d |  |  |  |  | 1070 | 55 | ܁= | ܁" |  |  |
| 540 | 1.05.05.04.10 | MICE-US Shielding Step VI Component Integration (FNAL - M&S) |  | 150d | 2018-04-04 | 2018-11-02 | 539SS, 536 | 2018-04-04 | 2018-11-02 | 150d | 10d |  |  |  |  |  | 1071 | 55 | ܁= | ܁" |  |  |
| 541 | 1.05.05.05 | **MICE-US Component Integration (Cost for Coordination & Oversight for above Integration Tasks)** |  | 1505d | 2012-10-01 | 2018-09-28 |  | 2012-10-01 | 2018-09-28 | 1505d | 35d |  |  | 10673h | 1,461,809 | 1,461,809 | 1095 | 55 |  |  |  |  |
| 542 | 1.05.05.05.01 | MICE-US Component Integration Cost FY13 (FNAL - Labor) |  | 251d | 2012-10-01 | 2013-09-30 | 21FS-15d | 2012-10-01 | 2013-09-30 | 251d | 35d | 0d | FNAP_PT_EXP_PHYST [4%]; FNUN_P_POSTDOC [22%] | 508h | 51,646 | 51,646 | 1096 | 55 | ܁= | ܁" |  |  |
| 543 | 1.05.05.05.02 | MICE-US Component Integration Cost FY13 (FNAL - M&S) |  | 251d | 2012-10-01 | 2013-09-30 | 542SS | 2012-10-01 | 2013-09-30 | 251d | 35d | 0d | FN_M&S_STND_FY12 |  | 17,928 | 17,928 | 1097 | 55 | ܁= | ܁" |  |  |
| 544 | 1.05.05.05.03 | MICE-US Component Integration Cost FY14 (FNAL - Labor) |  | 251d | 2013-10-01 | 2014-09-30 | 542, 543 | 2013-10-01 | 2014-09-30 | 251d | 35d | 0d | FNAP_PT_EXP_PHYST [13%]; FNUN_P_POSTDOC [88%] | 2033h | 206,737 | 206,737 | 1098 | 55 | ܁= | ܁" |  |  |
| 545 | 1.05.05.05.04 | MICE-US Component Integration Cost FY14 (FNAL - M&S) |  | 251d | 2013-10-01 | 2014-09-30 | 544SS | 2013-10-01 | 2014-09-30 | 251d | 35d | 0d | FN_M&S_STND_FY12 |  | 71,710 | 71,710 | 1099 | 55 | ܁= | ܁" |  |  |
| 546 | 1.05.05.05.05 | MICE-US Component Integration Cost FY15 (FNAL - Labor) |  | 251d | 2014-10-01 | 2015-09-30 | 544, 545 | 2014-10-01 | 2015-09-30 | 251d | 35d | 0d | FNAP_PT_EXP_PHYST [13%]; FNUN_P_POSTDOC [88%] | 2033h | 206,737 | 206,737 | 1100 | 55 | ܁= | ܁" |  |  |
| 547 | 1.05.05.05.06 | MICE-US Component Integration Cost FY15 (FNAL - M&S) |  | 251d | 2014-10-01 | 2015-09-30 | 546SS | 2014-10-01 | 2015-09-30 | 251d | 35d | 0d | FN_M&S_STND_FY12 |  | 71,710 | 71,710 | 1101 | 55 | ܁= | ܁" |  |  |
| 548 | 1.05.05.05.07 | MICE-US Component Integration Cost FY16 (FNAL - Labor) |  | 252d | 2015-10-01 | 2016-09-30 | 546, 547 | 2015-10-01 | 2016-09-30 | 252d | 35d | 0d | FNAP_PT_EXP_PHYST [13%]; FNUN_P_POSTDOC [88%] | 2033h | 206,737 | 206,737 | 1102 | 55 | ܁= | ܁" |  |  |
| 549 | 1.05.05.05.08 | MICE-US Component Integration Cost FY16 (FNAL - M&S) |  | 252d | 2015-10-01 | 2016-09-30 | 548SS | 2015-10-01 | 2016-09-30 | 252d | 35d | 0d | FN_M&S_STND_FY12 |  | 71,710 | 71,710 | 1103 | 55 | ܁= | ܁" |  |  |
| 550 | 1.05.05.05.09 | MICE-US Component Integration Cost FY17 (FNAL - Labor) |  | 250d | 2016-10-03 | 2017-09-29 | 548, 549 | 2016-10-03 | 2017-09-29 | 250d | 35d | 0d | FNAP_PT_EXP_PHYST [13%]; FNUN_P_POSTDOC [88%] | 2033h | 206,737 | 206,737 | 1104 | 55 | ܁= | ܁" |  |  |
| 551 | 1.05.05.05.10 | MICE-US Component Integration Cost FY17 (FNAL - M&S) |  | 250d | 2016-10-03 | 2017-09-29 | 550SS | 2016-10-03 | 2017-09-29 | 250d | 35d | 0d | FN_M&S_STND_FY12 |  | 71,710 | 71,710 | 1105 | 55 | ܁= | ܁" |  |  |
| 552 | 1.05.05.05.11 | MICE-US Component Integration Cost FY18 (FNAL - Labor) |  | 250d | 2017-10-02 | 2018-09-28 | 550, 551 | 2017-10-02 | 2018-09-28 | 250d | 35d | 0d | FNAP_PT_EXP_PHYST [13%]; FNUN_P_POSTDOC [88%] | 2033h | 206,737 | 206,737 | 1106 | 55 | ܁= | ܁" |  |  |
| 553 | 1.05.05.05.12 | MICE-US Component Integration Cost FY18 (FNAL - M&S) |  | 250d | 2017-10-02 | 2018-09-28 | 552SS | 2017-10-02 | 2018-09-28 | 250d | 35d |  | FN_M&S_STND_FY12 |  | 71,710 | 71,710 | 1107 | 55 | ܁= | ܁" |  |  |

Notes:
- 526: IMPACT:(RF Integration problems)(Likely impact is a 6-12 month delay in MICE Step V readiness) - ACTION:(Re-visit integration issues and correct)
- 533: IMPACT:(Likely impact is a 6 month delay in MICE Step IV data) - ACTION:(Re-do integration engineering for partial yoke solution in MICE Hall)
- 537: IMPACT:(Likely impact is a 6-12 month delay in MICE Step V readiness) - ACTION:(Re-visit integration issues and correct)
